# GSTOP_rev 1

Schedule from MS Project, 2004-10-20 to 2006-06-30, status date 2005-03-23, A marks actual dates.
GSTOP Project Plan

## Calendars

- Standard: Mon-Fri 08:00-12:00, 13:00-17:00; Sat-Sun off.

## Resources

| Resource |
| --- |
| GTG |
| GTG Exec Comm |
| Symbol Subteam |
| NWCG Training Team |
| GSTOP Team |
| NWCG Member Agencies |
| Reviewers |
| GSTOP Subteam(s) |
| all concerned/impacted parties |
| Business Community |
| BLM publication shop |
| Business Lead |
| Business Lead |
| FGDC |
| NARA |
| GeoMAC |
| NPS I&M |
| NPS Focus |
| IRMWT |
| Project Mgr |
| Sean Triplett |
| IMT Teams |
| GTAG |
| Firescope |
| NWCG Agency |
| FEMA |
| GACC guidelines |
| Ken Bottle |
| Subteam Lead |
| Victoria Smith |
| Deb Epps |
| Independent Reviewer |
| GSTOP Exec Comm |
| John Guthrie |
| Karen Folger |
| Sherry Durst |
| Kim Kelly |
| Luther Arizana |
| Emmor Nile |
| Sue McLellan |
| StdProd Subteam |
| GIST Qual/GIS Min Expec Subteam |
| Elise Browne |
| MED Subteam |
| Eric |
| DataShareArcTrans Subteam |
| GTG Standards Committee |
| Internet Search |
| Military |
| etc. |
| survey GISTs |
| Plans Sections (Mary Kwart) |
| Documents Sections |
| Mary Kwart |
| agency guidance |
| TBD |
| Sub-Team |
| Other "team" environs (e.g. military) |
| survey? Mary Kwart? |
| field teams |
| Susan Goodman |
| Other "team" environs |
| survey |
| NamConvSubteam |
| BLM Pulications |
| NWCG Working teams |
| NWCG PMO |
| Project Mgt |
| IMT Planning Section |
| Technical Specialists |
| NIIMS Group |
| Department of Homeland Security (DHS) |
| ESRI |
| Ken |
| Yvonne |
| BLM |
| GTG Joe Frost |

## Schedule

| ID | WBS | Task | Duration | Start | Finish | Predecessors | Complete | Baseline start | Baseline finish | Baseline duration | Constraint | Resources | Work | Actual work | Text1 |
| --- | --- | --- | --- | --- | --- | --- | --- | --- | --- | --- | --- | --- | --- | --- | --- |
| 1 | 1 | **Initiate the GSTOP Project** | 105d? | 2004-10-20 A | 2005-03-15 A |  | 100% | 2004-11-30 | 2004-12-01 | 2d |  | GTG Exec Comm | 5504h | 5504h |  |
| 2 | 1.1 | GSTOP Executive Committee Formed | 6d | 2004-12-01 A | 2004-12-08 A |  | 100% | 2004-12-01 | 2004-12-01 | 1d | finish no earlier than 2004-12-08 | IRMWT | 48h | 48h |  |
| 3 | 1.2 | GSTOP Project Manager Identified | 1d | 2004-10-20 A | 2004-10-20 A |  | 100% | 2004-11-30 | 2004-12-01 | 2d | finish no earlier than 2004-10-20 | GTG Exec Comm | 8h | 8h |  |
| 4 | 1.3 | GSTOP Project Charter Approved | 31d | 2004-10-20 A | 2004-12-01 A |  | 100% | 2004-12-01 | 2004-12-01 | 1d |  | NWCG Member Agencies | 248h | 248h | Project Charter |
| 5 | 1.4 | Secure GSTOP Project Funding | 68d | 2004-12-01 A | 2005-03-04 A |  | 100% | 2004-12-01 | 2004-12-01 | 1d | finish no earlier than 2005-03-04 | NWCG Member Agencies | 544h | 544h |  |
| 6 | 1.5 | **Identify GSTOP Project Team** | 74d? | 2004-12-02 A | 2005-03-15 A |  | 100% | 2004-12-01 | 2004-12-01 | 1d |  | GTG Exec Comm | 3816h | 3816h | Team Roster |
| 7 | 1.5.1 | **Form the GSTOP Team** | 74d? | 2004-12-02 A | 2005-03-15 A | 4 | 100% | 2004-12-01 | 2004-12-31 | 22d? |  | GTG Exec Comm | 3224h | 3224h |  |
| 8 | 1.5.1.1 | GSTOP Project Business Lead Identified | 29d | 2004-12-15 A | 2005-01-24 A |  | 100% | 2004-12-31 | 2004-12-31 | 0d | finish no earlier than 2005-01-24 | Project Mgr | 232h | 232h |  |
| 9 | 1.5.1.2 | Define and Assign Project Subteams and Leads | 5d? | 2004-12-02 A | 2004-12-08 A |  | 100% | 2004-12-01 | 2004-12-01 | 1d? |  | Project Mgr | 40h | 40h |  |
| 10 | 1.5.1.3 | Develop Project Team Operating Principles & Guidelines | 5d? | 2004-12-02 A | 2004-12-08 A |  | 100% | 2004-12-01 | 2004-12-01 | 1d? |  | Project Mgr | 40h | 40h | Operating Principles Doc |
| 11 | 1.5.1.4 | **Develop the GSTOP Project Management Plans** | 74d? | 2004-12-02 A | 2005-03-15 A |  | 100% | 2004-12-01 | 2004-12-06 | 4d? |  | Project Mgr | 1976h | 1976h |  |
| 12 | 1.5.1.4.1 | Review Charter and resolve any ambiguities/issues | 51d? | 2004-12-02 A | 2005-02-10 A |  | 100% | 2004-12-01 | 2004-12-01 | 1d? |  | Project Mgr | 408h | 408h | Updated Charter |
| 13 | 1.5.1.4.2 | Develop Intial Project Work Plan | 50d? | 2004-12-02 A | 2005-02-09 A |  | 100% | 2004-12-01 | 2004-12-01 | 1d? |  | Project Mgr | 400h | 400h | Work Plan |
| 14 | 1.5.1.4.3 | Develop Intial Project Communication Plan | 72d | 2004-12-06 A | 2005-03-15 A |  | 100% | 2004-12-06 | 2004-12-06 | 1d | finish no earlier than 2005-03-15 | Business Lead | 576h | 576h | Communication Plan |
| 15 | 1.5.1.4.4 | Develop Intial Project Responsibility Matrix | 1d? | 2004-12-02 A | 2004-12-02 A |  | 100% | 2004-12-01 | 2004-12-01 | 1d? |  |  |  |  |  |
| 16 | 1.5.1.4.5 | Develop Intial Project Resource Plan | 31d? | 2004-12-02 A | 2005-01-13 A |  | 100% | 2004-12-01 | 2004-12-01 | 1d? |  |  |  |  | Staffing Plan |
| 17 | 1.5.1.5 | **Setup the project team's structures for communication** | 42d? | 2004-12-02 A | 2005-01-28 A |  | 100% | 2004-12-01 | 2004-12-01 | 1d? |  | Business Lead | 344h | 344h |  |
| 18 | 1.5.1.5.1 | Create GSTOP private team workspace | 1d? | 2004-12-02 A | 2004-12-02 A |  | 100% | 2004-12-01 | 2004-12-01 | 1d? |  | Sean Triplett | 8h | 8h | Accessible Workspace |
| 19 | 1.5.1.5.2 | Develop Project Status Report Template | 42d? | 2004-12-02 A | 2005-01-28 A |  | 100% | 2004-12-01 | 2004-12-01 | 1d? |  |  |  |  |  |
| 20 | 2 | **GSTOP Requirements** | 142d? | 2004-12-01 A | 2005-06-16 A | 1 | 100% | 2004-12-31 | 2005-01-18 | 13d? |  | GSTOP Team | 8223.33h | 8223.33h |  |
| 21 | 2.1 | **Incident GIS Standard Symbology** | 142d? | 2004-12-01 A | 2005-06-16 A |  | 100% | 2004-12-31 | 2005-01-05 | 4d? |  | Ken Bottle | 2528h | 2528h |  |
| 22 | 2.1.1 | **Establish Symbols Sub-Team business practices** | 58d? | 2005-01-12 A | 2005-04-01 A |  | 100% | 2004-12-31 | 2004-12-31 | 1d? |  |  | 424h | 424h |  |
| 23 | 2.1.1.1 | **Develop a Symbol Sub-team Communication Plan** | 53d? | 2005-01-12 A | 2005-03-25 A |  | 100% | 2004-12-31 | 2004-12-31 | 1d? |  | Ken Bottle | 424h | 424h | Communication Plan |
| 24 | 2.1.1.1.1 | Define ground-rules for Sub-Team (internal) communication | 53d? | 2005-01-12 A | 2005-03-25 A |  | 100% | 2004-12-31 | 2004-12-31 | 1d? | finish no earlier than 2005-03-25 |  |  |  |  |
| 25 | 2.1.1.1.2 | Define ground-rules for communication between the Symbol Sub-Team and other GSTOP Sub-Teams | 53d? | 2005-01-12 A | 2005-03-25 A |  | 100% | 2004-12-31 | 2004-12-31 | 1d? | finish no earlier than 2005-03-25 |  |  |  |  |
| 26 | 2.1.1.1.3 | Define ground rules for communication between the Sub-Team and entities outside of the GSTOP Project | 53d? | 2005-01-12 A | 2005-03-25 A |  | 100% | 2004-12-31 | 2004-12-31 | 1d? | finish no earlier than 2005-03-25 |  |  |  |  |
| 27 | 2.1.1.1.4 | Establish a process and schedule for Sub-Team (internal) progress report updates | 53d? | 2005-01-12 A | 2005-03-25 A |  | 100% | 2004-12-31 | 2004-12-31 | 1d? | finish no earlier than 2005-03-25 |  |  |  |  |
| 28 | 2.1.1.1.5 | Establish a process and schedule for Sub-Team progress report updates to the GSTOP Team | 53d? | 2005-01-12 A | 2005-03-25 A |  | 100% | 2004-12-31 | 2004-12-31 | 1d? | finish no earlier than 2005-03-25 |  |  |  |  |

| ID | WBS | Task | Duration | Start | Finish | Predecessors | Complete | Baseline start | Baseline finish | Baseline duration | Constraint | Resources | Work | Actual work | Text1 |
| --- | --- | --- | --- | --- | --- | --- | --- | --- | --- | --- | --- | --- | --- | --- | --- |
| 29 | 2.1.1.2 | **Establish Review Processes** | 58d? | 2005-01-12 A | 2005-04-01 A |  | 100% | 2004-12-31 | 2004-12-31 | 1d? |  |  |  |  | Symbol Set Review Process |
| 30 | 2.1.1.2.1 | Establish a process for Sub-Team (internal) review of potential symbols | 58d? | 2005-01-12 A | 2005-04-01 A |  | 100% | 2004-12-31 | 2004-12-31 | 1d? | finish no earlier than 2005-04-01 |  |  |  |  |
| 31 | 2.1.1.2.2 | Establish a process for Sub-Team (internal) review of the draft standard symbols | 58d? | 2005-01-12 A | 2005-04-01 A |  | 100% | 2004-12-31 | 2004-12-31 | 1d? | finish no earlier than 2005-04-01 |  |  |  |  |
| 32 | 2.1.1.2.3 | Establish a process for peer reviews | 58d? | 2005-01-12 A | 2005-04-01 A |  | 100% | 2004-12-31 | 2004-12-31 | 1d? | finish no earlier than 2005-04-01 |  |  |  |  |
| 33 | 2.1.1.2.4 | Establish a process for periodic GSTOP Team reviews | 58d? | 2005-01-12 A | 2005-04-01 A |  | 100% | 2004-12-31 | 2004-12-31 | 1d? | finish no earlier than 2005-04-01 |  |  |  |  |
| 34 | 2.1.1.2.5 | Establish a process for reviewing the final report | 58d? | 2005-01-12 A | 2005-04-01 A |  | 100% | 2004-12-31 | 2004-12-31 | 1d? | finish no earlier than 2005-04-01 |  |  |  |  |
| 35 | 2.1.1.3 | **Establish Change processes** | 58d? | 2005-01-12 A | 2005-04-01 A |  | 100% | 2004-12-31 | 2004-12-31 | 1d? |  |  |  |  | Symbol Set Change Process |
| 36 | 2.1.1.3.1 | Establish a process for additions/deletions of potential symbols mid-stream through the Project | 58d? | 2005-01-12 A | 2005-04-01 A |  | 100% | 2004-12-31 | 2004-12-31 | 1d? |  |  |  |  |  |
| 37 | 2.1.1.3.2 | Establish a change process for the additions/deletion of standard symbols after the final recommendation has been submitted and prior to completion of the GSTOP project | 58d? | 2005-01-12 A | 2005-04-01 A | 36 | 100% | 2004-12-31 | 2004-12-31 | 1d? |  |  |  |  |  |
| 38 | 2.1.1.3.3 | Establish a change process for the additions/deletion of standard symbols after the completion of the GSTOP project | 58d? | 2005-01-12 A | 2005-04-01 A | 37 | 100% | 2004-12-31 | 2004-12-31 | 1d? |  |  |  |  |  |
| 39 | 2.1.2 | **Develop GIS Standard Symbology SOP Requirements** | 49d? | 2005-02-01 A | 2005-04-08 A |  | 100% |  |  |  |  |  | 408h | 408h |  |
| 40 | 2.1.2.1 | **Establish symbol evaluation methods** | 12d? | 2005-03-17 A | 2005-04-01 A |  | 100% | 2004-12-31 | 2004-12-31 | 1d? |  |  |  |  |  |
| 41 | 2.1.2.1.1 | Define method for evaluating marker symbols | 12d? | 2005-03-17 A | 2005-04-01 A |  | 100% | 2004-12-31 | 2004-12-31 | 1d? | finish no earlier than 2005-04-01 |  |  |  |  |
| 42 | 2.1.2.1.2 | Define method for evaluating line symbols | 12d? | 2005-03-17 A | 2005-04-01 A |  | 100% | 2004-12-31 | 2004-12-31 | 1d? | finish no earlier than 2005-04-01 |  |  |  |  |
| 43 | 2.1.2.1.3 | Define method for evaluating fill symbols | 12d? | 2005-03-17 A | 2005-04-01 A |  | 100% | 2004-12-31 | 2004-12-31 | 1d? | finish no earlier than 2005-04-01 |  |  |  |  |
| 44 | 2.1.2.1.4 | Conduct a final review of evaluation methods | 12d? | 2005-03-17 A | 2005-04-01 A |  | 100% | 2004-12-31 | 2004-12-31 | 1d? | finish no earlier than 2005-04-01 |  |  |  | Standard Symbol Evaluation Methodology |
| 45 | 2.1.2.2 | **Define criteria for the acceptance of symbols as standards** | 17d? | 2005-03-17 A | 2005-04-08 A |  | 100% | 2004-12-31 | 2004-12-31 | 1d? |  | John Guthrie; Karen Folger; Ken Bottle | 408h | 408h |  |
| 46 | 2.1.2.2.1 | Develop acceptance criteria for marker symbols | 17d? | 2005-03-17 A | 2005-04-08 A |  | 100% | 2004-12-31 | 2004-12-31 | 1d? | finish no earlier than 2005-04-08 |  |  |  |  |
| 47 | 2.1.2.2.2 | Develop acceptance criteria for line symbols | 17d? | 2005-03-17 A | 2005-04-08 A |  | 100% | 2004-12-31 | 2004-12-31 | 1d? | finish no earlier than 2005-04-08 |  |  |  |  |
| 48 | 2.1.2.2.3 | Develop acceptance criteria for fill symbols | 17d? | 2005-03-17 A | 2005-04-08 A |  | 100% | 2004-12-31 | 2004-12-31 | 1d? | finish no earlier than 2005-04-08 |  |  |  |  |
| 49 | 2.1.2.2.4 | Conduct a final review of selection criteria | 17d? | 2005-03-17 A | 2005-04-08 A |  | 100% | 2004-12-31 | 2004-12-31 | 1d? | finish no earlier than 2005-04-08 |  |  |  | Standard Symbol Acceptance Criteria |
| 50 | 2.1.2.3 | **Establish file format for symbols** | 44d? | 2005-02-01 A | 2005-04-01 A |  | 100% | 2004-12-31 | 2004-12-31 | 1d? |  |  |  |  |  |
| 51 | 2.1.2.3.1 | Define acceptable formats of symbols for evaluation | 44d? | 2005-02-01 A | 2005-04-01 A |  | 100% | 2004-12-31 | 2004-12-31 | 1d? | finish no earlier than 2005-04-01 |  |  |  |  |
| 52 | 2.4.1.2 | Define format of recommended standard symbols | 44d? | 2005-02-01 A | 2005-04-01 A |  | 100% | 2004-12-31 | 2004-12-31 | 1d? | finish no earlier than 2005-04-01 |  |  |  |  |

| ID | WBS | Task | Type | Duration | Start | Finish | Predecessors | Complete | Baseline start | Baseline finish | Baseline duration | Constraint | Resources | Work | Actual work | Text1 |
| --- | --- | --- | --- | --- | --- | --- | --- | --- | --- | --- | --- | --- | --- | --- | --- | --- |
| 53 | 2.1.3 | **Develop Draft GIS Standard Symbology SOPs** |  | 125d? | 2004-12-01 A | 2005-05-24 A | 39 | 100% |  |  |  |  |  | 464h | 464h |  |
| 54 | 2.1.3.1 | **Develop a list of symbols to be evaluated for acceptance as draft standards** |  | 101d? | 2004-12-01 A | 2005-04-20 A |  | 100% | 2004-12-31 | 2004-12-31 | 1d? |  |  | 168h | 168h |  |
| 55 | 2.1.3.1.1 | Collect Fire mapping symbols from the Fireline Handbook |  | 81d? | 2004-12-01 A | 2005-03-23 A |  | 100% | 2004-12-31 | 2004-12-31 | 1d? |  |  |  |  | symbol image files |
| 56 | 2.1.3.1.2 | Collect Fire mapping symbols suggestions from the 5 federal fire management agencies (FS, BLM, NPS, FWS, BIA) and state agencies |  | 81d? | 2004-12-01 A | 2005-03-23 A |  | 100% | 2004-12-31 | 2004-12-31 | 1d? |  |  |  |  | symbol image files |
| 57 | 2.1.3.1.3 | Collect Fire mapping symbols suggestions from the BIA |  | 7d? | 2005-04-11 A | 2005-04-19 A | 56 | 100% | 2004-12-31 | 2004-12-31 | 1d? | finish no earlier than 2005-04-01 | Kim Kelly; Luther Arizana | 112h | 112h | symbol image files |
| 58 | 2.1.3.1.4 | Collect Fire mapping symbols from HSA (FEMA), FAA |  | 81d? | 2004-12-01 A | 2005-03-23 A |  | 100% | 2004-12-31 | 2004-12-31 | 1d? |  |  |  |  | symbol image files |
| 59 | 2.1.3.1.5 | Collect Fire mapping symbols from HSA (FEMA), FAA, and DOD |  | 7d? | 2005-04-11 A | 2005-04-19 A | 58 | 100% | 2004-12-31 | 2004-12-31 | 1d? | finish no earlier than 2005-04-01 | Sherry Durst | 56h | 56h | symbol image files |
| 60 | 2.1.3.1.6 | Document potential sources for additional fire mapping symbols |  | 1d? | 2005-04-11 A | 2005-04-11 A |  | 100% | 2004-12-31 | 2004-12-31 | 1d? |  |  |  |  | List of data sources |
| 61 | 2.1.3.1.7 | Compile symbols into a single potential symbol set |  | 1d? | 2005-04-20 A | 2005-04-20 A | 55, 56, 57, 58 | 100% | 2004-12-31 | 2004-12-31 | 1d? |  |  |  |  | Set of potential standard symbols |
| 62 | 2.1.3.2 | **Determine the draft standard marker symbols** |  | 8d? | 2005-04-21 A | 2005-05-02 A | 54 | 100% | 2004-12-31 | 2004-12-31 | 1d? |  |  | 72h | 72h |  |
| 63 | 2.1.3.2.1 | Evaluate each potential marker symbol against the marker symbol selection criteria |  | 1d? | 2005-04-21 A | 2005-04-21 A |  | 100% | 2004-12-31 | 2004-12-31 | 1d? |  |  |  |  | Marker Symbol Evaluation Document |
| 64 | 2.1.3.2.2 | Selection the draft standard marker symbols |  | 1d? | 2005-04-21 A | 2005-04-21 A |  | 100% | 2004-12-31 | 2004-12-31 | 1d? |  | Symbol Subteam | 8h | 8h | Draft list of selected marker symbols |
| 65 | 2.1.3.2.3 | Conduct a completeness review of the draft standard marker symbols |  | 8d? | 2005-04-21 A | 2005-05-02 A |  | 100% | 2004-12-31 | 2004-12-31 | 1d? | finish no earlier than 2005-04-14 | Symbol Subteam | 64h | 64h | Draft Standard Marker Symbols document |
| 66 | 2.1.3.3 | **Determine the draft standard line symbols** |  | 8d? | 2005-04-21 A | 2005-05-02 A | 54 | 100% | 2004-12-31 | 2004-12-31 | 1d? |  |  | 72h | 72h |  |
| 67 | 2.1.3.3.1 | Evaluate each potential line symbol against the line symbol selection criteria |  | 1d? | 2005-04-21 A | 2005-04-21 A |  | 100% | 2004-12-31 | 2004-12-31 | 1d? |  |  |  |  | Line Symbol Evaluation Document |
| 68 | 2.1.3.3.2 | Select the draft standard line symbols |  | 1d? | 2005-04-21 A | 2005-04-21 A |  | 100% | 2004-12-31 | 2004-12-31 | 1d? |  | Symbol Subteam | 8h | 8h | Draft list of selected Line symbols |
| 69 | 2.1.3.3.3 | Conduct a completeness review of the draft standard line symbols |  | 8d? | 2005-04-21 A | 2005-05-02 A |  | 100% | 2004-12-31 | 2004-12-31 | 1d? | finish no earlier than 2005-04-14 | Symbol Subteam | 64h | 64h | Draft Standard Line Symbols document |
| 70 | 2.1.3.4 | **Determine the draft standard fill symbols** |  | 8d? | 2005-04-21 A | 2005-05-02 A | 54 | 100% | 2004-12-31 | 2004-12-31 | 1d? |  |  | 72h | 72h |  |
| 71 | 2.1.3.4.1 | Evaluate each potential fill symbol against the fill symbol selection criteria |  | 1d? | 2005-04-21 A | 2005-04-21 A |  | 100% | 2004-12-31 | 2004-12-31 | 1d? |  |  |  |  | Fill Symbol Evaluation Document |
| 72 | 2.1.3.4.2 | Select the draft standard fill symbols |  | 1d? | 2005-04-21 A | 2005-04-21 A |  | 100% | 2004-12-31 | 2004-12-31 | 1d? |  | Symbol Subteam | 8h | 8h | Draft list of selected fill symbols |
| 73 | 2.1.3.4.3 | Conduct a completeness review of the draft standard fill symbols |  | 8d? | 2005-04-21 A | 2005-05-02 A |  | 100% | 2004-12-31 | 2004-12-31 | 1d? | finish no earlier than 2005-04-14 | Symbol Subteam | 64h | 64h | Draft Standard fill Symbols document |
| 74 | 2.1.3.5 | **Conduct initial peer review of the draft standard marker, line, and fill symbols** |  | 16d? | 2005-05-03 A | 2005-05-24 A | 62, 66, 70 | 100% | 2004-12-31 | 2005-01-05 | 4d? |  |  | 80h | 80h |  |
| 75 | 2.1.3.5.1 | Prepare draft standard symbols for initial peer review |  | 1d? | 2005-05-03 A | 2005-05-03 A |  | 100% | 2004-12-31 | 2004-12-31 | 1d? |  |  |  |  | Initial Peer Review Package |
| 76 | 2.1.3.5.2 | Submit the draft standard symbols to the 5 federal fire management agencies and State agencies via the NWCG Geospatial Task Group (GTG); and to the HSA (FEMA), FAA, DOD, and GSTOP Team for peer review | milestone | 0d | 2005-05-03 A | 2005-05-03 A | 75 | 100% | 2004-12-31 | 2004-12-31 | 1d? |  |  |  |  | Submission Report |
| 77 | 2.1.3.5.3 | Review draft Standard Symbols |  | 5d | 2005-05-04 A | 2005-05-10 A | 76 | 100% |  |  |  |  | GSTOP Team; GTG | 80h | 80h | Initial Feedback on Standard Symbols |
| 78 | 2.1.3.5.4 | Review feedback of initial peer review |  | 2d | 2005-05-18 A | 2005-05-19 A | 76FS+10d | 100% | 2005-01-03 | 2005-01-03 | 1d? |  |  |  |  | Initial Peer Review Document |
| 79 | 2.1.3.5.5 | Identify required changes to draft standard symbols based on the initial peer review feedback |  | 2d | 2005-05-20 A | 2005-05-23 A | 78 | 100% | 2005-01-04 | 2005-01-04 | 1d? |  |  |  |  | List of required symbol changes |
| 80 | 2.1.3.5.6 | Make required changes, as identified, to draft standard symbols |  | 1d? | 2005-05-24 A | 2005-05-24 A | 79 | 100% | 2005-01-05 | 2005-01-05 | 1d? |  |  |  |  | Initial updated Symbols list |
| 81 | 2.1.3.6 | Prepare draft SOPs for field review |  | 1d? | 2005-04-19 A | 2005-04-19 A | 375 | 100% |  |  |  |  |  |  |  |  |

| ID | WBS | Task | Type | Duration | Start | Finish | Predecessors | Complete | Baseline start | Baseline finish | Baseline duration | Resources | Work | Actual work | Text1 |
| --- | --- | --- | --- | --- | --- | --- | --- | --- | --- | --- | --- | --- | --- | --- | --- |
| 82 | 2.1.4 | **Conduct final peer review of the draft standard marker, line and fill symbols** |  | 17d? | 2005-05-25 A | 2005-06-16 A | 74 | 100% | 2004-12-31 | 2004-12-31 | 1d? |  | 88h | 88h |  |
| 83 | 2.1.4.1 | Prepare draft standard symbols for final peer review |  | 1d? | 2005-05-25 A | 2005-05-25 A |  | 100% | 2004-12-31 | 2004-12-31 | 1d? |  |  |  | Final Peer Review Package |
| 84 | 2.1.4.2 | Submit the draft standard symbols to the 5 federal fire management agencies and State agencies via the NWCG Geospatial Task Group (GTG); and to the HSA (FEMA), FAA, DOD, and GSTOP Team for peer review | milestone | 0d | 2005-05-25 A | 2005-05-25 A | 83 | 100% | 2004-12-31 | 2004-12-31 | 1d? |  |  |  | Submission Report |
| 85 | 2.1.4.3 | Review draft Standard Symbols |  | 10d | 2005-05-26 A | 2005-06-08 A | 84 | 100% |  |  |  | Reviewers | 80h | 80h | Final Feedback on Standard Symbols |
| 86 | 2.1.4.4 | Review feedback of the final peer review |  | 1d? | 2005-06-09 A | 2005-06-09 A | 85 | 100% | 2004-12-31 | 2004-12-31 | 1d? |  |  |  | Final Peer Review Document |
| 87 | 2.1.4.5 | Identify required changes to draft standard symbols based on the final peer review feedback |  | 2d | 2005-06-10 A | 2005-06-13 A | 86 | 100% | 2004-12-31 | 2004-12-31 | 1d? |  |  |  | List of required symbol changes |
| 88 | 2.1.4.6 | Make required changes, as identified, to draft standard symbols |  | 2d | 2005-06-14 A | 2005-06-15 A | 87 | 100% | 2004-12-31 | 2004-12-31 | 1d? |  |  |  | final updated symbols list |
| 89 | 2.1.4.7 | Ratify the final draft standard symbols |  | 1d? | 2005-06-16 A | 2005-06-16 A | 88 | 100% | 2004-12-31 | 2004-12-31 | 1d? | Symbol Subteam | 8h | 8h | Final Draft Standard Symbols List |
| 90 | 2.1.5 | **Finalize recommendation of standard Fire Mapping symbols** |  | 2d? | 2005-03-16 A | 2005-03-17 A |  | 100% | 2004-12-31 | 2004-12-31 | 1d? |  | 8h | 8h |  |
| 91 | 2.1.5.1 | Create a report recommending the adoption of the draft standard symbols |  | 1d? | 2005-03-16 A | 2005-03-16 A |  | 100% | 2004-12-31 | 2004-12-31 | 1d? |  |  |  | Recommendation Report |
| 92 | 2.1.5.2 | Conduct a review of the report |  | 1d? | 2005-03-17 A | 2005-03-17 A | 91 | 100% | 2004-12-31 | 2004-12-31 | 1d? | Symbol Subteam | 8h | 8h | Finalized Recommendation Report |
| 93 | 2.1.5.3 | Submit the report to GSTOP-PM | milestone | 0d | 2005-03-17 A | 2005-03-17 A | 92 | 100% | 2004-12-31 | 2004-12-31 | 1d |  |  |  | Report Submission |
| 94 | 2.2 | **Incident GIS Standard Naming Conventions** |  | 81d? | 2005-01-25 A | 2005-05-17 A |  | 100% | 2004-12-31 | 2005-01-06 | 5d? | Emmor Nile | 848h | 848h |  |
| 95 | 2.2.1 | **Develop GIS Naming Convention/Directory Structure Subteam Practices** |  | 1d? | 2005-03-16 A | 2005-03-16 A |  | 100% |  |  |  |  |  |  |  |
| 96 | 2.2.1.1 | Set objectives for work plan |  | 1d? | 2005-03-16 A | 2005-03-16 A |  | 100% |  |  |  |  |  |  | document |
| 97 | 2.2.1.2 | Define ground rules for sub team |  | 1d? | 2005-03-16 A | 2005-03-16 A |  | 100% |  |  |  |  |  |  | document |
| 98 | 2.2.1.3 | Define common ground with other sub teams |  | 1d? | 2005-03-16 A | 2005-03-16 A |  | 100% |  |  |  |  |  |  | communications agreement |
| 99 | 2.2.2 | **Develop GIS Standard Naming Convention SOP Requirements** |  | 62d? | 2005-01-25 A | 2005-04-20 A |  | 100% |  |  |  |  | 64h | 64h |  |
| 100 | 2.2.2.1 | Define Information Needs (What do we need to gather?) |  | 1d? | 2005-03-16 A | 2005-03-16 A |  | 100% | 2004-12-31 | 2004-12-31 | 1d? |  |  |  |  |
| 101 | 2.2.2.2 | Collect existing naming and filing conventions from GIST's attached to IMT's |  | 1d? | 2005-03-17 A | 2005-03-17 A | 100 | 100% |  |  |  |  |  |  | physical examples |
| 102 | 2.2.2.3 | **Conduct Analysis** |  | 2d? | 2005-03-16 A | 2005-03-17 A |  | 100% | 2005-01-04 | 2005-01-04 | 1d? |  |  |  |  |
| 103 | 2.2.2.3.1 | Review strengths & weaknesses of existing methodologies |  | 1d? | 2005-03-16 A | 2005-03-16 A |  | 100% |  |  |  |  |  |  | shared |
| 104 | 2.2.2.3.2 | Resolve overlap and conflicts |  | 1d? | 2005-03-17 A | 2005-03-17 A | 103 | 100% |  |  |  |  |  |  |  |
| 105 | 2.2.2.4 | **Develop Preliminary Requirements for GIS Naming Convention and Directory Structure** |  | 3d? | 2005-01-25 A | 2005-01-27 A | 104 | 100% | 2005-01-05 | 2005-01-05 | 1d? |  | 48h | 48h | GIS Naming Convention Guidelines |
| 106 | 2.2.2.4.1 | Draft naming convention guidelines/requirements |  | 3d? | 2005-01-25 A | 2005-01-27 A |  | 100% |  |  |  | NamConvSubteam | 24h | 24h |  |
| 107 | 2.2.2.4.2 | Draft directory structure guidelines/requirements |  | 3d? | 2005-01-25 A | 2005-01-27 A | 106 | 100% |  |  |  | NamConvSubteam | 24h | 24h |  |

| ID | WBS | Task | Type | Duration | Start | Finish | Predecessors | Complete | Baseline start | Baseline finish | Baseline duration | Constraint | Resources | Work | Actual work |
| --- | --- | --- | --- | --- | --- | --- | --- | --- | --- | --- | --- | --- | --- | --- | --- |
| 108 | 2.2.2.5 | **Review and Validate Requirements** |  | 11d? | 2005-04-05 A | 2005-04-19 A | 107 | 100% | 2005-01-06 | 2005-01-06 | 1d? |  |  | 16h | 16h |
| 109 | 2.2.2.5.1 | Post draft guidelines/requirements for GIS Naming Convention and Directory Structure for inter team review |  | 3d? | 2005-04-05 A | 2005-04-07 A |  | 100% |  |  |  |  |  |  |  |
| 110 | 2.2.2.5.2 | Review of draft guidelines/Requirements for GIS Naming Convention and Directory Structure |  | 1d | 2005-04-15 A | 2005-04-15 A | 109 | 100% |  |  |  | finish no earlier than 2005-04-15 | GSTOP Team | 8h | 8h |
| 111 | 2.2.2.5.3 | Edit draft guidelines/Requirements based on team input |  | 1d | 2005-04-18 A | 2005-04-18 A | 110 | 100% |  |  |  |  | NamConvSubteam | 8h | 8h |
| 112 | 2.2.2.5.4 | Post draft guidelines/Requirements for external review |  | 1d? | 2005-04-19 A | 2005-04-19 A | 111 | 100% |  |  |  |  |  |  |  |
| 113 | 2.2.2.6 | Draft GIS Naming Convention/Directory Structure Requirements developed | milestone | 1d? | 2005-04-20 A | 2005-04-20 A | 108 | 100% |  |  |  |  |  |  |  |
| 114 | 2.2.3 | **Develop Draft GIS Standard Naming Convention SOPs** |  | 55d? | 2005-02-10 A | 2005-04-27 A | 99 | 100% |  |  |  |  |  |  |  |
| 115 | 2.2.3.1 | **Prepare Sample of Naming Conventions and Directory Structure** |  | 52d? | 2005-02-10 A | 2005-04-22 A |  | 100% |  |  |  |  |  |  |  |
| 116 | 2.2.3.1.1 | Prepare Naming conventions |  | 1d? | 2005-02-10 A | 2005-02-10 A |  | 100% |  |  |  |  |  |  |  |
| 117 | 2.2.3.1.2 | Develop Directory structure | milestone | 0d? | 2005-02-10 A | 2005-02-10 A |  | 100% |  |  |  |  |  |  |  |
| 118 | 2.2.3.1.3 | Prepare Methods of work |  | 1d? | 2005-04-21 A | 2005-04-21 A |  | 100% |  |  |  |  |  |  |  |
| 119 | 2.2.3.1.4 | Prepare draft SOPs for field review |  | 1d? | 2005-04-22 A | 2005-04-22 A | 116, 117, 118, 375 | 100% |  |  |  |  |  |  |  |
| 120 | 2.2.3.2 | **Sample Documents/draft SOPs Review and Validation** |  | 3d? | 2005-04-25 A | 2005-04-27 A | 115 | 100% |  |  |  |  |  |  |  |
| 121 | 2.2.3.2.1 | Post sample documents for inter team review |  | 1d? | 2005-04-25 A | 2005-04-25 A |  | 100% |  |  |  |  |  |  |  |
| 122 | 2.2.3.2.2 | Edit sample documents based on input |  | 1d? | 2005-04-26 A | 2005-04-26 A | 121 | 100% |  |  |  |  |  |  |  |
| 123 | 2.2.3.2.3 | Draft GIS Naming Convention/Directory Structure SOPs developed | milestone | 1d? | 2005-04-27 A | 2005-04-27 A | 122 | 100% |  |  |  |  |  |  |  |
| 124 | 2.2.4 | **Conduct External Review of GIS Naming Standard/Directory Structure SOP requirements and draft SOPs** |  | 12d? | 2005-04-28 A | 2005-05-13 A | 114 | 100% |  |  |  |  |  | 128h | 128h |
| 125 | 2.2.4.1 | Design External Review of guidelines/requirements for GIS Naming Standards and Directory Structure |  | 2d? | 2005-04-28 A | 2005-04-29 A | 112 | 100% |  |  |  |  | Emmor Nile | 16h | 16h |
| 126 | 2.2.4.2 | Post sample documents/SOPs for external review |  | 5d? | 2005-05-02 A | 2005-05-06 A | 125 | 100% | 2004-12-31 | 2005-01-17 | 12d? |  |  |  |  |
| 127 | 2.2.4.3 | Conduct External review of Guidelines/Requirements and draft SOPs |  | 0.5d? | 2005-05-09 A | 2005-05-09 A | 126 | 100% |  |  |  |  | GTG; Reviewers | 8h | 8h |
| 128 | 2.2.4.4 | Edit draft guidelines/Requirements based on input |  | 1d? | 2005-04-28 A | 2005-04-28 A |  | 100% |  |  |  |  | NamConvSubteam | 8h | 8h |
| 129 | 2.2.4.5 | Edit sample documents/SOPs based on input |  | 12d? | 2005-04-28 A | 2005-05-13 A |  | 100% | 2004-12-31 | 2005-01-05 | 4d? |  | NamConvSubteam | 96h | 96h |
| 130 | 2.2.5 | **Finalize recommendation of GIS Standard Naming Conventions** |  | 2d? | 2005-05-16 A | 2005-05-17 A | 124 | 100% | 2004-12-31 | 2004-12-31 | 1d? |  |  | 8h | 8h |
| 131 | 2.2.5.1 | Create a report recommending the adoption of the standard |  | 1d? | 2005-05-16 A | 2005-05-16 A |  | 100% | 2004-12-31 | 2004-12-31 | 1d? |  |  |  |  |
| 132 | 2.2.5.2 | Conduct a review of the report |  | 1d? | 2005-05-17 A | 2005-05-17 A | 131 | 100% | 2004-12-31 | 2004-12-31 | 1d? |  | NamConvSubteam | 8h | 8h |
| 133 | 2.2.5.3 | Submit the report to GSTOP-PM | milestone | 0d | 2005-05-17 A | 2005-05-17 A | 132 | 100% | 2004-12-31 | 2004-12-31 | 1d |  |  |  |  |

Notes:
- 116: Text1: doc on disaster help
- 117: Text1: doc on disaster help
- 125: Text1: Plan for external review of GIS Naming Standards/Directory Structure requirements
- 128: Text1: final requirements
- 129: Text1: final SOPs
- 131: Text1: Recommendation Report
- 132: Text1: Finalized Recommendation Report
- 133: Text1: Report Submission

| ID | WBS | Task | Type | Duration | Start | Finish | Predecessors | Complete | Constraint | Resources | Work | Actual work | Text1 |
| --- | --- | --- | --- | --- | --- | --- | --- | --- | --- | --- | --- | --- | --- |
| 134 | 2.3 | **Incident GIS Standard Product Definitions** |  | 65d? | 2005-02-09 A | 2005-05-11 A |  | 100% |  | Karen Folger | 704h | 704h |  |
| 135 | 2.3.1 | **Develop GIS Standard Product Definitions SOP Requirements** |  | 52d? | 2005-02-09 A | 2005-04-22 A |  | 100% |  |  | 160h | 160h |  |
| 136 | 2.3.1.1 | **Define criteria for the acceptance of standard products definitions** |  | 2d? | 2005-03-16 A | 2005-03-17 A |  | 100% |  |  |  |  | Acceptance Criteria Set |
| 137 | 2.3.1.1.1 | Develop acceptance criteria for std products definitions |  | 1d? | 2005-03-16 A | 2005-03-16 A |  | 100% |  |  |  |  |  |
| 138 | 2.3.1.1.2 | Conduct a final review of selection criteria |  | 1d? | 2005-03-17 A | 2005-03-17 A | 137 | 100% |  |  |  |  | Standard Products Acceptance Criteria |
| 139 | 2.3.1.2 | **Define/Collect Information** |  | 25d? | 2005-02-09 A | 2005-03-16 A |  | 100% |  |  |  |  |  |
| 140 | 2.3.1.2.1 | Develop Standard Products Matrix to compare many versions of standard products. (GIST Draft Taskbook/GIST Course Workbook/PNWCG Product Objectives) | milestone | 0d? | 2005-02-09 A | 2005-02-09 A |  | 100% |  |  |  |  | Matrix Spreadsheet |
| 141 | 2.3.1.2.2 | Acquire DPRO Standards and incorporate into above matrix. | milestone | 0d? | 2005-03-01 A | 2005-03-01 A |  | 100% |  |  |  |  | Updated Matrix |
| 142 | 2.3.1.2.3 | Victoria Smith definitions/PNWCG definitions/DPRO defs. Compile these into a list for group to review. Cite source. | milestone | 0d? | 2005-03-01 A | 2005-03-01 A |  | 100% |  |  |  |  | List of Std Prods (draft) |
| 143 | 2.3.1.2.4 | Post for review including samples |  | 1d? | 2005-03-16 A | 2005-03-16 A | 142 | 100% |  |  |  |  | List posted to FTP site |
| 144 | 2.3.1.2.5 | Collect examples of new kinds of standard products that aren't in any of the existing definitions |  | 1d? | 2005-02-10 A | 2005-02-10 A |  | 100% | start no earlier than 2005-02-10 |  |  |  | Provide on ftp site |
| 145 | 2.3.1.3 | **Conduct Analysis** |  | 27d? | 2005-03-17 A | 2005-04-22 A | 139 | 100% |  |  | 160h | 160h |  |
| 146 | 2.3.1.3.1 | Define the meaning of product definitions - what goes into them? |  | 1d? | 2005-03-17 A | 2005-03-17 A |  | 100% |  |  |  |  |  |
| 147 | 2.3.1.3.2 | Create a draft template of what a product definition is |  | 1d? | 2005-03-23 A | 2005-03-23 A |  | 100% | finish no earlier than 2005-03-23 |  |  |  | Product Definition Template (draft) |
| 148 | 2.3.1.3.3 | Review existing standards definitions (Victoria/PNWCG/DPRO) & Identify discrepancies between groups defining standard |  | 10d | 2005-03-24 A | 2005-04-06 A | 147 | 100% |  |  |  |  | Discrepancy list |
| 149 | 2.3.1.3.4 | Highlight specific reasons for discrepancies (Fire Use vs. Type 1) if needed |  | 1d? | 2005-03-24 A | 2005-03-24 A | 147 | 100% |  |  |  |  |  |
| 150 | 2.3.1.3.5 | Bring these to the larger group for discussion and resolution |  | 10d | 2005-04-07 A | 2005-04-20 A | 149, 148, 147 | 100% |  | GSTOP Team; GTG | 160h | 160h |  |
| 151 | 2.3.1.3.6 | Gather responses from GSTOP and GTG; incorporte feedback |  | 1d? | 2005-04-21 A | 2005-04-21 A | 150 | 100% |  |  |  |  |  |
| 152 | 2.3.1.3.7 | Send out to wider folks for review (Field Test) |  | 1d? | 2005-04-22 A | 2005-04-22 A | 151 | 100% |  |  |  |  |  |
| 153 | 2.3.2 | **Develop draft GIS Standard Product Definition SOPs** |  | 1d? | 2005-04-25 A | 2005-04-25 A | 145 | 100% |  |  |  |  | Preliminary Package of Standard Products Definitions |
| 154 | 2.3.2.1 | Provide a package of draft products definitions and samples for review |  | 1d? | 2005-04-25 A | 2005-04-25 A |  | 100% |  |  |  |  | Preliminary package |
| 155 | 2.3.2.2 | Evaluate std products against acceptance criteria |  | 1d? | 2005-04-25 A | 2005-04-25 A |  | 100% |  |  |  |  |  |
| 156 | 2.3.2.3 | Provide data location and review process to internal group |  | 1d? | 2005-04-25 A | 2005-04-25 A |  | 100% |  |  |  |  | Submission report |
| 157 | 2.3.2.4 | Prepare draft SOPs for review |  | 1d? | 2005-04-25 A | 2005-04-25 A | 375 | 100% |  |  |  |  |  |

| ID | WBS | Task | Type | Duration | Start | Finish | Predecessors | Complete | Baseline start | Baseline finish | Baseline duration | Resources | Work | Actual work |
| --- | --- | --- | --- | --- | --- | --- | --- | --- | --- | --- | --- | --- | --- | --- |
| 158 | 2.3.3 | **Conduct External Review of draft GIS Standard Product Definition SOPs** |  | 10d? | 2005-04-26 A | 2005-05-09 A | 153 | 100% |  |  |  |  | 16h | 16h |
| 159 | 2.3.3.1 | **Conduct outside peer review of the draft standard products definitions** |  | 4d? | 2005-04-26 A | 2005-04-29 A |  | 100% |  |  |  |  | 8h | 8h |
| 160 | 2.3.3.1.1 | Submit the draft standard symbols to the 5 federal fire management agencies and State agencies via the NWCG Geospatial Task Group (GTG); and to the DHS (FEMA), FAA, DOD, and GSTOP Team for peer review |  | 1d? | 2005-04-26 A | 2005-04-26 A |  | 100% |  |  |  | GTG | 8h | 8h |
| 161 | 2.3.3.1.2 | Review feedback of initial peer review |  | 1d? | 2005-04-27 A | 2005-04-27 A | 160 | 100% |  |  |  |  |  |  |
| 162 | 2.3.3.1.3 | Identify required changes to draft standard products based on the initial peer review feedback |  | 1d? | 2005-04-28 A | 2005-04-28 A | 161 | 100% |  |  |  |  |  |  |
| 163 | 2.3.3.1.4 | Make required changes, as identified, to draft standard products |  | 1d? | 2005-04-29 A | 2005-04-29 A | 162 | 100% |  |  |  |  |  |  |
| 164 | 2.3.3.2 | **Conduct final peer review of the draft standard products** |  | 6d? | 2005-05-02 A | 2005-05-09 A | 159 | 100% |  |  |  |  | 8h | 8h |
| 165 | 2.3.3.2.1 | Prepare draft standard products for final peer review |  | 1d? | 2005-05-02 A | 2005-05-02 A |  | 100% |  |  |  |  |  |  |
| 166 | 2.3.3.2.2 | Submit the draft standard products to the 5 federal fire management agencies and State agencies via the NWCG Geospatial Task Group (GTG); and to the HSA (FEMA), FAA, DOD, and GSTOP Team for peer review |  | 1d? | 2005-05-03 A | 2005-05-03 A | 165 | 100% |  |  |  | GTG | 8h | 8h |
| 167 | 2.3.3.2.3 | Review feedback of the final peer review |  | 1d? | 2005-05-04 A | 2005-05-04 A | 166 | 100% |  |  |  |  |  |  |
| 168 | 2.3.3.2.4 | Identify required changes to draft standard products based on the final peer review feedback |  | 1d? | 2005-05-05 A | 2005-05-05 A | 167 | 100% |  |  |  |  |  |  |
| 169 | 2.3.3.2.5 | Make required changes, as identified, to draft standard products |  | 1d? | 2005-05-06 A | 2005-05-06 A | 168 | 100% |  |  |  |  |  |  |
| 170 | 2.3.3.2.6 | Ratify the final draft standard symbols |  | 1d? | 2005-05-09 A | 2005-05-09 A | 169 | 100% |  |  |  |  |  |  |
| 171 | 2.3.4 | **Finalize recommendation of standard Fire Mapping products** |  | 2d? | 2005-05-10 A | 2005-05-11 A | 164 | 100% |  |  |  |  | 8h | 8h |
| 172 | 2.3.4.1 | Create a report recommending the adoption of the draft standard product definitions |  | 1d? | 2005-05-10 A | 2005-05-10 A |  | 100% |  |  |  |  |  |  |
| 173 | 2.3.4.2 | Conduct a review of the report for completeness, accuracy, language, and grammar |  | 1d? | 2005-05-11 A | 2005-05-11 A | 172 | 100% |  |  |  | StdProd Subteam | 8h | 8h |
| 174 | 2.3.4.3 | Submit the report to GSTOP-PM | milestone | 0d | 2005-05-11 A | 2005-05-11 A | 173 | 100% |  |  |  |  |  |  |
| 175 | 2.3.4.4 | Find a permanent storage location for this package? National clearinghouse? |  | 1d? | 2005-05-10 A | 2005-05-10 A |  | 100% |  |  |  |  |  |  |
| 176 | 2.4 | **Incident GIST Minimum Qualifications & GIS Expectations** |  | 28.5d? | 2005-03-16 A | 2005-04-25 A |  | 100% | 2004-12-31 | 2005-01-06 | 5d? | Victoria Smith | 484h | 484h |
| 177 | 2.4.1 | **Develop Requirements for determining the GIST Minimum Qualifications & GIS Expectations** |  | 6.5d? | 2005-03-16 A | 2005-03-24 A |  | 100% |  |  |  |  | 176h | 176h |
| 178 | 2.4.1.1 | **Establish evaluation methods for minimum GIST qualifications/GIS expectations** |  | 1d? | 2005-03-16 A | 2005-03-16 A |  | 100% |  |  |  |  |  |  |
| 179 | 2.4.1.1.1 | Define method for evaluating minimum GIST qualifications/GIS expectations |  | 1d? | 2005-03-16 A | 2005-03-16 A |  | 100% |  |  |  |  |  |  |
| 180 | 2.4.1.1.2 | Conduct a final review of evaluation methods |  | 1d? | 2005-03-16 A | 2005-03-16 A |  | 100% |  |  |  |  |  |  |
| 181 | 2.4.1.2 | **Define criteria for the acceptance of minimum GIST qualifications/GIS expectations** |  | 1d? | 2005-03-16 A | 2005-03-16 A |  | 100% |  |  |  |  |  |  |
| 182 | 2.4.1.2.1 | Develop acceptance criteria for minimum GIST qualifications/GIS expectations |  | 1d? | 2005-03-16 A | 2005-03-16 A |  | 100% |  |  |  |  |  |  |
| 183 | 2.4.1.2.2 | Conduct a final review of selection criteria |  | 1d? | 2005-03-16 A | 2005-03-16 A |  | 100% |  |  |  |  |  |  |

Notes:
- 160: Text1: Submission Report
- 161: Text1: Initial Peer Review Document
- 162: Text1: List of required changes
- 163: Text1: Initial updated Products Definitions
- 165: Text1: Final Peer Review Package
- 166: Text1: Submission Report
- 167: Text1: Final Peer Review Document
- 168: Text1: List of required changes
- 169: Text1: final updated products list
- 170: Text1: Final Draft Standard Productss List
- 172: Text1: Recommendation Report
- 173: Text1: Finalized Recommendation Report
- 174: Text1: Report Submission
- 178: Text1: Evaluation Methodology for Minimum GIST Qualifications/GIS Expectations
- 181: Text1: Acceptance Criteria Set

| ID | WBS | Task | Duration | Start | Finish | Predecessors | Complete | Resources | Work | Actual work |
| --- | --- | --- | --- | --- | --- | --- | --- | --- | --- | --- |
| 184 | 2.4.1.3 | **Collect Information on minimum GIST qualifications and minimum GIS expectations on an incident** | 6.5d? | 2005-03-16 A | 2005-03-24 A |  | 100% |  | 176h | 176h |
| 185 | 2.4.1.3.1 | Gather documents and references (including white papers, memos, After Action Reviews, agency guidelines) | 6d? | 2005-03-16 A | 2005-03-23 A |  | 100% | GTAG; Firescope; NWCG Member Agencies | 144h | 144h |
| 186 | 2.4.1.3.2 | Obtain and review revised Taskbook | 0.5d? | 2005-03-24 A | 2005-03-24 A | 185 | 100% | John Guthrie; Victoria Smith | 8h | 8h |
| 187 | 2.4.1.3.3 | Scan or translate paper documents to electronic format | 1d? | 2005-03-16 A | 2005-03-16 A |  | 100% |  |  |  |
| 188 | 2.4.1.3.4 | Research current GIST/GIS standards | 1d? | 2005-03-16 A | 2005-03-16 A |  | 100% | FEMA; GACC guidelines; NWCG Agency | 24h | 24h |
| 189 | 2.4.2 | **Develop draft of GIST Minimum Qualifications & Expecations** | 12d? | 2005-03-24 A | 2005-04-11 A | 177 | 100% |  | 8h | 8h |
| 190 | 2.4.2.1 | **Develop a list of GIST qualifications to be evaluated for acceptance as draft minimum standards** | 3d? | 2005-03-24 A | 2005-03-29 A | 184 | 100% |  | 8h | 8h |
| 191 | 2.4.2.1.1 | Compare the current GIST standards | 1d? | 2005-03-24 A | 2005-03-25 A |  | 100% | Elise Browne | 8h | 8h |
| 192 | 2.4.2.1.2 | Compile the GIST qualifications into a single list of potential minimum GIST qualifications | 1d? | 2005-03-25 A | 2005-03-28 A | 191 | 100% |  |  |  |
| 193 | 2.4.2.1.3 | Compile a list of GIST qualifications which are deemed to be beyond the minimum for future reference | 1d? | 2005-03-28 A | 2005-03-29 A | 192 | 100% |  |  |  |
| 194 | 2.4.2.2 | **Determine the draft standard minimum GIST qualifications** | 3d? | 2005-03-29 A | 2005-04-01 A | 190 | 100% |  |  |  |
| 195 | 2.4.2.2.1 | Evaluate each potential minimum GIST qualification using the approved evaluation methods | 1d? | 2005-03-29 A | 2005-03-30 A | 178 | 100% |  |  |  |
| 196 | 2.4.2.2.2 | Select the minimum GIST qualifications | 1d? | 2005-03-30 A | 2005-03-31 A | 195 | 100% |  |  |  |
| 197 | 2.4.2.2.3 | Conduct a completeness review of the draft minimum GIST qualifications | 1d? | 2005-03-31 A | 2005-04-01 A | 196 | 100% |  |  |  |
| 198 | 2.4.2.3 | **Conduct internal review of draft standard minimum GIST qualifications & GIS expectations** | 6d? | 2005-04-01 A | 2005-04-11 A | 194 | 100% |  |  |  |
| 199 | 2.4.2.3.1 | Prepare draft standard minimum GIST qualifications and GIS expectations, including acceptance criteria | 1d? | 2005-04-01 A | 2005-04-04 A |  | 100% |  |  |  |
| 200 | 2.4.2.3.2 | Post draft standard to DisasterHelp website and notify GSTOP team for group review | 1d? | 2005-04-04 A | 2005-04-05 A | 199 | 100% |  |  |  |
| 201 | 2.4.2.3.3 | Provide data location and review process to internal group | 1d? | 2005-04-05 A | 2005-04-06 A | 200 | 100% |  |  |  |
| 202 | 2.4.2.3.4 | Review feedback of initial peer review | 1d? | 2005-04-06 A | 2005-04-07 A | 201 | 100% |  |  |  |
| 203 | 2.4.2.3.5 | Identify required changes to draft standard based on the initial peer review feedback | 1d? | 2005-04-07 A | 2005-04-08 A | 202 | 100% |  |  |  |
| 204 | 2.4.2.3.6 | Make required changes, as identified, to draft standard | 1d? | 2005-04-08 A | 2005-04-11 A | 203 | 100% |  |  |  |
| 205 | 2.4.3 | **Conduct final peer review of the draft standard minimum GIST qualifications & GIS expectations** | 7d? | 2005-04-11 A | 2005-04-20 A | 189 | 100% | GIST Qual/GIS Min Expec Subteam | 72h | 72h |
| 206 | 2.4.3.1 | Prepare survey or questionnaire to accompany draft standards for final peer review. | 1d? | 2005-04-11 A | 2005-04-12 A |  | 100% |  |  |  |
| 207 | 2.4.3.2 | Prepare draft standard minimum GIST Qualification/GIST expectations for final peer review, including the survey of results | 1d? | 2005-04-12 A | 2005-04-13 A | 206 | 100% |  |  |  |
| 208 | 2.4.3.3 | Submit the draft expectations to the 5 federal fire management agencies and State agencies via the NWCG Geospatial Task Group (GTG); and to the HSA (FEMA), FAA, DOD, and GSTOP Team for peer review. | 1d? | 2005-04-13 A | 2005-04-14 A | 207 | 100% | GTG | 8h | 8h |
| 209 | 2.4.3.4 | Review feedback of the final peer review, including survey of results | 1d? | 2005-04-14 A | 2005-04-15 A | 208 | 100% |  |  |  |
| 210 | 2.4.3.5 | Identify required changes to draft standard minimum GIST qualifications/GIS expectations based on the final peer review feedback | 1d? | 2005-04-15 A | 2005-04-18 A | 209 | 100% |  |  |  |
| 211 | 2.4.3.6 | Make required changes, as identified, to draft minimum GIST qualifications/GIS expectations symbols | 1d? | 2005-04-18 A | 2005-04-19 A | 210 | 100% |  |  |  |
| 212 | 2.4.3.7 | Ratify the final draft standard minimum GIST qualifications/GIS expectations | 1d? | 2005-04-19 A | 2005-04-20 A | 211 | 100% | GIST Qual/GIS Min Expec Subteam | 8h | 8h |

Notes:
- 185: Text1: electronic format of original documents in folder on DisasterHelp site
- 187: using books, media (including internet and magazines) / Text1: electronic documents with quotes and bibliographic references
- 188: Text1: electronic format of original documents
- 191: Text1: matrix of similarities
- 192: Text1: list of minimum GIST qualifications for evaluation
- 193: Text1: list of other GIST qualifications (wish list)
- 194: Text1: Draft of minimum GIST qualifications standard
- 195: Text1: GIST qualifications evaluation document
- 196: Text1: Draft list of minimum GIST qualifications
- 197: Text1: Draft standard of the minimum GIST qualifications
- 199: Text1: Initial peer review package
- 200: Text1: Location posted, review team notified
- 201: Text1: Review report
- 202: Text1: Initial peer review document
- 203: Text1: List of required changes
- 204: Text1: Initial updated draft standard minimum GIST qualifications and GIS expectations
- 206: Text1: Final Peer Review Survey
- 207: Text1: Final Peer Review Package
- 208: Text1: Submission Report
- 209: Text1: Final Peer Review Document
- 210: Text1: List of required changes
- 211: Text1: final updated list of minimum GIST qualifications and GIS expectations
- 212: Text1: Final Draft Standard Minimum GIST Qualifications/GIS Expectations

| ID | WBS | Task | Duration | Start | Finish | Predecessors | Complete | Baseline start | Baseline finish | Baseline duration | Constraint | Resources | Work | Actual work | Text1 |
| --- | --- | --- | --- | --- | --- | --- | --- | --- | --- | --- | --- | --- | --- | --- | --- |
| 213 | 2.4.4 | **Finalize recommendation for standard Minimum GIST Qualifications & GIS Expectations on an Incident** | 3d? | 2005-04-20 A | 2005-04-25 A | 205 | 100% |  |  |  |  |  |  |  |  |
| 214 | 2.4.4.1 | Create a report recommending the adoption of the draft minimum GIST Qualifications/GIS Expectations | 1d? | 2005-04-20 A | 2005-04-21 A |  | 100% |  |  |  |  |  |  |  | Recommendation Report |
| 215 | 2.4.4.2 | Conduct a review of the report for completeness, accuracy, language, and grammar | 1d? | 2005-04-21 A | 2005-04-22 A | 214 | 100% |  |  |  |  |  |  |  | Finalized Recommendation Report |
| 216 | 2.4.4.3 | Submit the report to GSTOP-PM | 1d? | 2005-04-22 A | 2005-04-25 A | 215 | 100% |  |  |  |  |  |  |  | Report Submission |
| 217 | 2.5 | **Incident GIS Minimum Essential Datasets** | 53d? | 2005-02-10 A | 2005-04-25 A |  | 100% | 2004-12-31 | 2005-01-06 | 5d? |  | John Guthrie | 912h | 912h |  |
| 218 | 2.5.1 | **Establish MED Sub-Team business practices** | 25d? | 2005-02-10 A | 2005-03-16 A |  | 100% |  |  |  |  |  |  |  |  |
| 219 | 2.5.1.1 | **Develop a MED Sub-team Communication Plan** | 25d? | 2005-02-10 A | 2005-03-16 A |  | 100% | 2004-12-31 | 2005-01-18 | 13d? |  |  |  |  | Communication Plan Document |
| 220 | 2.5.1.1.1 | Define ground-rules for Sub-Team (internal) communication | 1d? | 2005-03-16 A | 2005-03-16 A |  | 100% | 2004-12-31 | 2005-01-10 | 7d? |  |  |  |  | Write Up |
| 221 | 2.5.1.1.2 | Define ground-rules for communication between the MED Sub-Team and other GSTOP Sub-Teams | 1d? | 2005-02-10 A | 2005-02-10 A |  | 100% | 2004-12-31 | 2004-12-31 | 1d? |  |  |  |  | Write Up |
| 222 | 2.5.1.1.3 | Define ground rules for communication between the Sub-Team and entities outside of the GSTOP Project | 1d? | 2005-02-10 A | 2005-02-10 A |  | 100% | 2005-01-03 | 2005-01-03 | 1d? |  |  |  |  | Write Up |
| 223 | 2.5.1.1.4 | Establish a process and schedule for Sub-Team (internal) progress report updates | 1d? | 2005-02-10 A | 2005-02-10 A |  | 100% | 2005-01-04 | 2005-01-04 | 1d? |  |  |  |  | Write Up |
| 224 | 2.5.1.1.5 | Establish a process and schedule for Sub-Team progress report updates to the GSTOP Team | 1d? | 2005-02-10 A | 2005-02-10 A |  | 100% | 2005-01-05 | 2005-01-05 | 1d? |  |  |  |  | Write Up |
| 225 | 2.5.1.2 | **Establish Review Processes** | 25d? | 2005-02-10 A | 2005-03-16 A |  | 100% | 2005-01-06 | 2005-01-06 | 1d? |  |  |  |  | Review Process Document |
| 226 | 2.5.1.2.1 | Establish a process for Sub-Team (internal) review of potential MEDs | 1d? | 2005-02-10 A | 2005-02-10 A |  | 100% | 2005-01-07 | 2005-01-07 | 1d? |  |  |  |  | Write Up |
| 227 | 2.5.1.2.2 | Establish a process for Sub-Team (internal) review of the draft standard MEDs | 1d? | 2005-02-10 A | 2005-02-10 A | 226 | 100% | 2005-01-10 | 2005-01-10 | 1d? |  |  |  |  | Write Up |
| 228 | 2.5.1.2.3 | Establish a process for peer reviews | 1d? | 2005-03-16 A | 2005-03-16 A | 227 | 100% | 2005-01-11 | 2005-01-12 | 2d? |  |  |  |  | Write Up |
| 229 | 2.5.1.2.4 | Establish a process for periodic GSTOP Team reviews | 1d? | 2005-03-01 A | 2005-03-01 A |  | 100% | 2005-01-11 | 2005-01-11 | 1d? |  |  |  |  | Write Up |
| 230 | 2.5.1.2.5 | Establish a process for reviewing the final report | 1d? | 2005-03-01 A | 2005-03-01 A | 229 | 100% | 2005-01-12 | 2005-01-12 | 1d? |  |  |  |  | Write Up |
| 231 | 2.5.1.3 | **Establish Change processes** | 12d? | 2005-03-01 A | 2005-03-16 A | 230 | 100% | 2005-01-13 | 2005-01-14 | 2d? |  |  |  |  | Change Process Document |
| 232 | 2.5.1.3.1 | Establish a process for additions/deletions of potential MEDs mid-stream through the Project | 1d? | 2005-03-01 A | 2005-03-01 A |  | 100% | 2005-01-13 | 2005-01-13 | 1d? |  |  |  |  | Write Up |
| 233 | 2.5.1.3.2 | Establish a change process for the additions/deletion of standard MEDs after the final recommendation has been submitted | 1d? | 2005-03-01 A | 2005-03-01 A | 232 | 100% | 2005-01-14 | 2005-01-14 | 1d? |  |  |  |  | Write Up |
| 234 | 2.5.1.3.3 | Establish a change process for the additions/deletion of standard MEDs after the final recommendation has been approved through the GSTOP Team | 1d? | 2005-03-16 A | 2005-03-16 A | 233 | 100% | 2005-01-17 | 2005-01-17 | 1d? |  |  |  |  | Write Up |
| 235 | 2.5.2 | **Develop requirements for GIS Minimum Essential Datasets SOPs** | 29d? | 2005-03-01 A | 2005-04-08 A |  | 100% |  |  |  |  |  | 352h | 352h |  |
| 236 | 2.5.2.1 | **Establish MED evaluation methods** | 18d? | 2005-03-16 A | 2005-04-08 A |  | 100% |  |  |  |  | MED Subteam | 152h | 152h | Evaluation Methodology Document |
| 237 | 2.5.2.1.1 | **Define High level criteria for the acceptance of MEDs as standards** | 17d? | 2005-03-17 A | 2005-04-08 A |  | 100% |  |  |  |  |  |  |  | Acceptance Criteria Document |
| 238 | 2.5.2.1.1.1 | Determine incident tasks and required deliverables | 1d? | 2005-03-17 A | 2005-03-17 A |  | 100% |  |  |  |  |  |  |  | Deliverables spreadsheet |
| 239 | 2.5.2.1.1.2 | Determine data availability criteria | 3d | 2005-04-05 A | 2005-04-07 A |  | 100% |  |  |  |  |  |  |  | Data Availability Criteria |
| 240 | 2.5.2.1.1.3 | Develop accuracy standards for databases | 1d? | 2005-04-08 A | 2005-04-08 A | 239 | 100% |  |  |  |  |  |  |  | Accuracy Standards statement |
| 241 | 2.5.2.1.2 | Define method for evaluating MEDs | 13d? | 2005-03-18 A | 2005-04-05 A |  | 100% | 2004-12-31 | 2005-01-03 | 2d? |  |  |  |  | MED Evaluation Method |
| 242 | 2.5.2.1.3 | Develop acceptance criteria for raster MEDs | 1d? | 2005-03-16 A | 2005-03-16 A |  | 100% |  |  |  |  |  |  |  | Writeup |
| 243 | 2.5.2.1.4 | Post draft Acceptance Critera for GSTOP Team review | 4d? | 2005-03-18 A | 2005-03-23 A |  | 100% |  |  |  |  |  |  |  |  |
| 244 | 2.5.2.1.5 | Review draft Acceptance Criteria | 1d? | 2005-03-28 A | 2005-03-28 A | 243 | 100% |  |  |  | finish no earlier than 2005-03-28 | GSTOP Team | 8h | 8h | GSTOP Team feedback |
| 245 | 2.5.2.1.6 | Update Acceptance Criteria for GSTOP Team input | 4d | 2005-03-29 A | 2005-04-01 A | 244 | 100% |  |  |  |  |  |  |  |  |
| 246 | 2.5.2.1.7 | Conduct a final review of selection criteria | 1d? | 2005-04-04 A | 2005-04-04 A | 245 | 100% | 2004-12-31 | 2004-12-31 | 1d? |  |  |  |  | MED Selection Criteria |

| ID | WBS | Task | Type | Duration | Start | Finish | Predecessors | Complete | Baseline start | Baseline finish | Baseline duration | Constraint | Resources | Work | Actual work | Text1 |
| --- | --- | --- | --- | --- | --- | --- | --- | --- | --- | --- | --- | --- | --- | --- | --- | --- |
| 247 | 2.5.2.2 | **Develop a list of MEDs to be evaluated for acceptance as draft standards** |  | 25d? | 2005-03-01 A | 2005-04-04 A |  | 100% | 2004-12-31 | 2004-12-31 | 1d? |  | MED Subteam | 200h | 200h |  |
| 248 | 2.5.2.2.1 | Determine what datasets are required for each deliverable |  | 24d | 2005-03-01 A | 2005-04-01 A |  | 100% |  |  |  | start no earlier than 2005-03-01 |  |  |  | Deliverables Spreadsheet (revised) |
| 249 | 2.5.2.2.2 | Collect Standard Product Definition from GSTOP subteam to evaluate for potential MEDs |  | 24d? | 2005-03-01 A | 2005-04-01 A |  | 100% | 2004-12-31 | 2004-12-31 | 1d? | finish no earlier than 2005-04-01 |  |  |  | Table of data needed for maps |
| 250 | 2.5.2.2.3 | Document potential sources for additional fire mapping MEDs |  | 1d? | 2005-04-04 A | 2005-04-04 A | 249 | 100% | 2004-12-31 | 2004-12-31 | 1d? |  |  |  |  | List of data sources |
| 251 | 2.5.2.2.4 | Compile MEDs into a single potential MED set |  | 1d? | 2005-04-04 A | 2005-04-04 A | 249 | 100% | 2005-01-03 | 2005-01-03 | 1d? |  |  |  |  | Set of potential standard MEDs |
| 252 | 2.5.2.2.5 | Define methods a GIST should yuse to determine if dataset meets Accuracy Standards |  | 1d? | 2005-03-16 A | 2005-03-16 A |  | 100% |  |  |  |  |  |  |  | Dataset Evaluation Process Document |
| 253 | 2.5.3 | **Develop draft SOPs for GIS Minimum Essential Datasets** |  | 9d? | 2005-04-11 A | 2005-04-21 A | 235 | 100% |  |  |  |  |  | 72h | 72h |  |
| 254 | 2.5.3.1 | **Determine the draft standard Raster MEDs** |  | 3d? | 2005-04-11 A | 2005-04-13 A | 247 | 100% | 2004-12-31 | 2004-12-31 | 1d? |  | MED Subteam | 24h | 24h |  |
| 255 | 2.5.3.1.1 | Evaluate each potential marker MED against the MED selection criteria |  | 1d? | 2005-04-11 A | 2005-04-11 A |  | 100% | 2004-12-31 | 2004-12-31 | 1d? |  |  |  |  | MED Evaluation Document |
| 256 | 2.5.3.1.2 | Sub-Team selection of the draft standards for MEDs vs. extended MED list |  | 1d? | 2005-04-12 A | 2005-04-12 A | 255 | 100% | 2004-12-31 | 2004-12-31 | 1d? |  |  |  |  | Draft list of selected MEDs |
| 257 | 2.5.3.1.3 | Conduct a Sub-team completeness review of the draft standard MEDs |  | 1d? | 2005-04-13 A | 2005-04-13 A | 256 | 100% | 2004-12-31 | 2004-12-31 | 1d? |  |  |  |  | Draft Standard MEDs Document |
| 258 | 2.5.3.2 | **Conduct a Sub-team completeness review of the draft standard and extended MEDs** |  | 5d? | 2005-04-14 A | 2005-04-20 A | 254 | 100% | 2004-12-31 | 2004-12-31 | 1d? |  | BLM publication shop | 48h | 48h | Draft Standard Fill MEDs Document |
| 259 | 2.5.3.2.1 | Prepare draft standard MEDs for initial peer review |  | 1d? | 2005-04-14 A | 2005-04-14 A |  | 100% | 2004-12-31 | 2004-12-31 | 1d? |  |  |  |  | Initial Peer Review Package |
| 260 | 2.5.3.2.2 | Submit the draft standard MEDs to the 5 federal fire management agencies, State agencies, and USGS via the NWCG Geospatial Task Group (GTG); and to DHS (FEMA), FAA, DOD, and GSTOP Team for peer review | milestone | 0d | 2005-04-14 A | 2005-04-14 A | 259 | 100% | 2004-12-31 | 2004-12-31 | 0d |  |  |  |  | Submission Report |
| 261 | 2.5.3.2.3 | Conduct initial peer review of the draft standard and extended MEDs |  | 1d? | 2005-04-15 A | 2005-04-15 A | 260 | 100% | 2004-12-31 | 2004-12-31 | 1d? |  | GSTOP Team | 8h | 8h |  |
| 262 | 2.5.3.2.4 | Review feedback of initial peer review |  | 1d? | 2005-04-18 A | 2005-04-18 A | 261 | 100% | 2004-12-31 | 2004-12-31 | 1d? |  |  |  |  | Initial Peer Review Document |
| 263 | 2.5.3.2.5 | Identify required changes to draft standard MEDs based on the initial peer review feedback |  | 1d? | 2005-04-19 A | 2005-04-19 A | 262 | 100% | 2005-01-18 | 2005-01-19 | 1d? |  |  |  |  | List of required MED changes |
| 264 | 2.5.3.2.6 | Make required changes, as identified, to draft standard MEDs |  | 1d? | 2005-04-20 A | 2005-04-20 A | 263 | 100% | 2005-01-19 | 2005-01-19 | 1d? |  |  |  |  | Initial updated MEDs list |
| 265 | 2.5.3.3 | Prepare draft SOPs for field test |  | 1d? | 2005-04-21 A | 2005-04-21 A | 258 | 100% |  |  |  |  |  |  |  |  |
| 266 | 2.5.4 | **Conduct final peer review of the draft standard marker, line, and fill MEDs** |  | 1d? | 2005-04-22 A | 2005-04-22 A | 253 | 100% | 2005-01-19 | 2005-01-19 | 1d? |  | NWCG Training Team | 56h | 56h |  |
| 267 | 2.5.4.1 | Prepare draft standard MEDs for final peer review |  | 1d? | 2005-04-22 A | 2005-04-22 A |  | 100% | 2005-01-19 | 2005-01-19 | 1d? |  | Victoria Smith; Deb Epps | 16h | 16h | Final Peer Review Package |
| 268 | 2.5.4.2 | Submit the draft standard MEDs to the 5 federal fire management agencies and State agencies via the NWCG Geospatial Task Group (GTG); and to the HSA (FEMA), FAA, DOD, and GSTOP Team for peer review |  | 1d? | 2005-04-22 A | 2005-04-22 A |  | 100% | 2005-01-19 | 2005-01-19 | 1d? |  | GSTOP Subteam(s) | 8h | 8h | Submission Report |
| 269 | 2.5.4.3 | Review feedback of the final peer review |  | 1d? | 2005-04-22 A | 2005-04-22 A |  | 100% | 2005-01-19 | 2005-01-19 | 1d? |  | GSTOP Subteam(s) | 8h | 8h | Final Peer Review Document |
| 270 | 2.5.4.4 | Identify required changes to draft standard MEDs based on the final peer review feedback |  | 1d? | 2005-04-22 A | 2005-04-22 A |  | 100% | 2005-01-19 | 2005-01-19 | 1d? |  | GSTOP Subteam(s) | 8h | 8h | List of required MED changes |
| 271 | 2.5.4.5 | Make required changes, as identified, to draft standard MEDs |  | 1d? | 2005-04-22 A | 2005-04-22 A |  | 100% | 2005-01-19 | 2005-01-19 | 1d? |  | GSTOP Subteam(s) | 8h | 8h | final updated MEDs list |
| 272 | 2.5.4.6 | Ratification of the final draft standard MEDs by the Sub-Team |  | 1d? | 2005-04-22 A | 2005-04-22 A |  | 100% | 2005-01-19 | 2005-01-19 | 1d? |  |  |  |  | Final Draft Standard MEDs List |

| ID | WBS | Task | Type | Duration | Start | Finish | Predecessors | Complete | Baseline start | Baseline finish | Baseline duration | Constraint | Resources | Work | Actual work |
| --- | --- | --- | --- | --- | --- | --- | --- | --- | --- | --- | --- | --- | --- | --- | --- |
| 273 | 2.5.5 | **Finalize recommendation of standard Fire Mapping MEDs** |  | 1d? | 2005-04-25 A | 2005-04-25 A | 266 | 100% | 2005-01-19 | 2005-01-19 | 1d? |  |  | 8h | 8h |
| 274 | 2.5.5.1 | Create a report recommending the adoption of the draft standard MEDs |  | 1d? | 2005-04-25 A | 2005-04-25 A |  | 100% | 2005-01-19 | 2005-01-19 | 1d? |  | GSTOP Team | 8h | 8h |
| 275 | 2.5.5.2 | Conduct a Sub-Team review of the report |  | 1d? | 2005-04-25 A | 2005-04-25 A |  | 100% | 2005-01-19 | 2005-01-19 | 1d? |  |  |  |  |
| 276 | 2.5.5.3 | Submit the report to GSTOP-PM |  | 1d? | 2005-04-25 A | 2005-04-25 A |  | 100% | 2005-01-19 | 2005-01-19 | 1d? |  |  |  |  |
| 277 | 2.6 | **Incident GIS Standard Data Sharing and Archiving Standards** |  | 8.42d? | 2005-03-16 A | 2005-03-28 A |  | 100% |  |  |  |  | Sean Triplett | 163.33h | 163.33h |
| 278 | 2.6.1 | **Develop requirements for GIS Standard Data Sharing and Archiving Standards SOPs** |  | 4.42d? | 2005-03-16 A | 2005-03-22 A |  | 100% |  |  |  |  |  | 72h | 72h |
| 279 | 2.6.1.1 | **Define Information Needs (What do we need to gather?)** |  | 2.42d? | 2005-03-16 A | 2005-03-18 A |  | 100% |  |  |  |  |  | 32h | 32h |
| 280 | 2.6.1.1.1 | Compile existing archiving standards in use (e.g. data format, transfer mode) |  | 1d? | 2005-03-16 A | 2005-03-16 A |  | 100% |  |  |  |  | Business Lead; GTG Standards Committee | 16h | 16h |
| 281 | 2.6.1.1.2 | Identify how archiving is done at present time by ICS, military, other incident responders, project-management |  | 0.17d? | 2005-03-17 A | 2005-03-17 A | 280 | 100% |  |  |  |  | Internet Search; Military; etc.; survey GISTs; Plans Sections (Mary Kwart); Documents Sections | 8h | 8h |
| 282 | 2.6.1.1.3 | Gather NARA, Records Management requirements (review policies, lawsuits) e.g. physical location, acceptable media, supporting documentation |  | 0.25d? | 2005-03-17 A | 2005-03-17 A | 281 | 100% |  |  |  |  | Business Lead; FGDC; NARA; NWCG Member Agencies | 8h | 8h |
| 283 | 2.6.1.1.4 | Determine the least common denominator (shapefile) or possibility of multiple formats |  | 1d? | 2005-03-17 A | 2005-03-18 A | 282 | 100% |  |  |  |  |  |  |  |
| 284 | 2.6.1.2 | Collect Information: Conduct literature review |  | 1d? | 2005-03-18 A | 2005-03-21 A | 279 | 100% |  |  |  |  | FGDC; GeoMAC; NPS I&M; NPS Focus; NARA | 40h | 40h |
| 285 | 2.6.1.3 | Conduct Analysis: Compile & Synthesize Requirements |  | 1d? | 2005-03-21 A | 2005-03-22 A | 284 | 100% |  |  |  |  |  |  |  |
| 286 | 2.6.2 | **Develop draft SOPs for GIS Standard Data Sharing and Archiving Standards** |  | 4d? | 2005-03-22 A | 2005-03-28 A | 278 | 100% |  |  |  |  |  | 24h | 24h |
| 287 | 2.6.2.1 | Develop Preliminary SOPs |  | 1d? | 2005-03-22 A | 2005-03-23 A |  | 100% |  |  |  |  | DataShareArcTrans Subteam | 8h | 8h |
| 288 | 2.6.2.2 | Sub-Team Review of SOP |  | 1d? | 2005-03-23 A | 2005-03-24 A | 287 | 100% |  |  |  |  | DataShareArcTrans Subteam | 8h | 8h |
| 289 | 2.6.2.3 | Revise, Edit Proposed SOP |  | 1d? | 2005-03-24 A | 2005-03-25 A | 288 | 100% |  |  |  |  | DataShareArcTrans Subteam | 8h | 8h |
| 290 | 2.6.2.4 | Submit to Project Manager for Team Review |  | 1d? | 2005-03-25 A | 2005-03-28 A | 289 | 100% |  |  |  |  |  |  |  |
| 291 | 2.7 | **Incident GIS Standard Documentation and Archiving** |  | 23d? | 2005-03-16 A | 2005-04-15 A |  | 100% |  |  |  |  | Sean Triplett | 1088h | 1088h |
| 292 | 2.7.1 | **Develop requirements for GIS Standard Documentation and Archiving SOPs** |  | 20d? | 2005-03-16 A | 2005-04-12 A |  | 100% |  |  |  |  |  | 760h | 760h |
| 293 | 2.7.1.1 | **Define Information Needs (What do we need to gather?)** |  | 18d? | 2005-03-16 A | 2005-04-08 A |  | 100% |  |  |  |  |  | 712h | 712h |
| 294 | 2.7.1.1.1 | Compile existing archiving standards in use (e.g. data format, transfer mode) |  | 10d? | 2005-03-23 A | 2005-04-05 A |  | 100% |  |  |  |  | GTG Standards Committee; Mary Kwart | 160h | 160h |
| 295 | 2.7.1.1.2 | Identify how archiving is done at present time by ICS, military, other incident responders, project-management |  | 13d? | 2005-03-23 A | 2005-04-08 A | 294 | 100% |  |  |  | finish no earlier than 2005-04-08 | Internet Search; Military; survey GISTs; Plans Sections (Mary Kwart); Documents Sections | 520h | 520h |
| 296 | 2.7.1.1.3 | ?? Gather NARA, Records Management requirements (review policies, lawsuits) e.g. physical location, acceptable media, supporting documentation |  | 1d | 2005-03-16 A | 2005-03-16 A |  | 100% |  |  |  |  | Business Lead; FGDC; NARA; agency guidance | 32h | 32h |
| 297 | 2.7.1.1.4 | Determine the least common denominator (shapefile) or possibility of multiple formats |  | 10d? | 2005-03-23 A | 2005-04-05 A | 294, 295, 296 | 100% |  |  |  |  |  |  |  |
| 298 | 2.7.1.2 | Review Documentation Unit Leader Task book and Job Aid |  | 1d? | 2005-03-16 A | 2005-03-16 A |  | 100% |  |  |  |  | FGDC; GeoMAC; NPS I&M; NPS Focus; NARA | 40h | 40h |
| 299 | 2.7.1.3 | Conduct Analysis: Compile, Synthesize requirements |  | 1d? | 2005-04-11 A | 2005-04-11 A | 298, 293 | 100% |  |  |  |  |  |  |  |
| 300 | 2.7.1.4 | Document Preliminary Requirements Specifications |  | 1d? | 2005-04-12 A | 2005-04-12 A | 299 | 100% |  |  |  |  | DataShareArcTrans Subteam | 8h | 8h |
| 301 | 2.7.1.5 | Post subteam Requirements for GSTOP Team Review | milestone | 0d | 2005-04-12 A | 2005-04-12 A | 300 | 100% |  |  |  |  |  |  |  |

Notes:
- 274: Text1: Recommendation Report
- 275: Text1: Finalized Recommendation Report
- 276: Text1: Report Submission
- 293: Text1: Spreadsheet
- 294: Brian Sorbel, Joe Frost, Susan Goodman / Text1: List of data types in use on incidents and standards
- 295: idea is to take advantage of "lessons learned." Have made contact with NORTHCOM (Military). / Text1: Matrix of incident/event data creators and indication of how they manage their data
- 296: Text1: list of data repositories, data warehouses, etc.
- 297: Should incident data be in a format compatible with GeoSpatial One-Stop, GEOMAC? / Text1: List of acceptable data forms for archiving.
- 298: Text1: Writeup of requirements for data repositories.
- 299: Text1: Writeup of common elements, differences, ideas worth pursuing.
- 300: Text1: Develop Proposed SOP
- 301: Text1: Information Needs for GIS Standard Documentation and Archiving

| ID | WBS | Task | Type | Duration | Start | Finish | Predecessors | Complete | Baseline start | Baseline finish | Baseline duration | Resources | Work | Actual work | Text1 |
| --- | --- | --- | --- | --- | --- | --- | --- | --- | --- | --- | --- | --- | --- | --- | --- |
| 302 | 2.7.2 | **Develop draft SOPs for GIS Standard Documentation and Archiving** |  | 3d? | 2005-04-13 A | 2005-04-15 A | 292 | 100% |  |  |  |  | 24h | 24h |  |
| 303 | 2.7.2.1 | Develop Preliminary SOPs |  | 1d? | 2005-04-13 A | 2005-04-13 A |  | 100% |  |  |  | DataShareArcTrans Subteam | 8h | 8h |  |
| 304 | 2.7.2.2 | Sub-Team Review of SOP |  | 1d? | 2005-04-14 A | 2005-04-14 A | 303 | 100% |  |  |  | DataShareArcTrans Subteam | 8h | 8h | Writeup of results of Sub-Team review |
| 305 | 2.7.2.3 | Revise, Edit Proposed SOP |  | 1d? | 2005-04-15 A | 2005-04-15 A | 304 | 100% |  |  |  | DataShareArcTrans Subteam | 8h | 8h | Revised SOP |
| 306 | 2.7.2.4 | Submit to Project Manager for Team Review | milestone | 0d | 2005-04-15 A | 2005-04-15 A | 305 | 100% |  |  |  |  |  |  | GIS Standard Documentation and Archiving draft SOPs |
| 307 | 2.7.3 | **Conduct External Review of GIS Standard Data Sharing and Archiving Standards SOP requirements and draft SOPs** |  | 12d? | 2005-03-16 A | 2005-03-31 A |  | 100% |  |  |  |  | 112h | 112h |  |
| 308 | 2.7.3.1 | Design External Review of guidelines/requirements for GIS Standard Documentation and Archiving SOPs |  | 2d? | 2005-03-16 A | 2005-03-17 A |  | 100% |  |  |  |  |  |  | Plan for external review of GIS Transition Procedures |
| 309 | 2.7.3.2 | Post sample documents/SOPs for external review |  | 5d? | 2005-03-18 A | 2005-03-24 A | 308 | 100% | 2004-12-31 | 2005-01-17 | 12d? |  |  |  |  |
| 310 | 2.7.3.3 | Conduct External review of Guidelines/Requirements and draft SOPs |  | 0.5d? | 2005-03-25 A | 2005-03-25 A | 309 | 100% |  |  |  | GTG; Reviewers | 8h | 8h |  |
| 311 | 2.7.3.4 | Edit draft guidelines/Requirements based on input |  | 1d? | 2005-03-16 A | 2005-03-16 A |  | 100% |  |  |  | Sub-Team | 8h | 8h | final requirements |
| 312 | 2.7.3.5 | Edit sample documents/SOPs based on input |  | 12d? | 2005-03-16 A | 2005-03-31 A |  | 100% | 2004-12-31 | 2005-01-05 | 4d? | Sub-Team | 96h | 96h | final SOPs |
| 313 | 2.7.4 | **Finalize recommendation of GIS Standard Documentation and Archiving** |  | 2d? | 2005-04-01 A | 2005-04-04 A | 307 | 100% | 2004-12-31 | 2004-12-31 | 1d? |  | 8h | 8h |  |
| 314 | 2.7.4.1 | Create a report recommending the adoption of the standard |  | 1d? | 2005-04-01 A | 2005-04-01 A |  | 100% | 2004-12-31 | 2004-12-31 | 1d? |  |  |  | Recommendation Report |
| 315 | 2.7.4.2 | Conduct a review of the report |  | 1d? | 2005-04-04 A | 2005-04-04 A | 314 | 100% | 2004-12-31 | 2004-12-31 | 1d? | Sub-Team | 8h | 8h | Finalized Recommendation Report |
| 316 | 2.7.4.3 | Submit the report to GSTOP-PM | milestone | 0d | 2005-04-04 A | 2005-04-04 A | 315 | 100% | 2004-12-31 | 2004-12-31 | 1d |  |  |  | Report Submission |
| 317 | 2.8 | **Incident GIS Transition Procedures** |  | 65d? | 2005-03-16 A | 2005-06-14 A |  | 100% |  |  |  |  | 360h | 360h |  |
| 318 | 2.8.1 | **Develop requirements for GIS Transition Procedures** |  | 17d? | 2005-03-18 A | 2005-04-11 A |  | 100% |  |  |  |  | 200h | 200h |  |
| 319 | 2.8.1.1 | **Define Information Needs (What do we need to gather?)** |  | 12d? | 2005-03-18 A | 2005-04-04 A |  | 100% |  |  |  |  | 160h | 160h |  |
| 320 | 2.8.1.1.1 | Determine "universe" of transitions: (team to team); (team to unit); (team to archive) |  | 1d? | 2005-03-23 A | 2005-03-23 A |  | 100% |  |  |  | Business Lead; FGDC; NARA; agency guidance | 32h | 32h | Annotated Hierarchical List |
| 321 | 2.8.1.1.2 | Conduct interviews and compile procedures documents currently in use |  | 1d? | 2005-03-23 A | 2005-03-23 A | 320 | 100% |  |  |  | Other "team" environs; Mary Kwart; Military; survey | 32h | 32h | annotated list |
| 322 | 2.8.1.1.3 | Identify if existing procedures in use "somewhere out there" may be acceptible (e.g. NARA) |  | 12d? | 2005-03-18 A | 2005-04-04 A | 321 | 100% |  |  |  | DataShareArcTrans Subteam | 96h | 96h | writeup |
| 323 | 2.8.1.2 | Evaluate Procedures: Identify test procedures for documentation and archiving |  | 1d? | 2005-04-05 A | 2005-04-05 A | 319 | 100% |  |  |  | DataShareArcTrans Subteam | 8h | 8h | writeup |
| 324 | 2.8.1.3 | Conduct Analysis: Test and identify strengths/weaknesses of existing procedures |  | 1d? | 2005-04-06 A | 2005-04-06 A | 323 | 100% |  |  |  | field teams; DataShareArcTrans Subteam | 16h | 16h | writieup of test |
| 325 | 2.8.1.4 | Develop Preliminary Requirements Specifications |  | 1d? | 2005-04-07 A | 2005-04-07 A | 324 | 100% |  |  |  |  |  |  | summarize test |

Notes:
- 320: is "unit to team" transfer covered in MED? Is transition to archive covered in team-to-unit?

| ID | WBS | Task | Type | Duration | Start | Finish | Predecessors | Complete | Baseline start | Baseline finish | Baseline duration | Resources | Work | Actual work | Text1 |
| --- | --- | --- | --- | --- | --- | --- | --- | --- | --- | --- | --- | --- | --- | --- | --- |
| 326 | 2.8.1.5 | **Review and Validate Requirements** |  | 2d? | 2005-04-08 A | 2005-04-11 A | 325 | 100% |  |  |  |  | 16h | 16h |  |
| 327 | 2.8.1.5.1 | Sub-Team Review of Requirements |  | 1d? | 2005-04-08 A | 2005-04-08 A |  | 100% |  |  |  | DataShareArcTrans Subteam | 8h | 8h | draft GIS Transition requirements |
| 328 | 2.8.1.5.2 | Revise, Edit requirements |  | 1d? | 2005-04-11 A | 2005-04-11 A | 327 | 100% |  |  |  | DataShareArcTrans Subteam | 8h | 8h | final GIS Transition requirements |
| 329 | 2.8.1.5.3 | Submit to Project Manager for Team Review | milestone | 0d | 2005-04-11 A | 2005-04-11 A | 328 | 100% |  |  |  |  |  |  |  |
| 330 | 2.8.2 | **Develop Preliminary SOP’s** |  | 5d? | 2005-06-08 A | 2005-06-14 A | 371, 318 | 100% |  |  |  |  | 40h | 40h |  |
| 331 | 2.8.2.1 | Create draft GIS Transition SOPs |  | 1d? | 2005-06-08 A | 2005-06-08 A |  | 100% |  |  |  | DataShareArcTrans Subteam | 8h | 8h | draft GIS Transition SOPs |
| 332 | 2.8.2.2 | Review draft GIS Transition SOPs |  | 1d? | 2005-06-09 A | 2005-06-09 A | 331 | 100% |  |  |  | DataShareArcTrans Subteam | 8h | 8h | Writeup of results of Sub-Team review |
| 333 | 2.8.2.3 | Revise, Edit draft GIS Transition SOPs |  | 1d? | 2005-06-10 A | 2005-06-10 A | 332 | 100% |  |  |  | DataShareArcTrans Subteam | 8h | 8h | Draft GIS Transition SOPs |
| 334 | 2.8.2.4 | Submit to Project Manager for Team Review | milestone | 0d | 2005-06-10 A | 2005-06-10 A | 333 | 100% |  |  |  |  |  |  |  |
| 335 | 2.8.2.5 | Review Draft GIS Transition SOPs |  | 1d? | 2005-06-13 A | 2005-06-13 A | 334 | 100% |  |  |  | GSTOP Team | 8h | 8h | comments on draft Transition SOPs |
| 336 | 2.8.2.6 | Revise, Edit GIS Transition SOPs |  | 1d? | 2005-06-14 A | 2005-06-14 A | 335 | 100% |  |  |  | DataShareArcTrans Subteam | 8h | 8h | Proposed GIS Transition SOPs |
| 337 | 2.8.3 | **Conduct External Review of GIS Transition Procedures SOP requirements and draft SOPs** |  | 12d? | 2005-03-16 A | 2005-03-31 A |  | 100% |  |  |  |  | 112h | 112h |  |
| 338 | 2.8.3.1 | Design External Review of guidelines/requirements for GIS Transition Procedures |  | 2d? | 2005-03-16 A | 2005-03-17 A |  | 100% |  |  |  |  |  |  | Plan for external review of GIS Transition Procedures |
| 339 | 2.8.3.2 | Post sample documents/SOPs for external review |  | 5d? | 2005-03-18 A | 2005-03-24 A | 338 | 100% | 2004-12-31 | 2005-01-17 | 12d? |  |  |  |  |
| 340 | 2.8.3.3 | Conduct External review of Guidelines/Requirements and draft SOPs |  | 0.5d? | 2005-03-25 A | 2005-03-25 A | 339 | 100% |  |  |  | GTG; Reviewers | 8h | 8h |  |
| 341 | 2.8.3.4 | Edit draft guidelines/Requirements based on input |  | 1d? | 2005-03-16 A | 2005-03-16 A |  | 100% |  |  |  | Sub-Team | 8h | 8h | final requirements |
| 342 | 2.8.3.5 | Edit sample documents/SOPs based on input |  | 12d? | 2005-03-16 A | 2005-03-31 A |  | 100% | 2004-12-31 | 2005-01-05 | 4d? | Sub-Team | 96h | 96h | final SOPs |
| 343 | 2.8.4 | **Finalize recommendation of GIS Transition Procedures** |  | 2d? | 2005-04-01 A | 2005-04-04 A | 337 | 100% | 2004-12-31 | 2004-12-31 | 1d? |  | 8h | 8h |  |
| 344 | 2.8.4.1 | Create a report recommending the adoption of the standard |  | 1d? | 2005-04-01 A | 2005-04-01 A |  | 100% | 2004-12-31 | 2004-12-31 | 1d? |  |  |  | Recommendation Report |
| 345 | 2.8.4.2 | Conduct a review of the report |  | 1d? | 2005-04-04 A | 2005-04-04 A | 344 | 100% | 2004-12-31 | 2004-12-31 | 1d? | Sub-Team | 8h | 8h | Finalized Recommendation Report |
| 346 | 2.8.4.3 | Submit the report to GSTOP-PM | milestone | 0d | 2005-04-04 A | 2005-04-04 A | 345 | 100% | 2004-12-31 | 2004-12-31 | 1d |  |  |  | Report Submission |
| 347 | 3 | **Agency Review of Incident GIS SOPs** |  | 185d? | 2005-06-07 A | 2006-02-20 A | 380 | 100% |  |  |  | GSTOP Team | 4440h | 4440h |  |
| 348 | 3.1 | Design common review processes for GIS SOP peer review |  | 1d? | 2005-06-07 A | 2005-06-07 A |  | 100% |  |  |  |  |  |  |  |
| 349 | 3.2 | **Review and Validate draft SOP’s** |  | 1d? | 2005-06-07 A | 2005-06-07 A |  | 100% |  |  |  |  | 40h | 40h |  |
| 350 | 3.2.1 | Review and Validate draft SOP’s for completeness |  | 0.5d? | 2005-06-07 A | 2005-06-07 A |  | 100% | 2005-01-19 | 2005-01-19 | 0.5d? | GSTOP Team; GTG; GTAG; Reviewers | 16h | 16h |  |
| 351 | 3.2.2 | Review and Validate draft SOP’s for GIS content |  | 1d? | 2005-06-07 A | 2005-06-07 A |  | 100% | 2005-01-19 | 2005-01-19 | 1d? | GSTOP Team; GTAG; Reviewers | 24h | 24h |  |

| ID | WBS | Task | Type | Duration | Start | Finish | Predecessors | Complete | Remaining | Baseline start | Baseline finish | Baseline duration | Total slack | Free slack | Constraint | Resources | Work | Actual work | Text1 |
| --- | --- | --- | --- | --- | --- | --- | --- | --- | --- | --- | --- | --- | --- | --- | --- | --- | --- | --- | --- |
| 352 | 3.3 | **Agencies' review of Draft SOPs** |  | 182d? | 2005-06-07 A | 2006-02-15 A |  | 100% |  | 2005-01-19 | 2005-01-19 | 1d? |  |  |  | all concerned/impacted parties | 2896h | 2896h |  |
| 353 | 3.3.1 | Create a cover letter and response process |  | 1d? | 2005-06-07 A | 2005-06-07 A |  | 100% |  | 2005-01-19 | 2005-01-19 | 1d? |  |  |  |  |  |  | cover letter |
| 354 | 3.3.2 | Distribute draft SOPs for Agency review |  | 1d? | 2005-06-08 A | 2005-06-08 A | 353 | 100% |  |  |  |  |  |  |  |  |  |  |  |
| 355 | 3.3.3 | Review and Validate draft SOP’s |  | 180d | 2005-06-09 A | 2006-02-15 A | 354 | 100% |  | 2005-01-19 | 2005-01-19 | 1d? |  |  |  | NWCG Member Agencies | 1440h | 1440h |  |
| 356 | 3.4 | **Incorporate Feedback from reviewers** |  | 3d? | 2006-02-16 A | 2006-02-20 A | 352 | 100% |  |  |  |  |  |  |  |  | 24h | 24h |  |
| 357 | 3.4.1 | Consolidate reviewers' inputs |  | 1d? | 2006-02-16 A | 2006-02-16 A |  | 100% |  | 2005-01-19 | 2005-01-19 | 1d? |  |  |  |  |  |  |  |
| 358 | 3.4.2 | Evaluate Feedback for inclusion in SOP revision |  | 1d? | 2006-02-17 A | 2006-02-17 A | 357 | 100% |  | 2005-01-19 | 2005-01-19 | 1d? |  |  |  | GSTOP Team; Independent Reviewer | 16h | 16h |  |
| 359 | 3.4.3 | Update draft SOPs for accepted feedback from reviewers |  | 1d? | 2006-02-20 A | 2006-02-20 A | 358 | 100% |  | 2005-01-19 | 2005-01-19 | 1d? |  |  |  | GSTOP Subteam(s) | 8h | 8h | Revised Draft SOPs |
| 360 | 4 | **Field Test of Incident GIS SOPs (including business requirements)** |  | 1d? | 2005-06-07 | 2005-06-07 | 380 |  |  |  |  |  | 278d |  |  | IMT Teams | 32h |  |  |
| 361 | 4.1 | Develop a list of GSTOP deliverable reviewers |  | 1d? | 2005-06-07 | 2005-06-07 |  |  |  |  |  |  | 278d |  |  | Business Lead | 8h |  | List of GSTOP reviewers |
| 362 | 4.2 | **Develop Quality Assurance and Field Test Plan** |  | 1d? | 2005-06-07 | 2005-06-07 |  |  |  |  |  |  | 278d |  |  | Subteam Lead | 8h |  |  |
| 363 | 4.2.1 | Develop survey instrument to capture field test feedback |  | 1d? | 2005-06-07 | 2005-06-07 |  |  |  |  |  |  | 278d |  |  |  |  |  | GSTOP Field Test results survey |
| 364 | 4.3 | **Execute Quality Assurance and Field Test Plan** |  | 1d? | 2005-06-07 | 2005-06-07 |  |  |  |  |  |  | 278d |  |  | Subteam Lead | 8h |  |  |
| 365 | 4.3.1 | Conduct interviews with GISTs to measure success of Draft SOPs |  | 1d? | 2005-06-07 | 2005-06-07 |  |  |  |  |  |  | 278d |  |  |  |  |  |  |
| 366 | 4.3.2 | Conduct interviews with SIT Unit Leaders to measure success of Draft SOPs |  | 1d? | 2005-06-07 | 2005-06-07 |  |  |  |  |  |  | 278d |  |  |  |  |  |  |
| 367 | 4.4 | Collect written/survey results from the field test |  | 1d? | 2005-06-07 | 2005-06-07 |  |  |  |  |  |  | 278d |  |  |  |  |  |  |
| 368 | 4.5 | Analyze Quality Assurance and Field Test Plan Results |  | 1d? | 2005-06-07 | 2005-06-07 |  |  |  |  |  |  | 278d |  |  |  |  |  |  |
| 369 | 5 | **GSTOP Requirements Milestones** |  | 101d? | 2005-02-10 A | 2005-07-01 |  | 99% | 0d? |  |  |  | 0d |  |  | Project Mgr | 3592h | 3592h |  |
| 370 | 5.1 | MS1: Requirements for GIS SOPs are developed | milestone | 0d | 2005-03-31 | 2005-03-31 | 21, 94, 134, 176, 217, 277, 291, 329 |  |  |  |  |  | -55d | 0d | must finish on 2005-03-31 | Project Mgr; GSTOP Exec Comm |  |  | progress report, project/communication plan |
| 371 | 5.2 | **Develop template for GIS SOPs** |  | 84d? | 2005-02-10 A | 2005-06-07 A |  | 100% |  |  |  |  |  |  |  | Project Mgr; Susan Goodman; Kim Kelly | 2520h | 2520h | Template SOP |
| 372 | 5.2.1 | Review current formats and compile representative selections |  | 37d? | 2005-02-10 A | 2005-04-01 A |  | 100% |  |  |  |  |  |  |  | Sue McLellan | 296h | 296h |  |
| 373 | 5.2.2 | Itemize standard SOP content |  | 2d? | 2005-03-31 A | 2005-04-01 A | 372 | 100% |  |  |  |  |  |  |  | Sue McLellan | 16h | 16h |  |
| 374 | 5.2.3 | Review content for completeness |  | 10d? | 2005-04-04 A | 2005-04-15 A | 373 | 100% |  |  |  |  |  |  | finish no earlier than 2005-04-15 | GSTOP Team | 80h | 80h |  |
| 375 | 5.2.4 | Design standard GIS SOP format |  | 1d? | 2005-04-18 A | 2005-04-18 A | 374 | 100% |  |  |  |  |  |  |  | BLM Pulications | 8h | 8h | GIS SOP template |
| 376 | 5.2.5 | Provide sample SOPs for publishing |  | 1d? | 2005-04-19 A | 2005-04-19 A | 375 | 100% |  |  |  |  |  |  |  | GSTOP Team | 8h | 8h |  |
| 377 | 5.2.6 | Mockup final GIS SOPs for GTG Team Review |  | 1d? | 2005-04-20 A | 2005-04-20 A | 376 | 100% |  |  |  |  |  |  |  | BLM Pulications | 8h | 8h | Draft SOP's |
| 378 | 5.2.7 | Review final GIS SOP mockup |  | 1d? | 2005-04-21 A | 2005-04-21 A | 377 | 100% |  |  |  |  |  |  |  | GSTOP Team | 8h | 8h |  |
| 379 | 5.2.8 | Final formatting and publication of draft SOPs for Field Test |  | 10d | 2005-05-25 A | 2005-06-07 A | 302, 53, 114, 153, 189, 253, 286 | 100% |  |  |  |  |  |  |  | BLM Pulications | 80h | 80h |  |
| 380 | 5.3 | MS2: Draft SOPs are produced and ready for Field Test |  | 16.5d? | 2005-05-13 A | 2005-06-06 A | 379 | 100% |  |  |  |  |  |  | must finish on 2005-05-13 | Project Mgr; Business Lead | 264h | 264h | draft SOPs |
| 381 | 5.4 | MS3: Requirements are reviewed and tested by business community | milestone | 0d | 2005-07-01 A | 2005-07-01 A | 360, 347 | 100% |  |  |  |  |  |  | must finish on 2005-12-15 | Business Lead; Business Community; Project Mgr |  |  | buiness community issues document |

| ID | WBS | Task | Type | Duration | Start | Finish | Predecessors | Complete | Remaining | Total slack | Free slack | Constraint | Resources | Work | Actual work |
| --- | --- | --- | --- | --- | --- | --- | --- | --- | --- | --- | --- | --- | --- | --- | --- |
| 382 | 6 | **Final Incident GIS SOPs** |  | 240d? | 2005-07-01 A | 2006-06-01 | 381 | 31% | 165.3d? | 21d |  |  | GSTOP Team | 3472h | 973.62h |
| 383 | 6.1 | Prep Final Text |  | 3d? | 2006-01-17 A | 2006-01-19 A |  | 100% |  |  |  | start no earlier than 2006-01-17 | GSTOP Team | 24h | 24h |
| 384 | 6.2 | Prep map product examples graphics with annotation, for web and hardcopy |  | 11d? | 2006-01-20 A | 2006-02-03 A | 383 | 100% |  |  |  |  | John Guthrie | 88h | 88h |
| 385 | 6.3 | Update MEDs |  | 10d? | 2006-01-19 A | 2006-02-01 A |  | 100% |  |  |  | start no earlier than 2006-01-19 | John Guthrie | 80h | 80h |
| 386 | 6.4 | Prep symbols graphics |  | 9d? | 2006-01-20 A | 2006-02-01 A |  | 100% |  |  |  | start no earlier than 2006-01-20 | Ken | 72h | 72h |
| 387 | 6.5 | Executive Summary and Introduction |  | 9d? | 2006-01-20 A | 2006-02-01 A |  | 100% |  |  |  | finish no earlier than 2006-02-01 | Business Lead | 72h | 72h |
| 388 | 6.6 | Final Draft SOP's Version 3 |  | 2d? | 2006-01-20 A | 2006-01-23 A |  | 100% |  |  |  |  | Yvonne | 16h | 16h |
| 389 | 6.7 | GTG Executive Committee Review |  | 3d? | 2006-02-14 A | 2006-02-16 A |  | 100% |  |  |  | start no earlier than 2006-02-14 | GTG | 24h | 24h |
| 390 | 6.8 | BLM Edit and Layout |  | 25d? | 2006-03-06 | 2006-04-07 |  |  |  | 60d |  | start no earlier than 2006-03-06 | BLM | 200h |  |
| 391 | 6.9 | Final Release to Web |  | 13d? | 2006-05-16 | 2006-06-01 |  |  |  | 21d |  | start no earlier than 2006-05-16 |  |  |  |
| 393 | 6.10 | MS5: GIS SOPs are finalized |  | 61d | 2005-07-01 | 2005-09-23 | 90, 130, 213, 273, 313, 343, 171 |  |  | 200d |  |  | Project Mgr; GSTOP Exec Comm | 976h |  |
| 394 | 6.11 | Deliver Final Incident GIS SOPs to Incident Based Automation Project | milestone | 0d | 2005-07-01 | 2005-07-01 |  |  |  | 261d |  |  |  |  |  |
| 395 | 6.12 | **Prepare delivery package for final SOPs to GTG** |  | 1d? | 2005-07-01 | 2005-07-01 |  |  |  | 260d |  |  |  |  |  |
| 396 | 6.12.1 | Prepare GIS SOP Implementation Plan |  | 1d? | 2005-07-01 | 2005-07-01 |  |  |  | 260d |  |  |  |  |  |
| 397 | 6.12.2 | **Prepare GIS SOP Change Management Plan** |  | 1d? | 2005-07-01 | 2005-07-01 |  |  |  | 260d |  |  |  |  |  |
| 398 | 6.12.2.1 | Develop GIS SOP Change Management Plan |  | 1d? | 2005-07-01 | 2005-07-01 |  |  |  | 260d |  |  |  |  |  |
| 399 | 6.12.2.2 | Review GIS SOP Change Management Plan |  | 1d? | 2005-07-01 | 2005-07-01 |  |  |  | 260d |  |  |  |  |  |
| 400 | 6.12.2.3 | Change Management Form |  | 1d? | 2005-07-01 | 2005-07-01 |  |  |  | 260d |  |  |  |  |  |
| 401 | 6.12.2.4 | Change Management Form on Internet |  | 1d? | 2005-07-01 | 2005-07-01 |  |  |  | 260d |  |  |  |  |  |
| 402 | 6.13 | MS6: Draft recommendation for SOP implementation | milestone | 0d | 2006-06-01 | 2006-06-01 |  |  |  | 0d |  | must finish on 2006-06-01 | GSTOP Team; GSTOP Exec Comm |  |  |
| 403 | 7 | **GSTOP Project Management** |  | 443d? | 2004-10-20 A | 2006-06-30 |  | 4% | 424.63d? | 0d |  |  | Sue McLellan | 5728h | 2160h |
| 404 | 7.1 | **Establish Subteam Business Practices** |  | 120d? | 2004-10-20 A | 2005-04-05 |  |  | 120d? | 323d |  |  |  | 8h |  |
| 405 | 7.1.1 | Review Business Practices Developed by Symbology SubTeam (communication, review process and change process) |  | 1d? | 2005-04-04 A | 2005-04-04 | 22 |  | 1d? | 323d | 0d |  | GSTOP Team | 8h |  |
| 406 | 7.1.2 | Finalize Sub-Team business practices |  | 1d? | 2005-04-05 | 2005-04-05 | 405 |  |  | 323d |  |  |  |  |  |
| 407 | 7.1.3 | Complete Team Operating Principles for document management (standard title page, headers/footers, naming convention, document location, etc.) |  | 1d? | 2004-10-20 | 2004-10-20 |  |  |  | 442d |  |  |  |  |  |
| 408 | 7.2 | Establish a process for providing feedback to Wildland Fire Agency Management from the GSTOP team |  | 1d? | 2004-10-20 | 2004-10-20 |  |  |  | 442d |  |  |  |  |  |

Notes:
- 393: Text1: final GIS SOPs
- 402: Text1: GIS SOP Implementation Recommendations
- 405: Text1: Sub-Team Business Practices
- 407: Text1: GSTOP document management guidelines
- 408: Text1: GSTOP communication process (to Wildland Fire Agency Management)

| ID | WBS | Task | Type | Duration | Start | Finish | Predecessors | Complete | Remaining | Total slack | Constraint | Resources | Work | Actual work |
| --- | --- | --- | --- | --- | --- | --- | --- | --- | --- | --- | --- | --- | --- | --- |
| 409 | 7.3 | **Conduct Periodic Conference Calls** |  | 284d? | 2004-10-20 | 2005-11-21 |  |  |  | 159d |  |  |  |  |
| 410 | 7.3.1 | Conference Call |  | 1d? | 2005-10-12 | 2005-10-12 |  |  |  | 187d | start no earlier than 2005-10-12 |  |  |  |
| 411 | 7.3.2 | Conference Call |  | 1d? | 2005-11-21 | 2005-11-21 |  |  |  | 159d | start no earlier than 2005-11-21 |  |  |  |
| 412 | 7.3.3 | Conference Call |  | 1d? | 2004-10-20 | 2004-10-20 |  |  |  | 442d |  |  |  |  |
| 413 | 7.4 | **Conduct Periodic Team Meetings** |  | 258d? | 2005-01-25 A | 2006-01-19 A |  | 100% |  |  |  | Project Mgr | 2160h | 2160h |
| 414 | 7.4.1 | January Team Meeting (Portland) |  | 3d | 2005-01-25 A | 2005-01-27 A |  | 100% |  |  | start no earlier than 2005-01-25 | GSTOP Team; Project Mgr | 48h | 48h |
| 415 | 7.4.2 | May Team Meeting (Denver) |  | 3d | 2005-05-10 A | 2005-05-12 A |  | 100% |  |  | start no earlier than 2005-05-10 | GSTOP Team; Project Mgr | 48h | 48h |
| 416 | 7.4.3 | January Team Meeting (Denver) |  | 3d? | 2006-01-17 A | 2006-01-19 A |  | 100% |  |  | finish no earlier than 2006-01-19 |  |  |  |
| 417 | 7.5 | **Develop GIS SOP Implementation Plan** |  | 379d? | 2005-01-18 | 2006-06-30 |  |  |  | 0d |  |  |  |  |
| 418 | 7.5.1 | Develop and implement GSTOP SOP User education and distribution strategy |  | 89d? | 2005-01-18 | 2005-05-20 |  |  |  | 290d | start no earlier than 2005-01-18 |  |  |  |
| 419 | 7.5.2 | Ensure incorporation of GSTOP deliverables into national and local training programs |  | 108d? | 2006-02-01 | 2006-06-30 |  |  |  | 0d | start no earlier than 2006-02-01 |  |  |  |
| 420 | 7.6 | **Closeout GSTOP Project** |  | 1d? | 2006-06-02 | 2006-06-02 | 402 |  |  | 20d |  | GTG Exec Comm | 16h |  |
| 421 | 7.6.1 | Convey final GSTOP deliverables to fire mapping tool development team (ESRI) |  | 1d? | 2006-06-02 | 2006-06-02 |  |  |  | 20d |  | GTG Joe Frost | 8h |  |
| 422 | 7.6.2 | Prepare GSTOP Team Recommendations |  | 1d? | 2006-06-02 | 2006-06-02 |  |  |  | 20d |  |  |  |  |
| 423 | 7.6.3 | Document Lessons Learned |  | 1d? | 2006-06-02 | 2006-06-02 |  |  |  | 20d |  |  |  |  |
| 424 | 7.6.4 | GSTOP Letters, Plaques, Coupons |  | 1d? | 2006-06-02 | 2006-06-02 |  |  |  | 20d |  |  |  |  |
| 425 | 7.6.5 | GSTOP Project Complete | milestone | 0d | 2006-06-02 | 2006-06-02 |  |  |  | 20d | finish no earlier than 2006-06-02 |  |  |  |
| 426 | 8 | **Implement GSTOP Project Communication Plan** |  | 402d? | 2004-10-20 A | 2006-05-04 |  | 5% | 381.31d? | 41d |  | Business Lead | 16496h | 2784.79h |
| 427 | 8.1 | **Create processes and methods for communication to stakeholders** |  | 168d? | 2004-10-20 A | 2005-06-10 |  | 4% | 161.59d? | 275d |  | Project Mgr | 8360h | 179.28h |
| 428 | 8.1.1 | **Establish communications with other projects/teams/agencies** |  | 114d? | 2004-12-01 A | 2005-05-09 |  |  | 114d? | 299d |  | GSTOP Team; IRMWT; NWCG Training Team; NWCG Working teams; NWCG PMO | 6840h |  |
| 429 | 8.1.1.1 | Establish interproject liaison and communication agreement and schedule with Incident-Based Automation project |  | 1d? | 2004-12-01 A | 2004-12-01 |  |  | 1d? | 412d | start no earlier than 2004-12-01 | Project Mgr | 8h |  |
| 430 | 8.1.1.2 | Establish interproject liaison and communication agreement and schedule with NWCG GIST position development and training effort |  | 26d | 2005-04-04 A | 2005-05-09 |  |  | 26d | 299d |  | Business Lead | 208h |  |
| 431 | 8.1.1.3 | Establish interproject liaison and communication agreement and schedule with NWCG DPRO training cirriculum revision effort |  | 26d | 2005-04-04 A | 2005-05-09 |  |  | 26d | 299d |  | Business Lead | 208h |  |
| 432 | 8.1.1.4 | Establish interproject liaison and communication agreement and schedule with SIT Unit Leader SME group |  | 26d | 2005-04-04 A | 2005-05-09 |  |  | 26d | 299d |  | Business Lead | 208h |  |
| 433 | 8.1.1.5 | Establish interproject liaison and communication agreement and schedule with NWCG Training WT |  | 26d | 2005-04-04 A | 2005-05-09 |  |  | 26d | 299d |  |  |  |  |
| 434 | 8.1.1.6 | Establish liaison relationships with Other All-Risk organizations involved with GIS SOP development [NIIMS Group,Department of Homeland Security (DHS),FEMA] |  | 60d? | 2005-02-15 A | 2005-05-09 |  |  | 60d? | 299d | finish no earlier than 2005-05-09 | NIIMS Group; Department of Homeland Security (DHS); FEMA | 1440h |  |
| 435 | 8.1.1.7 | Establish liaison relationships with Regional GIS coordinators |  | 26d? | 2005-04-04 | 2005-05-09 |  |  |  | 299d | finish no earlier than 2005-05-09 | Business Lead | 208h |  |
| 436 | 8.1.2 | Establish project status reporting processes |  | 1d? | 2004-12-06 A | 2004-12-06 |  |  | 1d? | 409d |  | Project Mgr | 8h |  |

Notes:
- 410: Text1: Conference Call Notes
- 411: Text1: Conference Call Notes
- 412: Text1: Conference Call Notes
- 415: Text1: Draft Sops
- 418: comm plan section 7: GSTOP SOP Users Strategy
- 421: ESRI; they already have created their software / may happen multiple times
- 425: Text1: GSTOP Final Report
- 427: comm plan section 3: communications responsibilities/project manager
- 428: comm plan section 4.1.3 Inter-project communications
- 429: Text1: GSTOP-IBA cooperative agreement
- 430: Text1: GSTOP-GIST position dvlpmtt/trng effort cooperative agreement
- 431: Text1: GSTOP-DPRO Training cirriculum revision effort cooperative agreement
- 432: Text1: GSTOP-SIT Unit Leader SME group cooperative agreement
- 433: Text1: GSTOP-NWCG Training WT cooperative agreement
- 436: Text1: Standard form for project progress reporting

| ID | WBS | Task | Type | Duration | Start | Finish | Predecessors | Complete | Remaining | Total slack | Free slack | Constraint | Resources | Work | Actual work | Text1 |
| --- | --- | --- | --- | --- | --- | --- | --- | --- | --- | --- | --- | --- | --- | --- | --- | --- |
| 437 | 8.1.3 | **Establish GSTOP Project communications methods** |  | 168d? | 2004-10-20 A | 2005-06-10 |  | 48% | 87.36d? | 275d |  |  |  | 168h | 128h |  |
| 438 | 8.1.3.1 | Establish team workspace on disaster help | milestone | 0d? | 2005-01-05 A | 2005-01-05 A |  | 100% |  |  |  |  |  |  |  |  |
| 439 | 8.1.3.2 | Find a storage location for GSTOP group review (NIFC site?) | milestone | 0d? | 2005-01-25 A | 2005-01-25 A |  | 100% |  |  |  |  |  |  |  | Location posted |
| 440 | 8.1.3.3 | **Establish GSTOP project webpages linked to GTG website** |  | 8d? | 2005-06-01 A | 2005-06-10 A |  | 100% |  |  |  |  | Project Mgr | 128h | 128h |  |
| 441 | 8.1.3.3.1 | Identify Website Content |  | 8d? | 2005-06-01 A | 2005-06-10 A |  | 100% |  |  |  | start no earlier than 2005-06-01 | Project Mgr | 64h | 64h |  |
| 442 | 8.1.3.4 | **Establish process for information dissemination to Wildland Fire Agency Management** |  | 1d? | 2004-10-20 | 2004-10-20 |  |  |  | 442d |  |  | Business Lead | 16h |  |  |
| 443 | 8.1.3.4.1 | Confirm which segment of "management" we need to communicate with when about what. |  | 0.33d? | 2004-10-20 | 2004-10-20 |  |  |  | 442.67d |  |  | Business Lead; Project Mgr; Susan Goodman | 8h |  |  |
| 444 | 8.1.3.4.2 | Design communciations and schedule for dissemination to Fire GIS qualified folks |  | 1d? | 2004-10-20 | 2004-10-20 |  |  |  | 442d |  |  |  |  |  |  |
| 445 | 8.1.3.4.3 | Complete distribution list of all regional key contacts for Fire GIS qualified staff |  | 1d? | 2004-10-20 | 2004-10-20 |  |  |  | 442d |  |  |  |  |  | List of all Fire GIS regional contacts |
| 446 | 8.1.3.4.4 | Advise regional Fire GIS contacts re: GSTOP communciation plan and schedule |  | 1d? | 2004-10-20 | 2004-10-20 |  |  |  | 442d |  |  |  |  |  | feedback |
| 447 | 8.1.3.4.5 | Adjust GSTOP Communciation plan for feedback |  | 1d? | 2004-10-20 | 2004-10-20 |  |  |  | 442d |  |  |  |  |  |  |
| 448 | 8.1.3.5 | **Establish process for information dissemination to Incident Management Teams via GACCs** |  | 1d? | 2004-10-20 | 2004-10-20 |  |  |  | 442d |  |  | Business Lead | 16h |  |  |
| 449 | 8.1.3.5.1 | Design communication and schedule (what messages, for whom when). |  | 0.33d? | 2004-10-20 | 2004-10-20 |  |  |  | 442.67d |  |  | Business Lead; Project Mgr; Susan Goodman | 8h |  |  |
| 450 | 8.1.3.5.2 | Advise NICC Coordinator re: planned communciations for GSTOP field test and rollout |  | 1d? | 2004-10-20 | 2004-10-20 |  |  |  | 442d |  |  |  |  |  | feedback |
| 451 | 8.1.3.6 | Establish process for reviewing and posting general project documents for view by project stakeholders |  | 1d? | 2004-10-20 | 2004-10-20 |  |  |  | 442d |  |  | Business Lead | 8h |  | GSTOP posting process (for project documents) |
| 452 | 8.1.3.7 | Establish process for developing and maintaining FAQs for GSTOP users |  | 1d? | 2004-10-20 | 2004-10-20 |  |  |  | 442d |  |  |  |  |  | GSTOP FAQ process (for project sponsors) |
| 453 | 8.1.3.8 | Establish process for developing and maintaining FAQ for business managers |  | 1d? | 2004-10-20 | 2004-10-20 |  |  |  | 442d |  |  |  |  |  | GSTOP FAQ process (for SOP users) |
| 454 | 8.1.4 | Develop a process for obtaining quantifiable feedback to evaluate the effectiveness of GSTOP communications efforts |  | 1d? | 2004-10-20 | 2004-10-20 |  |  |  | 442d |  |  |  |  |  |  |
| 455 | 8.2 | **Setup Project Briefings** |  | 2d? | 2005-01-25 A | 2005-01-26 |  |  | 2d? | 372d |  |  |  | 8h |  |  |
| 456 | 8.2.1 | Determine the set of meetings at which updates for the GSTOP project will be presented |  | 1d? | 2005-01-25 A | 2005-01-25 |  |  | 1d? | 372d | 0d |  | Business Lead | 8h |  | calendar of GSTOP project presentations |
| 457 | 8.2.2 | Schedule the presentations and all required logistics |  | 1d? | 2005-01-26 | 2005-01-26 | 456 |  |  | 372d |  |  |  |  |  |  |
| 458 | 8.3 | **Prepare Stakeholder Communications** |  | 1d? | 2004-10-20 | 2004-10-20 |  |  |  | 442d |  |  |  |  |  |  |
| 459 | 8.3.1 | Post general project documents for stakeholder view |  | 1d? | 2004-10-20 | 2004-10-20 |  |  |  | 442d |  |  |  |  |  | Project Charter, Project Plan, Staffing Plan |
| 460 | 8.3.2 | Develop GSTOP FAQs for users |  | 1d? | 2004-10-20 | 2004-10-20 |  |  |  | 442d |  |  |  |  |  | GSTOP FAQs for users |
| 461 | 8.3.3 | Develop GSTOP FAQs for business managers |  | 1d? | 2004-10-20 | 2004-10-20 |  |  |  | 442d |  |  |  |  |  | GSTOP FAQs for business managers |
| 462 | 8.3.4 | Develop GSTOP briefing(s) for GSTOP Sponsors |  | 1d? | 2004-10-20 | 2004-10-20 |  |  |  | 442d |  |  |  |  |  | GSTOP Sponsor Project Briefing(s) |
| 463 | 8.3.5 | Develop GSTOP briefing(s) for GSTOP Users |  | 1d? | 2004-10-20 | 2004-10-20 |  |  |  | 442d |  |  |  |  |  | GSTOP User Project Briefing(s) |
| 464 | 8.3.6 | Develop issue/white papers for Wildland Fire Agency Management |  | 1d? | 2004-10-20 | 2004-10-20 |  |  |  | 442d |  |  |  |  |  | GSTOP Issue/White Paper(s) |
| 465 | 8.3.7 | Develop GSTOP briefing(s) for Agency Technical community |  | 1d? | 2004-10-20 | 2004-10-20 |  |  |  | 442d |  |  |  |  |  | GSTOP Technical Briefing(s) |
| 466 | 8.3.8 | Develop standard form informational letters for general use throughout the project |  | 1d? | 2004-10-20 | 2004-10-20 |  |  |  | 442d |  |  |  |  |  |  |
| 467 | 8.3.9 | Develop GSTOP overview letter |  | 1d? | 2004-10-20 | 2004-10-20 |  |  |  | 442d |  |  |  |  |  |  |
| 468 | 8.3.10 | Develop GSTOP introduction letter soliciting input from other all-risk oganizations involved with GIS SOP development (include weblink to GSTOP project pages) |  | 1d? | 2004-10-20 | 2004-10-20 |  |  |  | 442d |  |  |  |  |  |  |

Notes:
- 454: comm plan 4.1.4 encouraging stakeholder feedback

| ID | WBS | Task | Duration | Start | Finish | Complete | Remaining | Total slack | Constraint | Resources | Work | Actual work | Text1 |
| --- | --- | --- | --- | --- | --- | --- | --- | --- | --- | --- | --- | --- | --- |
| 469 | 8.4 | **Conduct project briefings to stakeholders** | 402d? | 2004-10-20 A | 2006-05-04 | 35% | 262.17d? | 41d |  |  | 4912h | 2440h |  |
| 470 | 8.4.1 | **Conduct briefings for project sponsors (when and where?)** | 297d? | 2005-03-16 A | 2006-05-04 | 50% | 148.5d? | 41d |  | IRMWT; NWCG Member Agencies | 4880h | 2440h | Sponsor feedback |
| 471 | 8.4.1.1 | **Report to Executive Committee** | 297d? | 2005-03-16 A | 2006-05-04 | 50% | 148.5d? | 41d |  |  | 128h | 64h |  |
| 472 | 8.4.1.1.1 | 2005 Q1 Executive Briefing | 1d | 2005-03-16 A | 2005-03-16 A | 100% |  |  |  | Project Mgr; GTG Exec Comm | 16h | 16h | Executive Report |
| 473 | 8.4.1.1.2 | 2005 Q2 Executive Briefing | 1d | 2005-06-01 A | 2005-06-01 A | 100% |  |  | start no earlier than 2005-06-01 | Project Mgr; GTG Exec Comm | 16h | 16h | Executive Report |
| 474 | 8.4.1.1.3 | 2005 Q3 Executive Briefing | 1d? | 2005-09-01 A | 2005-09-01 A | 100% |  |  | start no earlier than 2005-09-01 | Project Mgr; GTG Exec Comm | 16h | 16h | Executive Report |
| 475 | 8.4.1.1.4 | 2005 Q4 Executive Briefing | 1d? | 2005-12-01 A | 2005-12-01 A | 100% |  |  | start no earlier than 2005-12-01 | Project Mgr; GTG Exec Comm | 16h | 16h | Executive Report |
| 476 | 8.4.1.1.5 | 2006 Q1 Executive Briefing | 1d? | 2006-02-14 | 2006-02-14 |  |  | 98d | finish no earlier than 2006-02-14 | Project Mgr; GTG Exec Comm | 16h |  | Executive Report |
| 477 | 8.4.1.1.6 | 2006 Q2 Executive Briefing | 3d | 2006-05-02 | 2006-05-04 |  |  | 41d | start no earlier than 2006-05-02 | Project Mgr; GTG Exec Comm | 48h |  | Executive Report |
| 478 | 8.4.2 | **Conduct project briefings at GSTOP SOP User community meetings (when and where?)** | 1d? | 2005-11-01 | 2005-11-01 |  |  | 173d |  | IMT Planning Section; Technical Specialists | 24h |  | GSTOP SOP User feedback |
| 479 | 8.4.2.1 | SIT Unit Leader SME meeting (where) | 1d? | 2005-11-01 | 2005-11-01 |  |  | 173d | start no earlier than 2005-11-01 | Business Lead | 8h |  | SIT Unit Leader SME group feedback |
| 480 | 8.4.3 | Conduct project briefings at Wildland Fire Agency Management business community meetings and conferences and agency meetings (when and where?) | 0.5d? | 2004-10-20 | 2004-10-20 |  |  | 442.5d |  | IMT Planning Section; Technical Specialists | 8h |  | Wildland Fire Agency Management feedback |
| 481 | 8.4.4 | **Conduct project briefings for Agency Technocal community (when and where?)** | 1d? | 2006-01-02 | 2006-01-02 |  |  | 129d |  |  |  |  | Agency Technical community feedback |
| 482 | 8.4.4.1 | Agency IRM meeting (where?) | 1d? | 2006-01-02 | 2006-01-02 |  |  | 129d | start no earlier than 2006-01-02 |  |  |  | Agency IRM feedback |
| 483 | 8.4.5 | Attend Fire Incident Mapping Tool beta test courses | 1d? | 2004-10-20 | 2004-10-20 |  |  | 442d |  |  |  |  | Feedback from Fire Incident Mapping Tool training |
