# GSTOP_rev 1

Schedule from MS Project, 2004-10-20 to 2006-06-02.
GSTOP Project Plan

## Calendars

- Standard: Mon-Fri 08:00-12:00, 13:00-17:00; Sat-Sun off.

## Resources

| Resource |
| --- |
| Sgoodman |
| Smclellan |
| Jfrost |
| GTG |
| GTG Exec Comm |
| Symbol Subteam |
| NWCG Training Team |
| GSTOP Team |
| subteam |
| NWCG member agencies |
| reviewers |
| GSTOP Team; GTG Exec Comm |
| subteam(s) |
| all concerned/impacted parties |
| business community |
| GSTOP Team; GTG; GTAG; |
| GSTOP Team; GTG |
| GSTOP Team; GTAG; |
| GSTOP Team; GTAG; somes other reviewers |
| GSTOP Team; GTG; GTAG |
| some other reviewers |
| subteams and Sue |
| gstop |
| GSTOP Team; Indepdent reviewer |
| subteams |
| Victoria |
| ; deb epps |
| BLM publication shop |
| GTG standards committee |
| Mary Kwart |
| Internet Search |
| Military |
| etc. |
| survey GISTs |
| Plans Sections (Mary Kwart) |
| Documents Sections |
| Business Lead |
| FGDC |
| NARA |
| agency guidance |
| TBD |
| GeoMAC |
| NPS I&M |
| NPS Focus |
| Sub-Team |
| Other "team" environs (e.g. military) |
| survey? Mary Kwart? |
| field teams |
| IRMWT |
| IRWMT |
| Project Mgr |
| Sean Triplett |
| IMT Teams |
| GTAG |
| Firescope |
| NWCG Agency Guidelines |
| books |
| media (including internet and magazines) |
| FEMA |
| NWCG Agency specific guidelines |
| GACC guidelines |
| Ken Bottle |

## Schedule

| ID | WBS | Task | Duration | Start | Finish | Predecessors | Baseline start | Baseline finish | Baseline duration | Total slack | Free slack | Constraint | Resources | Work | Text1 |
| --- | --- | --- | --- | --- | --- | --- | --- | --- | --- | --- | --- | --- | --- | --- | --- |
| 1 | 1 | **GSTOP Project Initiation** | 105d? | 2004-10-20 | 2005-03-15 |  | 2004-11-30 | 2004-12-31 | 23d? | 318d |  |  | IRMWT | 6264h |  |
| 2 | 1.1 | **Initiate the GSTOP Project** | 98d | 2004-10-20 | 2005-03-04 |  | 2004-11-30 | 2004-12-01 | 2d | 325d |  |  | GTG Exec Comm | 1392h |  |
| 3 | 1.1.1 | GSTOP Executive Committee Formed | 6d | 2004-12-01 | 2004-12-08 |  | 2004-12-01 | 2004-12-01 | 1d | 387d |  | finish no earlier than 2004-12-08 | IRWMT | 48h |  |
| 4 | 1.1.2 | GSTOP Project Manager Identified | 1d | 2004-10-20 | 2004-10-20 |  | 2004-11-30 | 2004-12-01 | 2d | 422d |  | finish no earlier than 2004-10-20 | GTG Exec Comm | 8h |  |
| 5 | 1.1.3 | GSTOP Project Charter Approved | 1d | 2004-12-01 | 2004-12-01 |  | 2004-12-01 | 2004-12-01 | 1d | 392d |  |  | NWCG member agencies | 8h | Project Charter |
| 6 | 1.1.4 | GSTOP Project Funding Secured | 68d | 2004-12-01 | 2005-03-04 |  | 2004-12-01 | 2004-12-01 | 1d | 325d |  | finish no earlier than 2005-03-04 | NWCG member agencies | 544h |  |
| 7 | 1.2 | **GSTOP Project Team Identified** | 75d? | 2004-12-01 | 2005-03-15 |  | 2004-12-01 | 2004-12-01 | 1d | 318d |  |  | GTG Exec Comm | 4032h | Team Roster |
| 8 | 1.2.1 | **Form the GSTOP Team** | 75d? | 2004-12-01 | 2005-03-15 |  | 2004-12-01 | 2004-12-31 | 22d? | 318d |  |  | GTG Exec Comm | 3424h |  |
| 9 | 1.2.1.1 | GSTOP Project Business Lead Identified | 29d | 2004-12-15 | 2005-01-24 |  | 2004-12-31 | 2004-12-31 | 0d | 354d |  | finish no earlier than 2005-01-24 | Project Mgr | 232h |  |
| 10 | 1.2.1.2 | Define and Assign Project Subteams and Leads | 5d? | 2005-01-24 | 2005-01-28 |  | 2004-12-01 | 2004-12-01 | 1d? | 350d |  | start no earlier than 2005-01-24 | Project Mgr | 40h |  |
| 11 | 1.2.1.3 | Develop Project Team Operating Principles & Guidelines | 5d? | 2005-01-24 | 2005-01-28 |  | 2004-12-01 | 2004-12-01 | 1d? | 350d |  | start no earlier than 2005-01-24 | Project Mgr | 40h | Operating Principles Doc |
| 12 | 1.2.1.4 | **Develop the GSTOP Project Management Plans** | 75d? | 2004-12-01 | 2005-03-15 |  | 2004-12-01 | 2004-12-06 | 4d? | 318d |  |  | Smclellan | 1984h |  |
| 13 | 1.2.1.4.1 | Review Charter and resolve any ambiguities/issues | 51d? | 2005-01-03 | 2005-03-14 |  | 2004-12-01 | 2004-12-01 | 1d? | 306d |  | start no earlier than 2005-01-03 | Project Mgr | 408h | Updated Charter |
| 14 | 1.2.1.4.2 | Develop Intial Project Work Plan | 50d? | 2005-01-04 | 2005-03-14 |  | 2004-12-01 | 2004-12-01 | 1d? | 306d |  | start no earlier than 2005-01-04 | Project Mgr | 400h | Work Plan |
| 15 | 1.2.1.4.3 | Develop Intial Project Communication Plan | 72d | 2004-12-06 | 2005-03-15 |  | 2004-12-06 | 2004-12-06 | 1d | 305d |  | finish no earlier than 2005-03-15 | Business Lead | 576h | Communication Plan |
| 16 | 1.2.1.4.4 | Develop Intial Project Responsibility Matrix | 1d? | 2004-12-01 | 2004-12-01 |  | 2004-12-01 | 2004-12-01 | 1d? | 379d |  |  |  |  |  |
| 17 | 1.2.1.4.5 | Develop Intial Project Resource Plan | 31d? | 2005-01-31 | 2005-03-14 |  | 2004-12-01 | 2004-12-01 | 1d? | 306d |  | start no earlier than 2005-01-31 |  |  | Staffing Plan |
| 18 | 1.2.1.5 | **Develop the GSTOP Communication and Management Structures** | 65d? | 2004-12-01 | 2005-03-01 |  | 2004-12-01 | 2004-12-01 | 1d? | 328d |  |  | Mary Kwart | 528h |  |
| 19 | 1.2.1.5.1 | Research 4 websites and select option for public communications | 1d? | 2004-12-01 | 2004-12-01 |  | 2004-12-01 | 2004-12-01 | 1d? | 379d |  |  |  |  |  |
| 20 | 1.2.1.5.2 | Create GSTOP private team workspace | 1d? | 2004-12-01 | 2004-12-01 |  | 2004-12-01 | 2004-12-01 | 1d? | 379d |  |  | Sean Triplett | 8h | Accessible Workspace |
| 21 | 1.2.1.5.3 | Develop Project Status Report Template | 42d? | 2005-01-03 | 2005-03-01 |  | 2004-12-01 | 2004-12-01 | 1d? | 315d |  | start no earlier than 2005-01-03 |  |  |  |
| 22 | 1.2.2 | Team Meeting | 5d? | 2005-01-24 | 2005-01-28 |  |  |  |  | 350d |  | finish no earlier than 2005-01-28 |  |  |  |
| 23 | 1.2.3 | Progress Report to Executive Committee | 1d? | 2005-03-15 | 2005-03-15 |  |  |  |  | 305d | 0d | start no earlier than 2005-03-15 | Smclellan | 8h | Executive Report |
| 25 | 2 | **GSTOP Requirements** | 13d? | 2005-03-15 | 2005-04-01 | 23 | 2004-12-31 | 2005-01-18 | 13d? | 305d |  |  | GSTOP Team | 408h |  |
| 26 | 2.1 | **Incident GIS Standard Symbology Requirements** | 4d? | 2005-03-16 | 2005-03-21 |  | 2004-12-31 | 2005-01-05 | 4d? | 314d |  |  | subteam | 104h |  |
| 27 | 2.1.1 | **Establish Symbols Sub-Team business practices** | 1d? | 2005-03-16 | 2005-03-16 |  | 2004-12-31 | 2004-12-31 | 1d? | 317d |  |  |  | 8h |  |
| 28 | 2.1.1.1 | **Develop a Symbol Sub-team Communication Plan** | 1d? | 2005-03-16 | 2005-03-16 |  | 2004-12-31 | 2004-12-31 | 1d? | 317d |  |  | Ken Bottle | 8h | Communication Plan |
| 29 | 2.1.1.1.1 | Define ground-rules for Sub-Team (internal) communication | 1d? | 2005-03-16 | 2005-03-16 |  | 2004-12-31 | 2004-12-31 | 1d? | 317d |  |  |  |  |  |
| 30 | 2.1.1.1.2 | Define ground-rules for communication between the Symbol Sub-Team and other GSTOP Sub-Teams | 1d? | 2005-03-16 | 2005-03-16 |  | 2004-12-31 | 2004-12-31 | 1d? | 317d |  |  |  |  |  |
| 31 | 2.1.1.1.3 | Define ground rules for communication between the Sub-Team and entities outside of the GSTOP Project | 1d? | 2005-03-16 | 2005-03-16 |  | 2004-12-31 | 2004-12-31 | 1d? | 317d |  |  |  |  |  |
| 32 | 2.1.1.1.4 | Establish a process and schedule for Sub-Team (internal) progress report updates | 1d? | 2005-03-16 | 2005-03-16 |  | 2004-12-31 | 2004-12-31 | 1d? | 317d |  |  |  |  |  |
| 33 | 2.1.1.1.5 | Establish a process and schedule for Sub-Team progress report updates to the GSTOP Team | 1d? | 2005-03-16 | 2005-03-16 |  | 2004-12-31 | 2004-12-31 | 1d? | 317d |  |  |  |  |  |

| ID | WBS | Task | Duration | Start | Finish | Baseline start | Baseline finish | Baseline duration | Total slack | Text1 |
| --- | --- | --- | --- | --- | --- | --- | --- | --- | --- | --- |
| 34 | 2.1.1.2 | **Establish Review Processes** | 1d? | 2005-03-16 | 2005-03-16 | 2004-12-31 | 2004-12-31 | 1d? | 317d | Symbol Set Review Process |
| 35 | 2.1.1.2.1 | Establish a process for Sub-Team (internal) review of potential symbols | 1d? | 2005-03-16 | 2005-03-16 | 2004-12-31 | 2004-12-31 | 1d? | 317d |  |
| 36 | 2.1.1.2.2 | Establish a process for Sub-Team (internal) review of the draft standard symbols | 1d? | 2005-03-16 | 2005-03-16 | 2004-12-31 | 2004-12-31 | 1d? | 317d |  |
| 37 | 2.1.1.2.3 | Establish a process for peer reviews | 1d? | 2005-03-16 | 2005-03-16 | 2004-12-31 | 2004-12-31 | 1d? | 317d |  |
| 38 | 2.1.1.2.4 | Establish a process for periodic GSTOP Team reviews | 1d? | 2005-03-16 | 2005-03-16 | 2004-12-31 | 2004-12-31 | 1d? | 317d |  |
| 39 | 2.1.1.2.5 | Establish a process for reviewing the final report | 1d? | 2005-03-16 | 2005-03-16 | 2004-12-31 | 2004-12-31 | 1d? | 317d |  |
| 40 | 2.1.1.3 | **Establish Change processes** | 1d? | 2005-03-16 | 2005-03-16 | 2004-12-31 | 2004-12-31 | 1d? | 317d | Symbol Set Change Process |
| 41 | 2.1.1.3.1 | Establish a process for additions/deletions of potential symbols mid-stream through the Project | 1d? | 2005-03-16 | 2005-03-16 | 2004-12-31 | 2004-12-31 | 1d? | 317d |  |
| 42 | 2.1.1.3.2 | Establish a change process for the additions/deletion of standard symbols after the final recommendation has been submitted and prior to completion of the GSTOP project | 1d? | 2005-03-16 | 2005-03-16 | 2004-12-31 | 2004-12-31 | 1d? | 317d |  |
| 43 | 2.1.1.3.3 | Establish a change process for the additions/deletion of standard symbols after the completion of the GSTOP project | 1d? | 2005-03-16 | 2005-03-16 | 2004-12-31 | 2004-12-31 | 1d? | 317d |  |
| 44 | 2.1.2 | **Establish symbol evaluation methods** | 1d? | 2005-03-16 | 2005-03-16 | 2004-12-31 | 2004-12-31 | 1d? | 317d |  |
| 45 | 2.1.2.1 | Define method for evaluating marker symbols | 1d? | 2005-03-16 | 2005-03-16 | 2004-12-31 | 2004-12-31 | 1d? | 317d |  |
| 46 | 2.1.2.2 | Define method for evaluating line symbols | 1d? | 2005-03-16 | 2005-03-16 | 2004-12-31 | 2004-12-31 | 1d? | 317d |  |
| 47 | 2.1.2.3 | Define method for evaluating fill symbols | 1d? | 2005-03-16 | 2005-03-16 | 2004-12-31 | 2004-12-31 | 1d? | 317d |  |
| 48 | 2.1.2.4 | Conduct a final review of evaluation methods | 1d? | 2005-03-16 | 2005-03-16 | 2004-12-31 | 2004-12-31 | 1d? | 317d | Standard Symbol Evaluation Methodology |
| 49 | 2.1.3 | **Define criteria for the acceptance of symbols as standards** | 1d? | 2005-03-16 | 2005-03-16 | 2004-12-31 | 2004-12-31 | 1d? | 317d |  |
| 50 | 2.1.3.1 | Develop acceptance criteria for marker symbols | 1d? | 2005-03-16 | 2005-03-16 | 2004-12-31 | 2004-12-31 | 1d? | 317d |  |
| 51 | 2.1.3.2 | Develop acceptance criteria for line symbols | 1d? | 2005-03-16 | 2005-03-16 | 2004-12-31 | 2004-12-31 | 1d? | 317d |  |
| 52 | 2.1.3.3 | Develop acceptance criteria for fill symbols | 1d? | 2005-03-16 | 2005-03-16 | 2004-12-31 | 2004-12-31 | 1d? | 317d |  |
| 53 | 2.1.3.4 | Conduct a final review of selection criteria | 1d? | 2005-03-16 | 2005-03-16 | 2004-12-31 | 2004-12-31 | 1d? | 317d | Standard Symbol Acceptance Criteria |
| 54 | 2.1.4 | **Establish file format for symbols** | 1d? | 2005-03-16 | 2005-03-16 | 2004-12-31 | 2004-12-31 | 1d? | 317d |  |
| 55 | 2.1.4.1 | Define acceptable formats of symbols for evaluation | 1d? | 2005-03-16 | 2005-03-16 | 2004-12-31 | 2004-12-31 | 1d? | 317d |  |
| 56 | 2.4.1.2 | Define format of recommended standard symbols | 1d? | 2005-03-16 | 2005-03-16 | 2004-12-31 | 2004-12-31 | 1d? | 317d |  |
| 57 | 2.1.5 | **Develop a list of symbols to be evaluated for acceptance as draft standards** | 1d? | 2005-03-16 | 2005-03-16 | 2004-12-31 | 2004-12-31 | 1d? | 317d |  |
| 58 | 2.1.5.1 | Collect Fire mapping symbols from the Fireline Handbook | 1d? | 2005-03-16 | 2005-03-16 | 2004-12-31 | 2004-12-31 | 1d? | 317d | symbol image files |
| 59 | 2.1.5.2 | Collect Fire mapping symbols suggestions from the 5 federal fire management agencies (FS, BLM, NPS, FWS, BIA) and state agencies via the NWCG Geospatial Task Group (GTG) | 1d? | 2005-03-16 | 2005-03-16 | 2004-12-31 | 2004-12-31 | 1d? | 317d | symbol image files |
| 60 | 2.1.5.3 | Collect Fire mapping symbols from HSA (FEMA), FAA, and DOD | 1d? | 2005-03-16 | 2005-03-16 | 2004-12-31 | 2004-12-31 | 1d? | 317d | symbol image files |
| 61 | 2.1.5.4 | Document potential sources for additional fire mapping symbols | 1d? | 2005-03-16 | 2005-03-16 | 2004-12-31 | 2004-12-31 | 1d? | 317d | List of data sources |
| 62 | 2.1.5.5 | Compile symbols into a single potential symbol set | 1d? | 2005-03-16 | 2005-03-16 | 2004-12-31 | 2004-12-31 | 1d? | 317d | Set of potential standard symbols |

| ID | WBS | Task | Duration | Start | Finish | Predecessors | Baseline start | Baseline finish | Baseline duration | Total slack | Free slack | Resources | Work | Text1 |
| --- | --- | --- | --- | --- | --- | --- | --- | --- | --- | --- | --- | --- | --- | --- |
| 63 | 2.1.6 | **Determine the draft standard marker symbols** | 1d? | 2005-03-16 | 2005-03-16 |  | 2004-12-31 | 2004-12-31 | 1d? | 317d |  |  | 16h |  |
| 64 | 2.1.6.1 | Evaluate each potential marker symbol against the marker symbol selection criteria | 1d? | 2005-03-16 | 2005-03-16 |  | 2004-12-31 | 2004-12-31 | 1d? | 317d |  |  |  | Marker Symbol Evaluation Document |
| 65 | 2.1.6.2 | Selection the draft standard marker symbols | 1d? | 2005-03-16 | 2005-03-16 |  | 2004-12-31 | 2004-12-31 | 1d? | 317d |  | Symbol Subteam | 8h | Draft list of selected marker symbols |
| 66 | 2.1.6.3 | Conduct a completeness review of the draft standard marker symbols | 1d? | 2005-03-16 | 2005-03-16 |  | 2004-12-31 | 2004-12-31 | 1d? | 317d |  | Symbol Subteam | 8h | Draft Standard Marker Symbols document |
| 67 | 2.1.7 | **Determine the draft standard line symbols** | 1d? | 2005-03-16 | 2005-03-16 |  | 2004-12-31 | 2004-12-31 | 1d? | 317d |  |  | 16h |  |
| 68 | 2.1.7.1 | Evaluate each potential line symbol against the line symbol selection criteria | 1d? | 2005-03-16 | 2005-03-16 |  | 2004-12-31 | 2004-12-31 | 1d? | 317d |  |  |  | Line Symbol Evaluation Document |
| 69 | 2.1.7.2 | Select the draft standard line symbols | 1d? | 2005-03-16 | 2005-03-16 |  | 2004-12-31 | 2004-12-31 | 1d? | 317d |  | Symbol Subteam | 8h | Draft list of selected Line symbols |
| 70 | 2.1.7.3 | Conduct a completeness review of the draft standard line symbols | 1d? | 2005-03-16 | 2005-03-16 |  | 2004-12-31 | 2004-12-31 | 1d? | 317d |  | Symbol Subteam | 8h | Draft Standard Line Symbols document |
| 71 | 2.1.8 | **Determine the draft standard fill symbols** | 1d? | 2005-03-16 | 2005-03-16 |  | 2004-12-31 | 2004-12-31 | 1d? | 317d |  |  | 16h |  |
| 72 | 2.1.8.1 | Evaluate each potential fill symbol against the fill symbol selection criteria | 1d? | 2005-03-16 | 2005-03-16 |  | 2004-12-31 | 2004-12-31 | 1d? | 317d |  |  |  | Fill Symbol Evaluation Document |
| 73 | 2.1.8.2 | Select the draft standard fill symbols | 1d? | 2005-03-16 | 2005-03-16 |  | 2004-12-31 | 2004-12-31 | 1d? | 317d |  | Symbol Subteam | 8h | Draft list of selected fill symbols |
| 74 | 2.1.8.3 | Conduct a completeness review of the draft standard fill symbols | 1d? | 2005-03-16 | 2005-03-16 |  | 2004-12-31 | 2004-12-31 | 1d? | 317d |  | Symbol Subteam | 8h | Draft Standard fill Symbols document |
| 75 | 2.1.9 | **Conduct initial peer review of the draft standard marker, line, and fill symbols** | 4d? | 2005-03-16 | 2005-03-21 |  | 2004-12-31 | 2005-01-05 | 4d? | 314d |  |  |  |  |
| 76 | 2.1.9.1 | Prepare draft standard symbols for initial peer review | 1d? | 2005-03-16 | 2005-03-16 |  | 2004-12-31 | 2004-12-31 | 1d? | 317d |  |  |  | Initial Peer Review Package |
| 77 | 2.1.9.2 | Submit the draft standard symbols to the 5 federal fire management agencies and State agencies via the NWCG Geospatial Task Group (GTG); and to the HSA (FEMA), FAA, DOD, and GSTOP Team for peer review | 1d? | 2005-03-16 | 2005-03-16 |  | 2004-12-31 | 2004-12-31 | 1d? | 314d | 0d |  |  | Submission Report |
| 78 | 2.1.9.3 | Review feedback of initial peer review | 1d? | 2005-03-17 | 2005-03-17 | 77 | 2005-01-03 | 2005-01-03 | 1d? | 314d | 0d |  |  | Initial Peer Review Document |
| 79 | 2.1.9.4 | Identify required changes to draft standard symbols based on the initial peer review feedback | 1d? | 2005-03-18 | 2005-03-18 | 78 | 2005-01-04 | 2005-01-04 | 1d? | 314d | 0d |  |  | List of required symbol changes |
| 80 | 2.1.9.5 | Make required changes, as identified, to draft standard symbols | 1d? | 2005-03-21 | 2005-03-21 | 79 | 2005-01-05 | 2005-01-05 | 1d? | 314d |  |  |  | Initial updated Symbols list |
| 81 | 2.1.10 | **Conduct final peer review of the draft standard marker, line and fill symbols** | 1d? | 2005-03-16 | 2005-03-16 |  | 2004-12-31 | 2004-12-31 | 1d? | 317d |  |  | 8h |  |
| 82 | 2.1.10.1 | Prepare draft standard symbols for final peer review | 1d? | 2005-03-16 | 2005-03-16 |  | 2004-12-31 | 2004-12-31 | 1d? | 317d |  |  |  | Final Peer Review Package |
| 83 | 2.1.10.2 | Submit the draft standard symbols to the 5 federal fire management agencies and State agencies via the NWCG Geospatial Task Group (GTG); and to the HSA (FEMA), FAA, DOD, and GSTOP Team for peer review | 1d? | 2005-03-16 | 2005-03-16 |  | 2004-12-31 | 2004-12-31 | 1d? | 317d |  |  |  | Submission Report |
| 84 | 2.1.10.3 | Review feedback of the final peer review | 1d? | 2005-03-16 | 2005-03-16 |  | 2004-12-31 | 2004-12-31 | 1d? | 317d |  |  |  | Final Peer Review Document |
| 85 | 2.1.10.4 | Identify required changes to draft standard symbols based on the final peer review feedback | 1d? | 2005-03-16 | 2005-03-16 |  | 2004-12-31 | 2004-12-31 | 1d? | 317d |  |  |  | List of required symbol changes |
| 86 | 2.1.10.5 | Make required changes, as identified, to draft standard symbols | 1d? | 2005-03-16 | 2005-03-16 |  | 2004-12-31 | 2004-12-31 | 1d? | 317d |  |  |  | final updated symbols list |
| 87 | 2.1.10.6 | Ratify the final draft standard symbols | 1d? | 2005-03-16 | 2005-03-16 |  | 2004-12-31 | 2004-12-31 | 1d? | 317d |  | Symbol Subteam | 8h | Final Draft Standard Symbols List |

| ID | WBS | Task | Duration | Start | Finish | Predecessors | Baseline start | Baseline finish | Baseline duration | Total slack | Free slack | Resources | Work | Text1 |
| --- | --- | --- | --- | --- | --- | --- | --- | --- | --- | --- | --- | --- | --- | --- |
| 88 | 2.1.11 | **Finalize recommendation of standard Fire Mapping symbols** | 1d? | 2005-03-16 | 2005-03-16 |  | 2004-12-31 | 2004-12-31 | 1d? | 317d |  |  | 8h |  |
| 89 | 2.1.11.1 | Create a report recommending the adoption of the draft standard symbols | 1d? | 2005-03-16 | 2005-03-16 |  | 2004-12-31 | 2004-12-31 | 1d? | 317d |  |  |  | Recommendation Report |
| 90 | 2.1.11.2 | Conduct a review of the report | 1d? | 2005-03-16 | 2005-03-16 |  | 2004-12-31 | 2004-12-31 | 1d? | 317d |  | Symbol Subteam | 8h | Finalized Recommendation Report |
| 91 | 2.1.11.3 | Submit the report to GSTOP-PM | 1d | 2005-03-16 | 2005-03-16 |  | 2004-12-31 | 2004-12-31 | 1d | 317d |  |  |  | Report Submission |
| 92 | 2.2 | **Incident GIS Standard Naming Conventions Requirements** | 12d? | 2005-03-16 | 2005-03-31 |  | 2004-12-31 | 2005-01-06 | 5d? | 306d |  |  |  |  |
| 93 | 2.2.1 | **Define Information Needs (What do we need to gather?)** | 1d? | 2005-03-16 | 2005-03-16 |  | 2004-12-31 | 2004-12-31 | 1d? | 317d |  |  |  |  |
| 94 | 2.2.1.1 | Set objectives for work plan | 1d? | 2005-03-16 | 2005-03-16 |  |  |  |  | 317d |  |  |  | document |
| 95 | 2.2.1.2 | Define ground rules for sub team | 1d? | 2005-03-16 | 2005-03-16 |  |  |  |  | 317d |  |  |  | document |
| 96 | 2.2.1.3 | Define common ground with other sub teams | 1d? | 2005-03-16 | 2005-03-16 |  |  |  |  | 317d |  |  |  | communications agreement |
| 97 | 2.2.2 | **Collect Information** | 1d? | 2005-03-16 | 2005-03-16 |  | 2005-01-03 | 2005-01-03 | 1d? | 312d |  |  |  |  |
| 98 | 2.2.2.1 | Collect existing naming and filing conventions from GIST's attached to IMT's | 1d? | 2005-03-16 | 2005-03-16 |  |  |  |  | 312d | 0d |  |  | physical examples |
| 99 | 2.2.3 | **Conduct Analysis** | 2d? | 2005-03-17 | 2005-03-18 | 98 | 2005-01-04 | 2005-01-04 | 1d? | 312d |  |  |  |  |
| 100 | 2.2.3.1 | Review strengths & weaknesses of existing methodologies | 1d? | 2005-03-17 | 2005-03-17 |  |  |  |  | 312d | 0d |  |  | shared |
| 101 | 2.2.3.2 | Resolve overlap and conflicts | 1d? | 2005-03-18 | 2005-03-18 | 100 |  |  |  | 312d | 0d |  |  |  |
| 102 | 2.2.4 | **Develop Preliminary Requirements Specifications** | 2d? | 2005-03-21 | 2005-03-22 | 101 | 2005-01-05 | 2005-01-05 | 1d? | 312d |  |  |  |  |
| 103 | 2.2.4.1 | Draft naming convention guidelines | 1d? | 2005-03-21 | 2005-03-21 |  |  |  |  | 312d | 0d |  |  |  |
| 104 | 2.2.4.2 | Draft directory structure guidelines | 1d? | 2005-03-22 | 2005-03-22 | 103 |  |  |  | 312d | 0d |  |  |  |
| 105 | 2.2.5 | **Requirements Review and Validation** | 1d? | 2005-03-23 | 2005-03-23 | 104 | 2005-01-06 | 2005-01-06 | 1d? | 312d |  |  |  |  |
| 106 | 2.2.5.1 | Post draft guidelines for inter team review | 1d? | 2005-03-23 | 2005-03-23 |  |  |  |  | 312d |  |  |  |  |
| 107 | 2.2.5.2 | Edit draft guidelines based on input | 1d? | 2005-03-23 | 2005-03-23 |  |  |  |  | 312d |  |  |  |  |
| 108 | 2.2.5.3 | Post draft guidelines for external review | 1d? | 2005-03-23 | 2005-03-23 |  |  |  |  | 312d |  |  |  |  |
| 109 | 2.2.5.4 | Edit draft guidelines based on input | 1d? | 2005-03-23 | 2005-03-23 |  |  |  |  | 312d |  |  |  |  |
| 110 | 2.2.6 | **Prepare Sample Documents** | 1d? | 2005-03-16 | 2005-03-16 |  |  |  |  | 317d |  |  |  |  |
| 111 | 2.2.6.1 | Prepare Naming conventions | 1d? | 2005-03-16 | 2005-03-16 |  |  |  |  | 317d |  |  |  |  |
| 112 | 2.2.6.2 | Develop Directory structure | 1d? | 2005-03-16 | 2005-03-16 |  |  |  |  | 317d |  |  |  |  |
| 113 | 2.2.6.3 | Prepare Methods of work | 1d? | 2005-03-16 | 2005-03-16 |  |  |  |  | 317d |  |  |  |  |

| ID | WBS | Task | Duration | Start | Finish | Predecessors | Baseline start | Baseline finish | Baseline duration | Total slack | Free slack |
| --- | --- | --- | --- | --- | --- | --- | --- | --- | --- | --- | --- |
| 114 | 2.2.7 | **Sample Documents Review and Validation** | 12d? | 2005-03-16 | 2005-03-31 |  |  |  |  | 306d |  |
| 115 | 2.2.7.1 | Post sample documents for inter team review | 1d? | 2005-03-16 | 2005-03-16 |  |  |  |  | 317d |  |
| 116 | 2.2.7.2 | Edit sample documents based on input | 1d? | 2005-03-16 | 2005-03-16 |  |  |  |  | 317d |  |
| 117 | 2.2.7.3 | Post sample documents for external review | 5d? | 2005-03-16 | 2005-03-22 |  | 2004-12-31 | 2005-01-17 | 12d? | 313d |  |
| 118 | 2.2.7.4 | Edit sample documents based on input | 12d? | 2005-03-16 | 2005-03-31 |  | 2004-12-31 | 2005-01-05 | 4d? | 306d |  |
| 119 | 2.3 | **Incident GIS Standard Product Definitions Requirements** | 8d? | 2005-03-16 | 2005-03-25 |  |  |  |  | 310d |  |
| 120 | 2.3.1 | **Define Information Needs (What do we need to gather?)** | 4d? | 2005-03-16 | 2005-03-21 |  |  |  |  | 314d |  |
| 121 | 2.3.1.1 | Develop Standard Products Matrix to compare many versions of standard products. (GIST Draft Taskbook/GIST Course Workbook/PNWCG Product Objectives) | 1d? | 2005-03-16 | 2005-03-16 |  | 2004-12-31 | 2004-12-31 | 1d? | 314d | 0d |
| 122 | 2.3.1.2 | Acquire DPRO Standards and incorporate into above matrix. | 1d? | 2005-03-17 | 2005-03-17 | 121 | 2005-01-03 | 2005-01-03 | 1d? | 314d | 0d |
| 123 | 2.3.1.3 | Need group assistance – there are no members who volunteered for this subgroup. It will need the participation of everyone to work. | 1d? | 2005-03-18 | 2005-03-18 | 122 | 2005-01-04 | 2005-01-04 | 1d? | 314d | 0d |
| 124 | 2.3.1.4 | Provide a final package of Standard Products including definitions and examples. | 1d? | 2005-03-21 | 2005-03-21 | 123 | 2005-01-05 | 2005-01-05 | 1d? | 314d |  |
| 125 | 2.3.2 | **Collect Information** | 3d? | 2005-03-16 | 2005-03-18 |  | 2005-01-06 | 2005-01-10 | 3d? | 310d |  |
| 126 | 2.3.2.1 | Definitions exist in the National Training course workbook for GIST. PNWCG has also created some standard definitions. Compile these into a list for group to review. Cite source. | 1d? | 2005-03-16 | 2005-03-16 |  | 2005-01-06 | 2005-01-06 | 1d? | 310d | 0d |
| 127 | 2.3.2.2 | Review DPRO product definitions and compare to existing definitions for GIST. | 1d? | 2005-03-17 | 2005-03-17 | 126 | 2005-01-07 | 2005-01-07 | 1d? | 310d | 0d |
| 128 | 2.3.2.3 | Collect examples of standard products. | 1d? | 2005-03-18 | 2005-03-18 | 127 | 2005-01-10 | 2005-01-10 | 1d? | 310d | 0d |
| 129 | 2.3.3 | **Conduct Analysis** | 2d? | 2005-03-21 | 2005-03-22 | 128 | 2005-01-11 | 2005-01-12 | 2d? | 310d |  |
| 130 | 2.3.3.1 | Review existing standards definitions (GIST course/PNWCG/DPRO) | 1d? | 2005-03-21 | 2005-03-21 |  | 2005-01-11 | 2005-01-11 | 1d? | 310d | 0d |
| 131 | 2.3.3.2 | Identify discrepancies between groups defining standard and bring these to the larger group for discussion and resolution. There may be specific reasons for discrepancies (Fire Use vs. Type 1) so these should be highlighted for the preliminary package. | 1d? | 2005-03-22 | 2005-03-22 | 130 | 2005-01-12 | 2005-01-12 | 1d? | 310d | 0d |
| 132 | 2.3.4 | **Develop Preliminary Requirements Specifications** | 2d? | 2005-03-23 | 2005-03-24 | 131 | 2005-01-13 | 2005-01-14 | 2d? | 310d |  |
| 133 | 2.3.4.1 | Provide a package of products definitions and samples for group review (GIST/SITL review?) | 1d? | 2005-03-23 | 2005-03-23 |  | 2005-01-13 | 2005-01-13 | 1d? | 310d | 0d |
| 134 | 2.3.4.2 | Find a storage location for GSTOP group review (NIFC site?) | 1d? | 2005-03-24 | 2005-03-24 | 133 | 2005-01-14 | 2005-01-14 | 1d? | 310d | 0d |
| 135 | 2.3.5 | **Review and Validate Requirements** | 1d? | 2005-03-25 | 2005-03-25 | 134 | 2005-01-17 | 2005-01-17 | 1d? | 310d |  |
| 136 | 2.3.5.1 | Decide upon method of acceptance/rejection/modification | 1d? | 2005-03-25 | 2005-03-25 |  | 2005-01-17 | 2005-01-17 | 1d? | 310d |  |
| 137 | 2.3.5.2 | Decide who to get feedback from (GIST 1st, then SITL/PLSC/others?) | 1d? | 2005-03-25 | 2005-03-25 |  | 2005-01-17 | 2005-01-17 | 1d? | 310d |  |
| 138 | 2.3.5.3 | Incorporate feedback into final package of definitions & samples | 1d? | 2005-03-25 | 2005-03-25 |  | 2005-01-17 | 2005-01-17 | 1d? | 310d |  |
| 139 | 2.3.5.4 | Find a permanent storage location for this package? National clearinghouse? | 1d? | 2005-03-25 | 2005-03-25 |  | 2005-01-17 | 2005-01-17 | 1d? | 310d |  |

| ID | WBS | Task | Duration | Start | Finish | Baseline start | Baseline finish | Baseline duration | Total slack | Work |
| --- | --- | --- | --- | --- | --- | --- | --- | --- | --- | --- |
| 140 | 2.4 | **Incident GIST Minimum Qualifications Requirements** | 1d? | 2005-03-16 | 2005-03-16 | 2004-12-31 | 2005-01-06 | 5d? | 317d | 64h |
| 141 | 2.4.1 | **Establish Min GIST qualifications/GIS expectations Sub-Team business practices** | 1d? | 2005-03-16 | 2005-03-16 |  |  |  | 317d |  |
| 142 | 2.4.1.1 | **Develop a Symbol Sub-team Communication Plan** | 1d? | 2005-03-16 | 2005-03-16 |  |  |  | 317d |  |
| 143 | 2.4.1.1.1 | Define ground-rules for Sub-Team (internal) communication | 1d? | 2005-03-16 | 2005-03-16 |  |  |  | 317d |  |
| 144 | 2.4.1.1.2 | Define ground-rules for communication between the Min GIST qualifications/GIS expectations Sub-Team and other GSTOP Sub-Teams | 1d? | 2005-03-16 | 2005-03-16 |  |  |  | 317d |  |
| 145 | 2.4.1.1.3 | Define ground rules for communication between the Sub-Team and entities outside of the GSTOP Project | 1d? | 2005-03-16 | 2005-03-16 |  |  |  | 317d |  |
| 146 | 2.4.1.1.4 | Establish a process and schedule for Sub-Team (internal) progress report updates | 1d? | 2005-03-16 | 2005-03-16 |  |  |  | 317d |  |
| 147 | 2.4.1.1.5 | Establish a process and schedule for Sub-Team progress report updates to the GSTOP Team | 1d? | 2005-03-16 | 2005-03-16 |  |  |  | 317d |  |
| 148 | 2.4.1.2 | **Establish Review Processes** | 1d? | 2005-03-16 | 2005-03-16 |  |  |  | 317d |  |
| 149 | 2.4.1.2.1 | Establish a process for Sub-Team (internal) review of potential minimum GIST qualifications/GIS expectations | 1d? | 2005-03-16 | 2005-03-16 |  |  |  | 317d |  |
| 150 | 2.4.1.2.2 | Establish a process for Sub-Team (internal) review of the draft minimum GIST qualifications/GIS expectations | 1d? | 2005-03-16 | 2005-03-16 |  |  |  | 317d |  |
| 151 | 2.4.1.2.3 | Establish a process for peer reviews | 1d? | 2005-03-16 | 2005-03-16 |  |  |  | 317d |  |
| 152 | 2.4.1.2.4 | Establish a process for periodic GSTOP Team reviews | 1d? | 2005-03-16 | 2005-03-16 |  |  |  | 317d |  |
| 153 | 2.4.1.2.5 | Establish a process for reviewing the final report | 1d? | 2005-03-16 | 2005-03-16 |  |  |  | 317d |  |
| 154 | 2.4.1.3 | **Establish Change processes** | 1d? | 2005-03-16 | 2005-03-16 |  |  |  | 317d |  |
| 155 | 2.4.1.3.1 | Establish a process for additions/deletions of potential minimum GIST qualifications/GIS expectations mid-stream through the project | 1d? | 2005-03-16 | 2005-03-16 |  |  |  | 317d |  |
| 156 | 2.4.1.3.2 | Establish a change process for the additions/deletion of minimum GIST qualifications/GIS expectations after the final recommendation has been submitted and prior to completion of the GSTOP project | 1d? | 2005-03-16 | 2005-03-16 |  |  |  | 317d |  |
| 157 | 2.4.1.3.3 | Establish a change process for the additions/deletion of minimum GIST qualifications/GIS expectations after the completion of the GSTOP project | 1d? | 2005-03-16 | 2005-03-16 |  |  |  | 317d |  |
| 158 | 2.4.2 | **Establish evaluation methods for minimum GIST qualifications/GIS expectations** | 1d? | 2005-03-16 | 2005-03-16 |  |  |  | 317d |  |
| 159 | 2.4.2.1 | Define method for evaluating minimum GIST qualifications/GIS expectations | 1d? | 2005-03-16 | 2005-03-16 |  |  |  | 317d |  |
| 160 | 2.4.2.2 | Conduct a final review of evaluation methods | 1d? | 2005-03-16 | 2005-03-16 |  |  |  | 317d |  |
| 161 | 2.4.3 | **Define criteria for the acceptance of minimum GIST qualifications/GIS expectations** | 1d? | 2005-03-16 | 2005-03-16 |  |  |  | 317d |  |
| 162 | 2.4.3.1 | Develop acceptance criteria for minimum GIST qualifications/GIS expectations | 1d? | 2005-03-16 | 2005-03-16 |  |  |  | 317d |  |
| 163 | 2.4.3.2 | Conduct a final review of selection criteria | 1d? | 2005-03-16 | 2005-03-16 |  |  |  | 317d |  |

Notes:
- 154: Text1: Change Process for Minimum GIST qualifications/GIS expectations
- 158: Text1: Evaluation Methodology for Minimum GIST Qualifications/GIS Expectations
- 161: Text1: Acceptance Criteria Set

| ID | WBS | Task | Duration | Start | Finish | Total slack | Resources | Work |
| --- | --- | --- | --- | --- | --- | --- | --- | --- |
| 164 | 2.4.4 | **Collect Information on minimum GIST qualifications and minimum GIS expectations on an incident** | 1d? | 2005-03-16 | 2005-03-16 | 317d |  | 64h |
| 165 | 2.4.4.1 | Gather documents and references (including white papers, memos, After Action Reviews) | 1d? | 2005-03-16 | 2005-03-16 | 317d | GTAG; Firescope; NWCG Agency Guidelines | 24h |
| 166 | 2.4.4.2 | Scan or translate paper documents to electronic format | 1d? | 2005-03-16 | 2005-03-16 | 317d | books; media (including internet and magazines) | 16h |
| 167 | 2.4.4.3 | Research current GIST/GIS standards | 1d? | 2005-03-16 | 2005-03-16 | 317d | FEMA; NWCG Agency specific guidelines; GACC guidelines | 24h |
| 168 | 2.4.5 | **Develop a list of GIST qualifications to be evaluated for acceptance as draft minimum standards** | 1d? | 2005-03-16 | 2005-03-16 | 317d |  |  |
| 169 | 2.4.5.1 | Compare the current GIST standards | 1d? | 2005-03-16 | 2005-03-16 | 317d |  |  |
| 170 | 2.4.5.2 | Compile the GIST qualifications into a single list of potential minimum GIST qualifications | 1d? | 2005-03-16 | 2005-03-16 | 317d |  |  |
| 171 | 2.4.5.3 | Compile a list of GIST qualifications which are deemed to be beyond the minimum for future reference | 1d? | 2005-03-16 | 2005-03-16 | 317d |  |  |
| 172 | 2.4.6 | **Develop a list of GIS expectations to be evaluated for acceptance as draft minimum standards** | 1d? | 2005-03-16 | 2005-03-16 | 317d |  |  |
| 173 | 2.4.6.1 | Compare any current GIS expectation standards | 1d? | 2005-03-16 | 2005-03-16 | 317d |  |  |
| 174 | 2.4.6.2 | Compile the GIS expectations into a list of potential minimum GIS expectations on an incident | 1d? | 2005-03-16 | 2005-03-16 | 317d |  |  |
| 175 | 2.4.6.3 | Compile a list of GIST qualifications which are deemed to be beyond the minimum for future reference | 1d? | 2005-03-16 | 2005-03-16 | 317d |  |  |
| 176 | 2.4.7 | **Determine the draft standard minimum GIST qualifications** | 1d? | 2005-03-16 | 2005-03-16 | 317d |  |  |
| 177 | 2.4.7.1 | Evaluate each potential minimum GIST qualification using the evaluation methods in 2.4.2 | 1d? | 2005-03-16 | 2005-03-16 | 317d |  |  |
| 178 | 2.4.7.2 | Select the minimum GIST qualifications | 1d? | 2005-03-16 | 2005-03-16 | 317d |  |  |
| 179 | 2.4.7.3 | Conduct a completeness review of the draft minimum GIST qualifications | 1d? | 2005-03-16 | 2005-03-16 | 317d |  |  |
| 180 | 2.4.8 | **Determine the draft standard minimum GIS expectations** | 1d? | 2005-03-16 | 2005-03-16 | 317d |  |  |
| 181 | 2.4.8.1 | Evaluate each potential minimum GIS expectation using the evaluation methods in 2.4.2 | 1d? | 2005-03-16 | 2005-03-16 | 317d |  |  |
| 182 | 2.4.8.2 | Select the minimum GIS expectations | 1d? | 2005-03-16 | 2005-03-16 | 317d |  |  |
| 183 | 2.4.8.3 | Conduct a completeness review of the draft minimum GIS expectations | 1d? | 2005-03-16 | 2005-03-16 | 317d |  |  |
| 184 | 2.4.9 | **Conduct internal review of draft standard minimum GIST qualifications and GIS expectations** | 1d? | 2005-03-16 | 2005-03-16 | 317d |  |  |
| 185 | 2.4.9.1 | Prepare draft standard minimum GIST qualifications and GIS expectations, including acceptance criteria | 1d? | 2005-03-16 | 2005-03-16 | 317d |  |  |
| 186 | 2.4.9.2 | Post draft standard to DisasterHelp website and notify GSTOP team for group review | 1d? | 2005-03-16 | 2005-03-16 | 317d |  |  |
| 187 | 2.4.9.3 | Provide data location and review process to internal group | 1d? | 2005-03-16 | 2005-03-16 | 317d |  |  |
| 188 | 2.4.9.4 | Review feedback of initial peer review | 1d? | 2005-03-16 | 2005-03-16 | 317d |  |  |
| 189 | 2.4.9.5 | Identify required changes to draft standard based on the initial peer review feedback | 1d? | 2005-03-16 | 2005-03-16 | 317d |  |  |
| 190 | 2.4.9.6 | Make required changes, as identified, to draft standard | 1d? | 2005-03-16 | 2005-03-16 | 317d |  |  |

Notes:
- 165: Text1: electronic format of original documents in folder on DisasterHelp site
- 166: Text1: electronic documents with quotes and bibliographic references
- 167: Text1: electronic format of original documents
- 169: Text1: matrix of similarities
- 170: Text1: list of minimum GIST qualifications for evaluation
- 171: Text1: list of other GIST qualifications (wish list)
- 173: Text1: matrix of similarities
- 174: Text1: list of minimum GIS expectations for evaluation
- 175: Text1: list of other GIS expectations (wish list)
- 176: Text1: Draft of minimum GIST qualifications standard
- 177: Text1: GIST qualifications evaluation document
- 178: Text1: Draft list of minimum GIST qualifications
- 179: Text1: Draft standard of the minimum GIST qualifications
- 180: Text1: Draft of minimum GIS expectations standard
- 181: Text1: GIS expectations evaluation document
- 182: Text1: Draft list of minimum GIS expectations
- 183: Text1: Draft standard of the minimum GIS expectations
- 185: Text1: Initial peer review package
- 186: Text1: Location posted, review team notified
- 187: Text1: Review report
- 188: Text1: Initial peer review document
- 189: Text1: List of required changes
- 190: Text1: Initial updated draft standard minimum GIST qualifications and GIS expectations

| ID | WBS | Task | Duration | Start | Finish | Predecessors | Baseline start | Baseline finish | Baseline duration | Total slack | Free slack | Work |
| --- | --- | --- | --- | --- | --- | --- | --- | --- | --- | --- | --- | --- |
| 191 | 2.4.10 | **Conduct final peer review of the draft standard minimum GIST qualifications and GIS expectations** | 1d? | 2005-03-16 | 2005-03-16 |  |  |  |  | 317d |  |  |
| 192 | 2.4.10.1 | Prepare survey or questionnaire to accompany draft standards for final peer review. | 1d? | 2005-03-16 | 2005-03-16 |  |  |  |  | 317d |  |  |
| 193 | 2.4.10.2 | Prepare draft standard minimum GIST Qualification/GIST expectations for final peer review, including the survey or questionnaire | 1d? | 2005-03-16 | 2005-03-16 |  |  |  |  | 317d |  |  |
| 194 | 2.4.10.3 | Submit the draft expectations to the 5 federal fire management agencies and State agencies via the NWCG Geospatial Task Group (GTG); and to the HSA (FEMA), FAA, DOD, and GSTOP Team for peer review. | 1d? | 2005-03-16 | 2005-03-16 |  |  |  |  | 317d |  |  |
| 195 | 2.4.10.4 | Review feedback of the final peer review, including questionnaire or survey | 1d? | 2005-03-16 | 2005-03-16 |  |  |  |  | 317d |  |  |
| 196 | 2.4.10.5 | Identify required changes to draft standard minimum GIST qualifications/GIS expectations based on the final peer review feedback | 1d? | 2005-03-16 | 2005-03-16 |  |  |  |  | 317d |  |  |
| 197 | 2.4.10.6 | Make required changes, as identified, to draft minimum GIST qualifications/GIS expectations symbols | 1d? | 2005-03-16 | 2005-03-16 |  |  |  |  | 317d |  |  |
| 198 | 2.4.10.7 | Ratify the final draft standard minimum GIST qualifications/GIS expectations | 1d? | 2005-03-16 | 2005-03-16 |  |  |  |  | 317d |  |  |
| 199 | 2.4.11 | **Finalize recommendation of standard Minimum GIST Qualifications and Minimum GIS Expectations on an Incident** | 1d? | 2005-03-16 | 2005-03-16 |  |  |  |  | 317d |  |  |
| 200 | 2.4.11.1 | Create a report recommending the adoption of the draft minimum GIST Qualifications/GIS Expectations | 1d? | 2005-03-16 | 2005-03-16 |  |  |  |  | 317d |  |  |
| 201 | 2.4.11.2 | Conduct a review of the report for completeness, accuracy, language, and grammar | 1d? | 2005-03-16 | 2005-03-16 |  |  |  |  | 317d |  |  |
| 202 | 2.4.11.3 | Submit the report to GSTOP-PM | 1d? | 2005-03-16 | 2005-03-16 |  |  |  |  | 317d |  |  |
| 203 | 2.5 | **Incident GIS Minimum Essential Datasets Requirements** | 13d? | 2005-03-15 | 2005-04-01 |  | 2004-12-31 | 2005-01-06 | 5d? | 305d |  | 136h |
| 204 | 2.5.1 | Establish MED Sub-Team business practices | 1d? | 2005-03-16 | 2005-03-16 |  |  |  |  | 317d |  |  |
| 205 | 2.5.2 | **Develop a MED Sub-team Communication Plan** | 13d? | 2005-03-16 | 2005-04-01 |  | 2004-12-31 | 2005-01-18 | 13d? | 305d |  |  |
| 206 | 2.5.2.1 | **Define ground-rules for Sub-Team (internal) communication** | 7d? | 2005-03-16 | 2005-03-24 |  | 2004-12-31 | 2005-01-10 | 7d? | 305d |  |  |
| 207 | 2.5.2.1.1 | Define ground-rules for communication between the MED Sub-Team and other GSTOP Sub-Teams | 1d? | 2005-03-16 | 2005-03-16 |  | 2004-12-31 | 2004-12-31 | 1d? | 305d | 0d |  |
| 208 | 2.5.2.1.2 | Define ground rules for communication between the Sub-Team and entities outside of the GSTOP Project | 1d? | 2005-03-17 | 2005-03-17 | 207 | 2005-01-03 | 2005-01-03 | 1d? | 305d | 0d |  |
| 209 | 2.5.2.1.3 | Establish a process and schedule for Sub-Team (internal) progress report updates | 1d? | 2005-03-18 | 2005-03-18 | 208 | 2005-01-04 | 2005-01-04 | 1d? | 305d | 0d |  |
| 210 | 2.5.2.1.4 | Establish a process and schedule for Sub-Team progress report updates to the GSTOP Team | 1d? | 2005-03-21 | 2005-03-21 | 209 | 2005-01-05 | 2005-01-05 | 1d? | 305d | 0d |  |
| 211 | 2.5.2.1.5 | Establish Review Processes | 1d? | 2005-03-22 | 2005-03-22 | 210 | 2005-01-06 | 2005-01-06 | 1d? | 305d | 0d |  |
| 212 | 2.5.2.1.6 | Establish a process for Sub-Team (internal) review of potential MEDs | 1d? | 2005-03-23 | 2005-03-23 | 211 | 2005-01-07 | 2005-01-07 | 1d? | 305d | 0d |  |
| 213 | 2.5.2.1.7 | Establish a process for Sub-Team (internal) review of the draft standard MEDs | 1d? | 2005-03-24 | 2005-03-24 | 212 | 2005-01-10 | 2005-01-10 | 1d? | 305d | 0d |  |
| 214 | 2.5.2.2 | **Establish a process for peer reviews** | 2d? | 2005-03-25 | 2005-03-28 | 213 | 2005-01-11 | 2005-01-12 | 2d? | 305d |  |  |
| 215 | 2.5.2.2.1 | Establish a process for periodic GSTOP Team reviews | 1d? | 2005-03-25 | 2005-03-25 |  | 2005-01-11 | 2005-01-11 | 1d? | 305d | 0d |  |
| 216 | 2.5.2.2.2 | Establish a process for reviewing the final report | 1d? | 2005-03-28 | 2005-03-28 | 215 | 2005-01-12 | 2005-01-12 | 1d? | 305d | 0d |  |

Notes:
- 192: Text1: Final Peer Review Questionnaire or survey
- 193: Text1: Final Peer Review Package
- 194: Text1: Submission Report
- 195: Text1: Final Peer Review Document
- 196: Text1: List of required changes
- 197: Text1: final updated list of minimum GIST qualifications and GIS expectations
- 198: Text1: Final Draft Standard Minimum GIST Qualifications/GIS Expectations
- 200: Text1: Recommendation Report
- 201: Text1: Finalized Recommendation Report
- 202: Text1: Report Submission
- 205: Text1: Communication Plan Document
- 206: Text1: Write Up
- 207: Text1: Write Up
- 208: Text1: Write Up
- 209: Text1: Write Up
- 210: Text1: Write Up
- 211: Text1: Review Process Document
- 212: Text1: Write Up
- 213: Text1: Write Up
- 214: Text1: Write Up
- 215: Text1: Write Up
- 216: Text1: Write Up

| ID | WBS | Task | Duration | Start | Finish | Predecessors | Baseline start | Baseline finish | Baseline duration | Total slack | Free slack | Text1 |
| --- | --- | --- | --- | --- | --- | --- | --- | --- | --- | --- | --- | --- |
| 217 | 2.5.2.3 | **Establish Change processes** | 2d? | 2005-03-29 | 2005-03-30 | 216 | 2005-01-13 | 2005-01-14 | 2d? | 305d |  | Change Process Document |
| 218 | 2.5.2.3.1 | Establish a process for additions/deletions of potential MEDs mid-stream through the Project | 1d? | 2005-03-29 | 2005-03-29 |  | 2005-01-13 | 2005-01-13 | 1d? | 305d | 0d | Write Up |
| 219 | 2.5.2.3.2 | Establish a change process for the additions/deletion of standard MEDs after the final recommendation has been submitted | 1d? | 2005-03-30 | 2005-03-30 | 218 | 2005-01-14 | 2005-01-14 | 1d? | 305d | 0d | Write Up |
| 220 | 2.5.2.4 | **Establish a change process for the additions/deletion of standard MEDs after the final recommendation has been approved through the GSTOP Project** | 1d? | 2005-03-31 | 2005-03-31 | 219 | 2005-01-17 | 2005-01-17 | 1d? | 305d |  | Write Up |
| 221 | 2.5.2.4.1 | Establish MED evaluation methods | 1d? | 2005-03-31 | 2005-03-31 |  | 2005-01-17 | 2005-01-17 | 1d? | 305d | 0d | Evaluation Methodology Document |
| 222 | 2.5.2.5 | Define method for evaluating marker MEDs | 1d? | 2005-04-01 | 2005-04-01 | 221 | 2005-01-18 | 2005-01-18 | 1d? | 305d |  | Write Up |
| 223 | 2.5.2.6 | Define method for evaluating line MEDs | 1d? | 2005-03-16 | 2005-03-16 |  | 2004-12-31 | 2004-12-31 | 1d? | 317d |  | Write Up |
| 224 | 2.5.3 | **Define method for evaluating fill MEDs** | 2d? | 2005-03-16 | 2005-03-17 |  | 2004-12-31 | 2005-01-03 | 2d? | 316d |  | Write Up |
| 225 | 2.5.3.1 | **Conduct a final review of evaluation methods** | 1d? | 2005-03-16 | 2005-03-16 |  | 2004-12-31 | 2004-12-31 | 1d? | 317d |  | Write Up |
| 226 | 2.5.3.1.1 | Define criteria for the acceptance of MEDs as standards | 1d? | 2005-03-16 | 2005-03-16 |  | 2004-12-31 | 2004-12-31 | 1d? | 317d |  | Acceptance Criteria Document |
| 227 | 2.5.3.1.2 | Develop acceptance criteria for marker MEDs | 1d? | 2005-03-16 | 2005-03-16 |  | 2004-12-31 | 2004-12-31 | 1d? | 317d |  | Write Up |
| 228 | 2.5.3.1.3 | Develop acceptance criteria for line MEDs | 1d? | 2005-03-16 | 2005-03-16 |  | 2004-12-31 | 2004-12-31 | 1d? | 317d |  | Write Up |
| 229 | 2.5.3.2 | **Develop acceptance criteria for fill MEDs** | 1d? | 2005-03-16 | 2005-03-16 |  | 2004-12-31 | 2004-12-31 | 1d? | 317d |  | Write Up |
| 230 | 2.5.3.2.1 | Conduct a final review of selection criteria | 1d? | 2005-03-16 | 2005-03-16 |  | 2004-12-31 | 2004-12-31 | 1d? | 317d |  | Write Up |
| 231 | 2.5.3.3 | **Develop a list of MEDs to be evaluated for acceptance as draft standards** | 1d? | 2005-03-16 | 2005-03-16 |  | 2004-12-31 | 2004-12-31 | 1d? | 317d |  | Deliverables |
| 232 | 2.5.3.3.1 | Collect Fire mapping MEDs from the 5 federal fire management agencies (FS, BLM, NPS, FWS, BIA), state agencies, and USGS via the NWCG Geospatial Task Group (GTG) | 1d? | 2005-03-16 | 2005-03-16 |  | 2004-12-31 | 2004-12-31 | 1d? | 317d |  | MED image files |
| 233 | 2.5.3.4 | **Collect Fire mapping MEDs from DHS (FEMA), FAA, and DOD** | 1d? | 2005-03-16 | 2005-03-16 |  | 2004-12-31 | 2004-12-31 | 1d? | 316d |  | MED image files |
| 234 | 2.5.3.4.1 | Document potential sources for additional fire mapping MEDs | 1d? | 2005-03-16 | 2005-03-16 |  | 2004-12-31 | 2004-12-31 | 1d? | 316d | 0d | List of data sources |
| 235 | 2.5.3.5 | Compile MEDs into a single potential MED set | 1d? | 2005-03-17 | 2005-03-17 | 234 | 2005-01-03 | 2005-01-03 | 1d? | 316d |  | Set of potential standard MEDs |
| 236 | 2.5.4 | **Determine the draft standard Raster MEDs** | 1d? | 2005-03-16 | 2005-03-16 |  | 2004-12-31 | 2004-12-31 | 1d? | 317d |  | Deliverables |
| 237 | 2.5.4.1 | **Evaluate each potential marker MED against the marker MED selection criteria** | 1d? | 2005-03-16 | 2005-03-16 |  | 2004-12-31 | 2004-12-31 | 1d? | 317d |  | MED Evaluation Document |
| 238 | 2.5.4.1.1 | Sub-Team selection of the draft standard marker MEDs | 1d? | 2005-03-16 | 2005-03-16 |  | 2004-12-31 | 2004-12-31 | 1d? | 317d |  | Draft list of selected MEDs |
| 239 | 2.5.4.1.2 | Conduct a Sub-team completeness review of the draft standard marker MEDs | 1d? | 2005-03-16 | 2005-03-16 |  | 2004-12-31 | 2004-12-31 | 1d? | 317d |  | Draft Standard Marker MEDs Document |
| 240 | 2.5.4.1.3 | Determine the draft standard Vector MEDs | 1d? | 2005-03-16 | 2005-03-16 |  | 2004-12-31 | 2004-12-31 | 1d? | 317d |  | Deliverables |
| 241 | 2.5.4.2 | Evaluate each potential line MED against the line MED selection criteria | 1d? | 2005-03-16 | 2005-03-16 |  | 2004-12-31 | 2004-12-31 | 1d? | 317d |  | MED Evaluation Document |

| ID | WBS | Task | Type | Duration | Start | Finish | Baseline start | Baseline finish | Baseline duration | Total slack | Resources | Work | Text1 |
| --- | --- | --- | --- | --- | --- | --- | --- | --- | --- | --- | --- | --- | --- |
| 242 | 2.5.4.3 | **Sub-Team selection of the draft standard line MEDs** |  | 1d? | 2005-03-16 | 2005-03-16 | 2004-12-31 | 2004-12-31 | 1d? | 317d |  |  | Draft list of selected MEDs |
| 243 | 2.5.4.3.1 | Conduct a Sub-team completeness review of the draft standard line MEDs |  | 1d? | 2005-03-16 | 2005-03-16 | 2004-12-31 | 2004-12-31 | 1d? | 317d |  |  | Draft Standard Line MEDs Document |
| 244 | 2.5.4.4 | Determine the draft standard Point MEDs |  | 1d? | 2005-03-16 | 2005-03-16 | 2004-12-31 | 2004-12-31 | 1d? | 317d |  |  | Deliverables |
| 245 | 2.5.4.5 | Evaluate each potential fill MED against the fill MED selection criteria |  | 1d? | 2005-03-16 | 2005-03-16 | 2004-12-31 | 2004-12-31 | 1d? | 317d |  |  | MED Evaluation Document |
| 246 | 2.5.4.6 | Sub-Team selection of the draft standard fill MEDs |  | 1d? | 2005-03-16 | 2005-03-16 | 2004-12-31 | 2004-12-31 | 1d? | 317d |  |  | Draft list of selected MEDs |
| 247 | 2.5.5 | Conduct a Sub-team completeness review of the draft standard fill MEDs |  | 1d? | 2005-03-16 | 2005-03-16 | 2004-12-31 | 2004-12-31 | 1d? | 317d | BLM publication shop | 8h | Draft Standard Fill MEDs Document |
| 248 | 2.5.6 | Conduct initial peer review of the draft standard marker, line, and fill MEDs |  | 1d? | 2005-03-16 | 2005-03-16 | 2004-12-31 | 2004-12-31 | 1d? | 317d | GSTOP Team | 8h | Deliverables |
| 249 | 2.5.7 | Prepare draft standard MEDs for initial peer review |  | 1d? | 2005-03-16 | 2005-03-16 | 2004-12-31 | 2004-12-31 | 1d? | 317d |  |  | Initial Peer Review Package |
| 250 | 2.5.8 | Submit the draft standard MEDs to the 5 federal fire management agencies, State agencies, and USGS via the NWCG Geospatial Task Group (GTG); and to DHS (FEMA), FAA, DOD, and GSTOP Team for peer review | milestone | 0d | 2005-03-15 | 2005-03-15 | 2004-12-31 | 2004-12-31 | 0d | 318d |  |  | Submission Report |
| 251 | 2.5.9 | Review feedback of initial peer review |  | 1d? | 2005-03-16 | 2005-03-16 | 2004-12-31 | 2004-12-31 | 1d? | 317d |  |  | Initial Peer Review Document |
| 252 | 2.5.10 | **Identify required changes to draft standard MEDs based on the initial peer review feedback** |  | 1d? | 2005-03-15 | 2005-03-16 | 2005-01-18 | 2005-01-19 | 1d? | 317d |  | 120h | List of required MED changes |
| 253 | 2.5.10.1 | **Make required changes, as identified, to draft standard MEDs** |  | 1d? | 2005-03-16 | 2005-03-16 | 2005-01-19 | 2005-01-19 | 1d? | 317d |  | 24h | Initial updated MEDs list |
| 254 | 2.5.10.1.1 | Conduct final peer review of the draft standard marker, line, and fill MEDs |  | 1d? | 2005-03-16 | 2005-03-16 | 2005-01-19 | 2005-01-19 | 1d? | 317d | NWCG Training Team | 8h | Deliverables |
| 255 | 2.5.10.1.2 | Prepare draft standard MEDs for final peer review |  | 1d? | 2005-03-16 | 2005-03-16 | 2005-01-19 | 2005-01-19 | 1d? | 317d | Victoria; ; deb epps | 16h | Final Peer Review Package |
| 256 | 2.5.10.2 | **Submit the draft standard MEDs to the 5 federal fire management agencies and State agencies via the NWCG Geospatial Task Group (GTG); and to the HSA (FEMA), FAA, DOD, and GSTOP Team for peer review** |  | 1d? | 2005-03-16 | 2005-03-16 | 2005-01-19 | 2005-01-19 | 1d? | 317d | subteam(s) | 32h | Submission Report |
| 257 | 2.5.10.2.1 | Review feedback of the final peer review |  | 1d? | 2005-03-16 | 2005-03-16 | 2005-01-19 | 2005-01-19 | 1d? | 317d | subteam(s) | 8h | Final Peer Review Document |
| 258 | 2.5.10.2.2 | Identify required changes to draft standard MEDs based on the final peer review feedback |  | 1d? | 2005-03-16 | 2005-03-16 | 2005-01-19 | 2005-01-19 | 1d? | 317d | subteam(s) | 8h | List of required MED changes |
| 259 | 2.5.10.2.3 | Make required changes, as identified, to draft standard MEDs |  | 1d? | 2005-03-16 | 2005-03-16 | 2005-01-19 | 2005-01-19 | 1d? | 317d | subteam(s) | 8h | final updated MEDs list |
| 260 | 2.5.10.2.4 | Ratification of the final draft standard MEDs by the Sub-Team |  | 1d? | 2005-03-16 | 2005-03-16 | 2005-01-19 | 2005-01-19 | 1d? | 317d |  |  | Final Draft Standard MEDs List |
| 261 | 2.5.10.3 | **Finalize recommendation of standard Fire Mapping MEDs** |  | 1d? | 2005-03-16 | 2005-03-16 | 2005-01-19 | 2005-01-19 | 1d? | 317d |  | 40h | Deliverables |
| 262 | 2.5.10.3.1 | Create a report recommending the adoption of the draft standard MEDs |  | 1d? | 2005-03-16 | 2005-03-16 | 2005-01-19 | 2005-01-19 | 1d? | 317d | GSTOP Team | 8h | Recommendation Report |
| 263 | 2.5.10.3.2 | Conduct a Sub-Team review of the report |  | 1d? | 2005-03-16 | 2005-03-16 | 2005-01-19 | 2005-01-19 | 1d? | 317d |  |  | Finalized Recommendation Report |
| 264 | 2.5.10.3.3 | Submit the report to GSTOP-PM |  | 1d? | 2005-03-16 | 2005-03-16 | 2005-01-19 | 2005-01-19 | 1d? | 317d |  |  | Report Submission |
| 265 | 2.5.10.3.4 | Review and Validate draft SOP’s for completeness |  | 0.5d? | 2005-03-16 | 2005-03-16 | 2005-01-19 | 2005-01-19 | 0.5d? | 317.5d | GSTOP Team; GTG; GTAG; some other reviewers | 8h |  |
| 266 | 2.5.10.3.5 | Review and Validate draft SOP’s for GIS content |  | 1d? | 2005-03-16 | 2005-03-16 | 2005-01-19 | 2005-01-19 | 1d? | 317d | GSTOP Team; GTAG; somes other reviewers | 8h |  |
| 267 | 2.5.10.3.6 | consolidate reviewers inputs |  | 1d? | 2005-03-16 | 2005-03-16 | 2005-01-19 | 2005-01-19 | 1d? | 317d |  |  |  |
| 268 | 2.5.10.3.7 | Evaluate Feedback for inclusion in SOP revision |  | 1d? | 2005-03-16 | 2005-03-16 | 2005-01-19 | 2005-01-19 | 1d? | 317d | GSTOP Team; Indepdent reviewer | 8h |  |
| 269 | 2.5.10.3.8 | Incorporate accepted feedback from reviewers |  | 1d? | 2005-03-16 | 2005-03-16 | 2005-01-19 | 2005-01-19 | 1d? | 317d | subteams | 8h | Revised Draft SOPs |

| ID | WBS | Task | Type | Duration | Start | Finish | Baseline start | Baseline finish | Baseline duration | Total slack | Constraint | Resources | Work |
| --- | --- | --- | --- | --- | --- | --- | --- | --- | --- | --- | --- | --- | --- |
| 270 | 2.5.10.4 | **Agencies' review of Draft SOPs** |  | 1d? | 2005-03-16 | 2005-03-16 | 2005-01-19 | 2005-01-19 | 1d? | 317d |  | all concerned/impacted parties | 16h |
| 271 | 2.5.10.4.1 | Create a cover letter, and response process |  | 1d? | 2005-03-16 | 2005-03-16 | 2005-01-19 | 2005-01-19 | 1d? | 317d |  |  |  |
| 272 | 2.5.10.4.2 | Review and Validate draft SOP’s |  | 1d? | 2005-03-16 | 2005-03-16 | 2005-01-19 | 2005-01-19 | 1d? | 317d |  | NWCG member agencies | 8h |
| 273 | 2.5.10.4.3 | Evaluate Feedback for inclusion in SOP revision |  | 1d? | 2005-03-16 | 2005-03-16 | 2005-01-19 | 2005-01-19 | 1d? | 317d |  |  |  |
| 274 | 2.5.10.4.4 | Incorporate Feedback from reviewers |  | 1d? | 2005-03-16 | 2005-03-16 | 2005-01-19 | 2005-01-19 | 1d? | 317d |  |  |  |
| 275 | 2.5.10.5 | Develop GSTOP Change Management Plan |  | 1d? | 2005-03-16 | 2005-03-16 | 2005-01-19 | 2005-01-19 | 1d? | 317d |  |  |  |
| 276 | 2.5.10.6 | Review GSTOP Change Management Plan |  | 1d? | 2005-03-16 | 2005-03-16 | 2005-01-19 | 2005-01-19 | 1d? | 317d |  | GTG Exec Comm | 8h |
| 277 | 2.5.10.7 | PRELIMINARY GIS SOP’s READY FOR FIELD TESTING | milestone | 0d | 2005-03-15 | 2005-03-15 | 2005-01-18 | 2005-01-18 | 0d | 318d | start no earlier than 2005-01-18 |  |  |
| 278 | 2.6 | **Incident GIS Standard Data Sharing and Archiving Standards (02-08-2005)** |  | 1d? | 2005-03-16 | 2005-03-16 |  |  |  | 317d |  |  |  |
| 279 | 2.6.1 | Define Information Needs (What do we need to gather?) |  | 1d? | 2005-03-16 | 2005-03-16 |  |  |  | 317d |  |  |  |
| 280 | 2.6.1.1 | Compile existing archiving standards in use (e.g. data format, transfer mode) |  | 1d? | 2005-03-16 | 2005-03-16 |  |  |  | 317d |  |  |  |
| 281 | 2.6.1.2 | Identify how archiving is done at present time by ICS, military, other incident responders, project-management |  | 1d? | 2005-03-16 | 2005-03-16 |  |  |  | 317d |  |  |  |
| 282 | 2.6.1.3 | Gather NARA, Records Management requirements (review policies, lawsuits) e.g. physical location, acceptable media, supporting documentation |  | 1d? | 2005-03-16 | 2005-03-16 |  |  |  | 317d |  |  |  |
| 283 | 2.6.1.4 | Determine the least common denominator (shapefile) or possibility of multiple formats |  | 1d? | 2005-03-16 | 2005-03-16 |  |  |  | 317d |  |  |  |
| 284 | 2.6.2 | **Collect Information** |  | 1d? | 2005-03-16 | 2005-03-16 |  |  |  | 317d |  |  |  |
| 285 | 2.6.2.1 | Conduct literature review |  | 1d? | 2005-03-16 | 2005-03-16 |  |  |  | 317d |  |  |  |
| 286 | 2.6.3 | **Conduct Analysis** |  | 1d? | 2005-03-16 | 2005-03-16 |  |  |  | 317d |  |  |  |
| 287 | 2.6.3.1 | Compile, Synthesize requirements |  | 1d? | 2005-03-16 | 2005-03-16 |  |  |  | 317d |  |  |  |
| 288 | 2.6.4 | **Develop Preliminary Requirements Specifications** |  | 1d? | 2005-03-16 | 2005-03-16 |  |  |  | 317d |  |  |  |
| 289 | 2.6.4.2 | Proposal of SOP |  | 1d? | 2005-03-16 | 2005-03-16 |  |  |  | 317d |  |  |  |
| 290 | 2.6.5 | **Review and Validate Requirements** |  | 1d? | 2005-03-16 | 2005-03-16 |  |  |  | 317d |  |  |  |
| 291 | 2.6.5.1 | Sub-Team Review of SOP |  | 1d? | 2005-03-16 | 2005-03-16 |  |  |  | 317d |  |  |  |
| 292 | 2.6.5.2 | Revise, Edit Proposed SOP |  | 1d? | 2005-03-16 | 2005-03-16 |  |  |  | 317d |  |  |  |
| 293 | 2.6.5.3 | Submit to Project Manager for Team Review |  | 1d? | 2005-03-16 | 2005-03-16 |  |  |  | 317d |  |  |  |

Notes:
- 280: Text1: GTG standards committee,Mary Kwart
- 281: Text1: Internet Search,Military,etc.,survey GISTs,Plans Sections (Mary Kwart),Documents Sections
- 282: Text1: Business Lead,FGDC,NARA,agency guidance
- 283: Text1: TBD
- 285: Text1: FGDC,GeoMAC,NPS I&M,NPS Focus,NARA
- 289: Text1: Sub-Team
- 291: Text1: Sub-Team
- 292: Text1: Sub-Team

| ID | WBS | Task | Duration | Start | Finish | Total slack | Text1 |
| --- | --- | --- | --- | --- | --- | --- | --- |
| 295 | 2.7 | **Incident GIS Standard Documentation and Archiving** | 1d? | 2005-03-16 | 2005-03-16 | 317d |  |
| 296 | 2.7.1 | **Incident GIS Standard Documentation and Archiving Procedures** | 1d? | 2005-03-16 | 2005-03-16 | 317d |  |
| 297 | 2.7.1.1 | Identify hierarchy of archive needs (incident, land unit, agency, NARA) | 1d? | 2005-03-16 | 2005-03-16 | 317d |  |
| 298 | 2.7.1.2 | Compile procedures currently in use | 1d? | 2005-03-16 | 2005-03-16 | 317d |  |
| 299 | 2.7.1.3 | Identify if existing procedures in use "somewhere out there" may be acceptible (e.g. NARA) | 1d? | 2005-03-16 | 2005-03-16 | 317d |  |
| 300 | 2.7.2 | Collect Information | 1d? | 2005-03-16 | 2005-03-16 | 317d |  |
| 301 | 2.7.2.1 | Identify test procedures for documentation and archiving | 1d? | 2005-03-16 | 2005-03-16 | 317d |  |
| 302 | 2.7.3 | Conduct Analysis | 1d? | 2005-03-16 | 2005-03-16 | 317d |  |
| 303 | 2.7.3.1 | Test and identify strengths/weaknesses of existing procedures | 1d? | 2005-03-16 | 2005-03-16 | 317d |  |
| 304 | 2.7.4 | Develop Preliminary Requirements Specifications | 1d? | 2005-03-16 | 2005-03-16 | 317d |  |
| 305 | 2.7.4.1 | Prepare recommendations | 1d? | 2005-03-16 | 2005-03-16 | 317d |  |
| 306 | 2.7.5 | Review and Validate Requirements | 1d? | 2005-03-16 | 2005-03-16 | 317d |  |
| 308 | 2.8 | **Incident GIS Transition Procedures** | 1d? | 2005-03-16 | 2005-03-16 | 317d |  |
| 309 | 2.8.1 | **Define Information Needs (What do we need to gather?)** | 1d? | 2005-03-16 | 2005-03-16 | 317d |  |
| 310 | 2.8.1.1 | Determine "universe" of transitions: (team to team); (team to unit); (team to archive) | 1d? | 2005-03-16 | 2005-03-16 | 317d | Business Lead,FGDC,NARA,agency guidance |
| 311 | 2.8.1.2 | Compile procedures currently in use | 1d? | 2005-03-16 | 2005-03-16 | 317d | Other "team" environs (e.g. military),survey? Mary Kwart? |
| 312 | 2.8.1.3 | Identify if existing procedures in use "somewhere out there" may be acceptible (e.g. NARA) | 1d? | 2005-03-16 | 2005-03-16 | 317d | Sub-Team |
| 313 | 2.8.2 | Evaluate Procedures | 1d? | 2005-03-16 | 2005-03-16 | 317d |  |
| 314 | 2.8.2.1 | Identify test procedures for documentation and archiving | 1d? | 2005-03-16 | 2005-03-16 | 317d | Sub-Team |
| 315 | 2.8.3 | **Conduct Analysis** | 1d? | 2005-03-16 | 2005-03-16 | 317d |  |
| 316 | 2.8.3.1 | Test and identify strengths/weaknesses of existing procedures | 1d? | 2005-03-16 | 2005-03-16 | 317d | Sub-Team,field teams |
| 317 | 2.8.4 | **Develop Preliminary Requirements Specifications** | 1d? | 2005-03-16 | 2005-03-16 | 317d |  |
| 318 | 2.8.4.1 | Prepare recommendations | 1d? | 2005-03-16 | 2005-03-16 | 317d |  |
| 319 | 2.8.5 | **Review and Validate Requirements** | 1d? | 2005-03-16 | 2005-03-16 | 317d |  |
| 320 | 2.8.5.1 | Sub-Team Review of SOP | 1d? | 2005-03-16 | 2005-03-16 | 317d | Sub-Team |
| 321 | 2.8.5.2 | Revise, Edit Proposed SOP | 1d? | 2005-03-16 | 2005-03-16 | 317d | Sub-Team |
| 322 | 2.8.6 | Submit to Project Manager for Team Review | 1d? | 2005-03-16 | 2005-03-16 | 317d |  |

| ID | WBS | Task | Duration | Start | Finish | Total slack | Resources | Work | Text1 |
| --- | --- | --- | --- | --- | --- | --- | --- | --- | --- |
| 324 | 3 | **Draft Incident GIS SOPs** | 1d? | 2004-12-01 | 2004-12-01 | 392d | GSTOP Team | 8h |  |
| 325 | 3.1 | Develop template for GIS SOPs for all Subgroups | 1d? | 2004-12-01 | 2004-12-01 | 392d |  |  | Template SOP |
| 326 | 3.2 | Define Information Needs (What do we need to gather?) | 1d? | 2004-12-01 | 2004-12-01 | 392d |  |  |  |
| 327 | 3.3 | Collect Information | 1d? | 2004-12-01 | 2004-12-01 | 392d |  |  |  |
| 328 | 3.4 | Conduct Analysis | 1d? | 2004-12-01 | 2004-12-01 | 392d |  |  |  |
| 329 | 3.5 | Develop Preliminary SOP’s | 1d? | 2004-12-01 | 2004-12-01 | 392d |  |  |  |
| 330 | 3.6 | Review and Validate draft SOP’s | 1d? | 2004-12-01 | 2004-12-01 | 392d |  |  |  |
| 331 | 3.7 | Incorporate Feedback from reviewers | 1d? | 2004-12-01 | 2004-12-01 | 392d |  |  |  |
| 332 | 3.8 | Develop GSTOP Change Management Plan | 1d? | 2004-12-01 | 2004-12-01 | 392d |  |  |  |
| 333 | 3.9 | Review GSTOP Change Management Plan | 1d? | 2004-12-01 | 2004-12-01 | 392d |  |  |  |
| 334 | 3.10 | PRELIMINARY GIS SOP’s READY FOR FIELD TESTING | 1d? | 2004-12-01 | 2004-12-01 | 392d |  |  |  |
| 335 | 4 | **Incident GIS SOPs Field Test** | 1d? | 2004-12-01 | 2004-12-01 | 392d | IMT Teams | 8h |  |
| 336 | 4.1 | Develop Quality Assurance and Field Test Plan | 1d? | 2004-12-01 | 2004-12-01 | 392d |  |  |  |
| 337 | 4.1.1 | develop questionnaire | 1d? | 2004-12-01 | 2004-12-01 | 392d |  |  |  |
| 338 | 4.2 | Execute Quality Assurance and Field Test Plan | 1d? | 2004-12-01 | 2004-12-01 | 392d |  |  |  |
| 339 | 4.2.1 | collect written/survey results from the field test | 1d? | 2004-12-01 | 2004-12-01 | 392d |  |  |  |
| 340 | 4.2.2 | conduct interviews with GISTs to measure success of Draft SOPs | 1d? | 2004-12-01 | 2004-12-01 | 392d |  |  |  |
| 341 | 4.2.3 | conduct interviews with SIT Unit Leaders to measure success of Draft SOPs | 1d? | 2004-12-01 | 2004-12-01 | 392d |  |  |  |
| 342 | 4.3 | Analyze Quality Assurance and Field Test Plan Results | 1d? | 2004-12-01 | 2004-12-01 | 392d |  |  |  |
| 343 | 4.4 | Ensure requirements are reviewed and tested by business community | 1d? | 2004-12-01 | 2004-12-01 | 392d |  |  |  |
| 344 | 5 | **Final Incident GIS SOPs** | 1d? | 2004-12-01 | 2004-12-01 | 392d | GSTOP Team | 8h |  |
| 345 | 5.1 | Analyze feedback on Incident GIS SOPs | 1d? | 2004-12-01 | 2004-12-01 | 392d |  |  |  |
| 346 | 5.2 | Update and finalize Incident GIS SOPs | 1d? | 2004-12-01 | 2004-12-01 | 392d |  |  |  |
| 347 | 5.3 | Deliver Final Incident GIS SOPs to Executive Committee | 1d? | 2004-12-01 | 2004-12-01 | 392d |  |  |  |
| 348 | 5.4 | Deliver Final Incident GIS SOPs to Incident Based Automation Project | 1d? | 2004-12-01 | 2004-12-01 | 392d |  |  |  |

| ID | WBS | Task | Duration | Start | Finish | Total slack | Constraint | Resources | Work |
| --- | --- | --- | --- | --- | --- | --- | --- | --- | --- |
| 349 | 6 | **GSTOP Project Closeout** | 393d? | 2004-12-01 | 2006-06-02 | 0d |  | GTG Exec Comm | 3144h |
| 350 | 6.1 | Prepare GSTOP Team Recommendations | 1d? | 2004-12-01 | 2004-12-01 | 392d |  |  |  |
| 351 | 6.2 | Document Lessons Learned | 1d? | 2004-12-01 | 2004-12-01 | 392d |  |  |  |
| 352 | 6.3 | GSTOP PROJECT TEAM RELEASED | 1d? | 2006-06-02 | 2006-06-02 | 0d | finish no earlier than 2006-06-02 |  |  |
