# GSTOP_rev 1

Schedule from MS Project, 2004-10-20 to 2006-06-02, status date 2005-03-23, A marks actual dates.
GSTOP Project Plan

## Calendars

- Standard: Mon-Fri 08:00-12:00, 13:00-17:00; Sat-Sun off.

## Resources

| Resource |
| --- |
| GTG |
| GTG Exec Comm |
| Symbol Subteam |
| NWCG Training Team |
| GSTOP Team |
| NWCG Member Agencies |
| Reviewers |
| GSTOP Subteam(s) |
| all concerned/impacted parties |
| Business Community |
| BLM publication shop |
| Business Lead |
| Business Lead |
| FGDC |
| NARA |
| GeoMAC |
| NPS I&M |
| NPS Focus |
| IRMWT |
| Project Mgr |
| Sean Triplett |
| IMT Teams |
| GTAG |
| Firescope |
| NWCG Agency |
| FEMA |
| GACC guidelines |
| Ken Bottle |
| Subteam Lead |
| Victoria Smith |
| Deb Epps |
| Independent Reviewer |
| GSTOP Exec Comm |
| John Guthrie |
| Karen Folger |
| Sherry Durst |
| Kim Kelly |
| Luther Arizana |
| Emmor Nile |
| Sue McLellan |
| StdProd Subteam |
| GIST Qual/GIS Min Expec Subteam |
| Elise Browne |
| MED Subteam |
| Eric |
| DataShareArcTrans Subteam |
| GTG Standards Committee |
| Internet Search |
| Military |
| etc. |
| survey GISTs |
| Plans Sections (Mary Kwart) |
| Documents Sections |
| Mary Kwart |
| agency guidance |
| TBD |
| Sub-Team |
| Other "team" environs (e.g. military) |
| survey? Mary Kwart? |
| field teams |

## Schedule

| ID | WBS | Task | Duration | Start | Finish | Predecessors | Complete | Remaining | Baseline start | Baseline finish | Baseline duration | Total slack | Free slack | Constraint | Resources | Work | Actual work | Text1 |
| --- | --- | --- | --- | --- | --- | --- | --- | --- | --- | --- | --- | --- | --- | --- | --- | --- | --- | --- |
| 1 | 1 | **Initiate the GSTOP Project** | 105d? | 2004-10-20 A | 2005-03-15 A |  | 100% |  | 2004-11-30 | 2004-12-01 | 2d |  |  |  | GTG Exec Comm | 5504h | 5504h |  |
| 2 | 1.1 | GSTOP Executive Committee Formed | 6d | 2004-12-01 A | 2004-12-08 A |  | 100% |  | 2004-12-01 | 2004-12-01 | 1d |  |  | finish no earlier than 2004-12-08 | IRMWT | 48h | 48h |  |
| 3 | 1.2 | GSTOP Project Manager Identified | 1d | 2004-10-20 A | 2004-10-20 A |  | 100% |  | 2004-11-30 | 2004-12-01 | 2d |  |  | finish no earlier than 2004-10-20 | GTG Exec Comm | 8h | 8h |  |
| 4 | 1.3 | GSTOP Project Charter Approved | 31d | 2004-10-20 A | 2004-12-01 A |  | 100% |  | 2004-12-01 | 2004-12-01 | 1d |  |  |  | NWCG Member Agencies | 248h | 248h | Project Charter |
| 5 | 1.4 | Secure GSTOP Project Funding | 68d | 2004-12-01 A | 2005-03-04 A |  | 100% |  | 2004-12-01 | 2004-12-01 | 1d |  |  | finish no earlier than 2005-03-04 | NWCG Member Agencies | 544h | 544h |  |
| 6 | 1.5 | **Identify GSTOP Project Team** | 74d? | 2004-12-02 A | 2005-03-15 A |  | 100% |  | 2004-12-01 | 2004-12-01 | 1d |  |  |  | GTG Exec Comm | 3816h | 3816h | Team Roster |
| 7 | 1.5.1 | **Form the GSTOP Team** | 74d? | 2004-12-02 A | 2005-03-15 A | 4 | 100% |  | 2004-12-01 | 2004-12-31 | 22d? |  |  |  | GTG Exec Comm | 3224h | 3224h |  |
| 8 | 1.5.1.1 | GSTOP Project Business Lead Identified | 29d | 2004-12-15 A | 2005-01-24 A |  | 100% |  | 2004-12-31 | 2004-12-31 | 0d |  |  | finish no earlier than 2005-01-24 | Project Mgr | 232h | 232h |  |
| 9 | 1.5.1.2 | Define and Assign Project Subteams and Leads | 5d? | 2004-12-02 A | 2004-12-08 A |  | 100% |  | 2004-12-01 | 2004-12-01 | 1d? |  |  |  | Project Mgr | 40h | 40h |  |
| 10 | 1.5.1.3 | Develop Project Team Operating Principles & Guidelines | 5d? | 2004-12-02 A | 2004-12-08 A |  | 100% |  | 2004-12-01 | 2004-12-01 | 1d? |  |  |  | Project Mgr | 40h | 40h | Operating Principles Doc |
| 11 | 1.5.1.4 | **Develop the GSTOP Project Management Plans** | 74d? | 2004-12-02 A | 2005-03-15 A |  | 100% |  | 2004-12-01 | 2004-12-06 | 4d? |  |  |  | Project Mgr | 1976h | 1976h |  |
| 12 | 1.5.1.4.1 | Review Charter and resolve any ambiguities/issues | 51d? | 2004-12-02 A | 2005-02-10 A |  | 100% |  | 2004-12-01 | 2004-12-01 | 1d? |  |  |  | Project Mgr | 408h | 408h | Updated Charter |
| 13 | 1.5.1.4.2 | Develop Intial Project Work Plan | 50d? | 2004-12-02 A | 2005-02-09 A |  | 100% |  | 2004-12-01 | 2004-12-01 | 1d? |  |  |  | Project Mgr | 400h | 400h | Work Plan |
| 14 | 1.5.1.4.3 | Develop Intial Project Communication Plan | 72d | 2004-12-06 A | 2005-03-15 A |  | 100% |  | 2004-12-06 | 2004-12-06 | 1d |  |  | finish no earlier than 2005-03-15 | Business Lead | 576h | 576h | Communication Plan |
| 15 | 1.5.1.4.4 | Develop Intial Project Responsibility Matrix | 1d? | 2004-12-02 A | 2004-12-02 A |  | 100% |  | 2004-12-01 | 2004-12-01 | 1d? |  |  |  |  |  |  |  |
| 16 | 1.5.1.4.5 | Develop Intial Project Resource Plan | 31d? | 2004-12-02 A | 2005-01-13 A |  | 100% |  | 2004-12-01 | 2004-12-01 | 1d? |  |  |  |  |  |  | Staffing Plan |
| 17 | 1.5.1.5 | **Setup the project team's structures for communication** | 42d? | 2004-12-02 A | 2005-01-28 A |  | 100% |  | 2004-12-01 | 2004-12-01 | 1d? |  |  |  | Business Lead | 344h | 344h |  |
| 18 | 1.5.1.5.1 | Create GSTOP private team workspace | 1d? | 2004-12-02 A | 2004-12-02 A |  | 100% |  | 2004-12-01 | 2004-12-01 | 1d? |  |  |  | Sean Triplett | 8h | 8h | Accessible Workspace |
| 19 | 1.5.1.5.2 | Develop Project Status Report Template | 42d? | 2004-12-02 A | 2005-01-28 A |  | 100% |  | 2004-12-01 | 2004-12-01 | 1d? |  |  |  |  |  |  |  |
| 21 | 2 | **GSTOP Requirements** | 132d? | 2004-12-01 A | 2005-06-02 | 400 | 15% | 111.98d? | 2004-12-31 | 2005-01-18 | 13d? | 247d | 0d |  | GSTOP Team | 6364h | 533.23h |  |
| 22 | 2.1 | **Incident GIS Standard Symbology Requirements** | 132d? | 2004-12-01 A | 2005-06-02 |  | 19% | 106.38d? | 2004-12-31 | 2005-01-05 | 4d? | -44d | 0d |  | Ken Bottle | 2448h | 204.96h |  |
| 23 | 2.1.1 | **Establish Symbols Sub-Team business practices** | 58d? | 2005-01-12 A | 2005-04-01 |  |  | 58d? | 2004-12-31 | 2004-12-31 | 1d? | 0d |  |  |  | 424h |  |  |
| 24 | 2.1.1.1 | **Develop a Symbol Sub-team Communication Plan** | 53d? | 2005-01-12 A | 2005-03-25 |  |  | 53d? | 2004-12-31 | 2004-12-31 | 1d? | 3d |  |  | Ken Bottle | 424h |  | Communication Plan |
| 25 | 2.1.1.1.1 | Define ground-rules for Sub-Team (internal) communication | 53d? | 2005-01-12 A | 2005-03-25 |  |  | 53d? | 2004-12-31 | 2004-12-31 | 1d? | 3d |  | finish no earlier than 2005-03-25 |  |  |  |  |
| 26 | 2.1.1.1.2 | Define ground-rules for communication between the Symbol Sub-Team and other GSTOP Sub-Teams | 53d? | 2005-01-12 A | 2005-03-25 |  |  | 53d? | 2004-12-31 | 2004-12-31 | 1d? | 3d |  | finish no earlier than 2005-03-25 |  |  |  |  |
| 27 | 2.1.1.1.3 | Define ground rules for communication between the Sub-Team and entities outside of the GSTOP Project | 53d? | 2005-01-12 A | 2005-03-25 |  |  | 53d? | 2004-12-31 | 2004-12-31 | 1d? | 3d |  | finish no earlier than 2005-03-25 |  |  |  |  |
| 28 | 2.1.1.1.4 | Establish a process and schedule for Sub-Team (internal) progress report updates | 53d? | 2005-01-12 A | 2005-03-25 |  |  | 53d? | 2004-12-31 | 2004-12-31 | 1d? | 3d |  | finish no earlier than 2005-03-25 |  |  |  |  |
| 29 | 2.1.1.1.5 | Establish a process and schedule for Sub-Team progress report updates to the GSTOP Team | 53d? | 2005-01-12 A | 2005-03-25 |  |  | 53d? | 2004-12-31 | 2004-12-31 | 1d? | 3d |  | finish no earlier than 2005-03-25 |  |  |  |  |

| ID | WBS | Task | Duration | Start | Finish | Predecessors | Complete | Remaining | Baseline start | Baseline finish | Baseline duration | Total slack | Free slack | Constraint | Resources | Work | Text1 |
| --- | --- | --- | --- | --- | --- | --- | --- | --- | --- | --- | --- | --- | --- | --- | --- | --- | --- |
| 30 | 2.1.1.2 | **Establish Review Processes** | 58d? | 2005-01-12 A | 2005-04-01 |  |  | 58d? | 2004-12-31 | 2004-12-31 | 1d? | 0d |  |  |  |  | Symbol Set Review Process |
| 31 | 2.1.1.2.1 | Establish a process for Sub-Team (internal) review of potential symbols | 58d? | 2005-01-12 A | 2005-04-01 |  |  | 58d? | 2004-12-31 | 2004-12-31 | 1d? | 0d |  | finish no earlier than 2005-04-01 |  |  |  |
| 32 | 2.1.1.2.2 | Establish a process for Sub-Team (internal) review of the draft standard symbols | 58d? | 2005-01-12 A | 2005-04-01 |  |  | 58d? | 2004-12-31 | 2004-12-31 | 1d? | 0d |  | finish no earlier than 2005-04-01 |  |  |  |
| 33 | 2.1.1.2.3 | Establish a process for peer reviews | 58d? | 2005-01-12 A | 2005-04-01 |  |  | 58d? | 2004-12-31 | 2004-12-31 | 1d? | 0d |  | finish no earlier than 2005-04-01 |  |  |  |
| 34 | 2.1.1.2.4 | Establish a process for periodic GSTOP Team reviews | 58d? | 2005-01-12 A | 2005-04-01 |  |  | 58d? | 2004-12-31 | 2004-12-31 | 1d? | 0d |  | finish no earlier than 2005-04-01 |  |  |  |
| 35 | 2.1.1.2.5 | Establish a process for reviewing the final report | 58d? | 2005-01-12 A | 2005-04-01 |  |  | 58d? | 2004-12-31 | 2004-12-31 | 1d? | 0d |  | finish no earlier than 2005-04-01 |  |  |  |
| 36 | 2.1.1.3 | **Establish Change processes** | 58d? | 2005-01-12 A | 2005-04-01 |  |  | 58d? | 2004-12-31 | 2004-12-31 | 1d? | 0d |  |  |  |  | Symbol Set Change Process |
| 37 | 2.1.1.3.1 | Establish a process for additions/deletions of potential symbols mid-stream through the Project | 58d? | 2005-01-12 A | 2005-04-01 |  |  | 58d? | 2004-12-31 | 2004-12-31 | 1d? | -58d | 0d |  |  |  |  |
| 38 | 2.1.1.3.2 | Establish a change process for the additions/deletion of standard symbols after the final recommendation has been submitted and prior to completion of the GSTOP project | 58d? | 2005-01-12 A | 2005-04-01 | 37 |  | 58d? | 2004-12-31 | 2004-12-31 | 1d? | -58d | 0d |  |  |  |  |
| 39 | 2.1.1.3.3 | Establish a change process for the additions/deletion of standard symbols after the completion of the GSTOP project | 58d? | 2005-01-12 A | 2005-04-01 | 38 |  | 58d? | 2004-12-31 | 2004-12-31 | 1d? | -2d | 0d |  |  |  |  |
| 40 | 2.1.2 | **Establish symbol evaluation methods** | 12d? | 2005-03-17 | 2005-04-01 |  |  |  | 2004-12-31 | 2004-12-31 | 1d? | -1d | 0d |  |  |  |  |
| 41 | 2.1.2.1 | Define method for evaluating marker symbols | 12d? | 2005-03-17 | 2005-04-01 |  |  |  | 2004-12-31 | 2004-12-31 | 1d? | -1d | 0d | finish no earlier than 2005-04-01 |  |  |  |
| 42 | 2.1.2.2 | Define method for evaluating line symbols | 12d? | 2005-03-17 | 2005-04-01 |  |  |  | 2004-12-31 | 2004-12-31 | 1d? | -1d | 0d | finish no earlier than 2005-04-01 |  |  |  |
| 43 | 2.1.2.3 | Define method for evaluating fill symbols | 12d? | 2005-03-17 | 2005-04-01 |  |  |  | 2004-12-31 | 2004-12-31 | 1d? | -1d | 0d | finish no earlier than 2005-04-01 |  |  |  |
| 44 | 2.1.2.4 | Conduct a final review of evaluation methods | 12d? | 2005-03-17 | 2005-04-01 |  |  |  | 2004-12-31 | 2004-12-31 | 1d? | -1d | 0d | finish no earlier than 2005-04-01 |  |  | Standard Symbol Evaluation Methodology |
| 45 | 2.1.3 | **Define criteria for the acceptance of symbols as standards** | 17d? | 2005-03-17 | 2005-04-08 |  |  |  | 2004-12-31 | 2004-12-31 | 1d? | -6d | 0d |  | John Guthrie; Karen Folger; Ken Bottle | 408h |  |
| 46 | 2.1.3.1 | Develop acceptance criteria for marker symbols | 17d? | 2005-03-17 | 2005-04-08 |  |  |  | 2004-12-31 | 2004-12-31 | 1d? | -6d | 0d | finish no earlier than 2005-04-08 |  |  |  |
| 47 | 2.1.3.2 | Develop acceptance criteria for line symbols | 17d? | 2005-03-17 | 2005-04-08 |  |  |  | 2004-12-31 | 2004-12-31 | 1d? | -6d | 0d | finish no earlier than 2005-04-08 |  |  |  |
| 48 | 2.1.3.3 | Develop acceptance criteria for fill symbols | 17d? | 2005-03-17 | 2005-04-08 |  |  |  | 2004-12-31 | 2004-12-31 | 1d? | -6d | 0d | finish no earlier than 2005-04-08 |  |  |  |
| 49 | 2.1.3.4 | Conduct a final review of selection criteria | 17d? | 2005-03-17 | 2005-04-08 |  |  |  | 2004-12-31 | 2004-12-31 | 1d? | -6d | 0d | finish no earlier than 2005-04-08 |  |  | Standard Symbol Acceptance Criteria |
| 50 | 2.1.4 | **Establish file format for symbols** | 44d? | 2005-02-01 A | 2005-04-01 |  |  | 44d? | 2004-12-31 | 2004-12-31 | 1d? | 0d |  |  |  |  |  |
| 51 | 2.1.4.1 | Define acceptable formats of symbols for evaluation | 44d? | 2005-02-01 A | 2005-04-01 |  |  | 44d? | 2004-12-31 | 2004-12-31 | 1d? | 0d |  | finish no earlier than 2005-04-01 |  |  |  |
| 52 | 2.4.1.2 | Define format of recommended standard symbols | 44d? | 2005-02-01 A | 2005-04-01 |  |  | 44d? | 2004-12-31 | 2004-12-31 | 1d? | 0d |  | finish no earlier than 2005-04-01 |  |  |  |
| 53 | 2.1.5 | **Develop a list of symbols to be evaluated for acceptance as draft standards** | 89d? | 2004-12-01 A | 2005-04-04 |  | 94% | 5.5d? | 2004-12-31 | 2004-12-31 | 1d? | -8d | 0d |  |  | 168h |  |
| 54 | 2.1.5.1 | Collect Fire mapping symbols from the Fireline Handbook | 81d? | 2004-12-01 A | 2005-03-23 A |  | 100% |  | 2004-12-31 | 2004-12-31 | 1d? |  |  |  |  |  | symbol image files |
| 55 | 2.1.5.2 | Collect Fire mapping symbols suggestions from the 5 federal fire management agencies (FS, BLM, NPS, FWS, BIA) and state agencies | 81d? | 2004-12-01 A | 2005-03-23 A |  | 100% |  | 2004-12-31 | 2004-12-31 | 1d? |  |  |  |  |  | symbol image files |
| 56 | 2.1.5.3 | Collect Fire mapping symbols suggestions from the BIA | 7d? | 2005-03-24 | 2005-04-01 | 55 |  |  | 2004-12-31 | 2004-12-31 | 1d? | -45d | 0d | finish no earlier than 2005-04-01 | Kim Kelly; Luther Arizana | 112h | symbol image files |
| 57 | 2.1.5.4 | Collect Fire mapping symbols from HSA (FEMA), FAA | 81d? | 2004-12-01 A | 2005-03-23 A |  | 100% |  | 2004-12-31 | 2004-12-31 | 1d? |  |  |  |  |  | symbol image files |
| 58 | 2.1.5.5 | Collect Fire mapping symbols from HSA (FEMA), FAA, and DOD | 7d? | 2005-03-24 | 2005-04-01 | 57 |  |  | 2004-12-31 | 2004-12-31 | 1d? | -44d | 0d | finish no earlier than 2005-04-01 | Sherry Durst | 56h | symbol image files |
| 59 | 2.1.5.6 | Document potential sources for additional fire mapping symbols | 1d? | 2005-03-16 | 2005-03-16 |  |  |  | 2004-12-31 | 2004-12-31 | 1d? | -32d | 0d |  |  |  | List of data sources |
| 60 | 2.1.5.7 | Compile symbols into a single potential symbol set | 1d? | 2005-04-04 | 2005-04-04 | 54, 55, 56, 57 |  |  | 2004-12-31 | 2004-12-31 | 1d? | -45d | 0d |  |  |  | Set of potential standard symbols |

| ID | WBS | Task | Type | Duration | Start | Finish | Predecessors | Baseline start | Baseline finish | Baseline duration | Total slack | Free slack | Constraint | Resources | Work | Text1 |
| --- | --- | --- | --- | --- | --- | --- | --- | --- | --- | --- | --- | --- | --- | --- | --- | --- |
| 61 | 2.1.6 | **Determine the draft standard marker symbols** |  | 8d? | 2005-04-05 | 2005-04-14 | 53 | 2004-12-31 | 2004-12-31 | 1d? | -45d | 0d |  |  | 72h |  |
| 62 | 2.1.6.1 | Evaluate each potential marker symbol against the marker symbol selection criteria |  | 1d? | 2005-04-05 | 2005-04-05 |  | 2004-12-31 | 2004-12-31 | 1d? | -38d | 0d |  |  |  | Marker Symbol Evaluation Document |
| 63 | 2.1.6.2 | Selection the draft standard marker symbols |  | 1d? | 2005-04-05 | 2005-04-05 |  | 2004-12-31 | 2004-12-31 | 1d? | -38d | 0d |  | Symbol Subteam | 8h | Draft list of selected marker symbols |
| 64 | 2.1.6.3 | Conduct a completeness review of the draft standard marker symbols |  | 8d? | 2005-04-05 | 2005-04-14 |  | 2004-12-31 | 2004-12-31 | 1d? | -45d | 0d | finish no earlier than 2005-04-14 | Symbol Subteam | 64h | Draft Standard Marker Symbols document |
| 65 | 2.1.7 | **Determine the draft standard line symbols** |  | 8d? | 2005-04-05 | 2005-04-14 | 53 | 2004-12-31 | 2004-12-31 | 1d? | -45d | 0d |  |  | 72h |  |
| 66 | 2.1.7.1 | Evaluate each potential line symbol against the line symbol selection criteria |  | 1d? | 2005-04-05 | 2005-04-05 |  | 2004-12-31 | 2004-12-31 | 1d? | -38d | 0d |  |  |  | Line Symbol Evaluation Document |
| 67 | 2.1.7.2 | Select the draft standard line symbols |  | 1d? | 2005-04-05 | 2005-04-05 |  | 2004-12-31 | 2004-12-31 | 1d? | -38d | 0d |  | Symbol Subteam | 8h | Draft list of selected Line symbols |
| 68 | 2.1.7.3 | Conduct a completeness review of the draft standard line symbols |  | 8d? | 2005-04-05 | 2005-04-14 |  | 2004-12-31 | 2004-12-31 | 1d? | -45d | 0d | finish no earlier than 2005-04-14 | Symbol Subteam | 64h | Draft Standard Line Symbols document |
| 69 | 2.1.8 | **Determine the draft standard fill symbols** |  | 8d? | 2005-04-05 | 2005-04-14 | 53 | 2004-12-31 | 2004-12-31 | 1d? | -45d | 0d |  |  | 72h |  |
| 70 | 2.1.8.1 | Evaluate each potential fill symbol against the fill symbol selection criteria |  | 1d? | 2005-04-05 | 2005-04-05 |  | 2004-12-31 | 2004-12-31 | 1d? | -38d | 0d |  |  |  | Fill Symbol Evaluation Document |
| 71 | 2.1.8.2 | Select the draft standard fill symbols |  | 1d? | 2005-04-05 | 2005-04-05 |  | 2004-12-31 | 2004-12-31 | 1d? | -38d | 0d |  | Symbol Subteam | 8h | Draft list of selected fill symbols |
| 72 | 2.1.8.3 | Conduct a completeness review of the draft standard fill symbols |  | 8d? | 2005-04-05 | 2005-04-14 |  | 2004-12-31 | 2004-12-31 | 1d? | -45d | 0d | finish no earlier than 2005-04-14 | Symbol Subteam | 64h | Draft Standard fill Symbols document |
| 73 | 2.1.9 | **Conduct initial peer review of the draft standard marker, line, and fill symbols** |  | 16d? | 2005-04-15 | 2005-05-06 | 61, 65, 69 | 2004-12-31 | 2005-01-05 | 4d? | -45d | 0d |  |  | 80h |  |
| 74 | 2.1.9.1 | Prepare draft standard symbols for initial peer review |  | 1d? | 2005-04-15 | 2005-04-15 |  | 2004-12-31 | 2004-12-31 | 1d? | -45d | 0d |  |  |  | Initial Peer Review Package |
| 75 | 2.1.9.2 | Submit the draft standard symbols to the 5 federal fire management agencies and State agencies via the NWCG Geospatial Task Group (GTG); and to the HSA (FEMA), FAA, DOD, and GSTOP Team for peer review | milestone | 0d | 2005-04-15 | 2005-04-15 | 74 | 2004-12-31 | 2004-12-31 | 1d? | -45d | 0d |  |  |  | Submission Report |
| 76 | 2.1.9.3 | Review draft Standard Symbols |  | 5d | 2005-04-18 | 2005-04-22 | 75 |  |  |  | -35d | 0d |  | GSTOP Team; GTG | 80h | Initial Feedback on Standard Symbols |
| 77 | 2.1.9.4 | Review feedback of initial peer review |  | 2d | 2005-05-02 | 2005-05-03 | 75FS+10d | 2005-01-03 | 2005-01-03 | 1d? | -45d | 0d |  |  |  | Initial Peer Review Document |
| 78 | 2.1.9.5 | Identify required changes to draft standard symbols based on the initial peer review feedback |  | 2d | 2005-05-04 | 2005-05-05 | 77 | 2005-01-04 | 2005-01-04 | 1d? | -45d | 0d |  |  |  | List of required symbol changes |
| 79 | 2.1.9.6 | Make required changes, as identified, to draft standard symbols |  | 1d? | 2005-05-06 | 2005-05-06 | 78 | 2005-01-05 | 2005-01-05 | 1d? | -45d | 0d |  |  |  | Initial updated Symbols list |
| 80 | 2.1.10 | **Conduct final peer review of the draft standard marker, line and fill symbols** |  | 17d? | 2005-05-09 | 2005-05-31 | 73 | 2004-12-31 | 2004-12-31 | 1d? | -45d | 0d |  |  | 88h |  |
| 81 | 2.1.10.1 | Prepare draft standard symbols for final peer review |  | 1d? | 2005-05-09 | 2005-05-09 |  | 2004-12-31 | 2004-12-31 | 1d? | -45d | 0d |  |  |  | Final Peer Review Package |
| 82 | 2.1.10.2 | Submit the draft standard symbols to the 5 federal fire management agencies and State agencies via the NWCG Geospatial Task Group (GTG); and to the HSA (FEMA), FAA, DOD, and GSTOP Team for peer review | milestone | 0d | 2005-05-09 | 2005-05-09 | 81 | 2004-12-31 | 2004-12-31 | 1d? | -45d | 0d |  |  |  | Submission Report |
| 83 | 2.1.10.3 | Review draft Standard Symbols |  | 10d | 2005-05-10 | 2005-05-23 | 82 |  |  |  | -45d | 0d |  | Reviewers | 80h | Final Feedback on Standard Symbols |
| 84 | 2.1.10.4 | Review feedback of the final peer review |  | 1d? | 2005-05-24 | 2005-05-24 | 83 | 2004-12-31 | 2004-12-31 | 1d? | -45d | 0d |  |  |  | Final Peer Review Document |
| 85 | 2.1.10.5 | Identify required changes to draft standard symbols based on the final peer review feedback |  | 2d | 2005-05-25 | 2005-05-26 | 84 | 2004-12-31 | 2004-12-31 | 1d? | -45d | 0d |  |  |  | List of required symbol changes |
| 86 | 2.1.10.6 | Make required changes, as identified, to draft standard symbols |  | 2d | 2005-05-27 | 2005-05-30 | 85 | 2004-12-31 | 2004-12-31 | 1d? | -45d | 0d |  |  |  | final updated symbols list |
| 87 | 2.1.10.7 | Ratify the final draft standard symbols |  | 1d? | 2005-05-31 | 2005-05-31 | 86 | 2004-12-31 | 2004-12-31 | 1d? | -45d | 0d |  | Symbol Subteam | 8h | Final Draft Standard Symbols List |

| ID | WBS | Task | Type | Duration | Start | Finish | Predecessors | Baseline start | Baseline finish | Baseline duration | Total slack | Free slack | Resources | Work | Text1 |
| --- | --- | --- | --- | --- | --- | --- | --- | --- | --- | --- | --- | --- | --- | --- | --- |
| 88 | 2.1.11 | **Finalize recommendation of standard Fire Mapping symbols** |  | 2d? | 2005-06-01 | 2005-06-02 | 80 | 2004-12-31 | 2004-12-31 | 1d? | -45d | 0d |  | 8h |  |
| 89 | 2.1.11.1 | Create a report recommending the adoption of the draft standard symbols |  | 1d? | 2005-06-01 | 2005-06-01 |  | 2004-12-31 | 2004-12-31 | 1d? | -45d | 0d |  |  | Recommendation Report |
| 90 | 2.1.11.2 | Conduct a review of the report |  | 1d? | 2005-06-02 | 2005-06-02 | 89 | 2004-12-31 | 2004-12-31 | 1d? | -45d | 0d | Symbol Subteam | 8h | Finalized Recommendation Report |
| 91 | 2.1.11.3 | Submit the report to GSTOP-PM | milestone | 0d | 2005-06-02 | 2005-06-02 | 90 | 2004-12-31 | 2004-12-31 | 1d | -45d | 0d |  |  | Report Submission |
| 92 | 2.2 | **Incident GIS Standard Naming Conventions Requirements** |  | 12d? | 2005-03-16 | 2005-03-31 |  | 2004-12-31 | 2005-01-06 | 5d? | 0d |  | Emmor Nile | 96h |  |
| 93 | 2.2.1 | **Define Information Needs (What do we need to gather?)** |  | 1d? | 2005-03-16 | 2005-03-16 |  | 2004-12-31 | 2004-12-31 | 1d? | 11d |  |  |  |  |
| 94 | 2.2.1.1 | Set objectives for work plan |  | 1d? | 2005-03-16 | 2005-03-16 |  |  |  |  | 11d |  |  |  | document |
| 95 | 2.2.1.2 | Define ground rules for sub team |  | 1d? | 2005-03-16 | 2005-03-16 |  |  |  |  | 11d |  |  |  | document |
| 96 | 2.2.1.3 | Define common ground with other sub teams |  | 1d? | 2005-03-16 | 2005-03-16 |  |  |  |  | 11d |  |  |  | communications agreement |
| 97 | 2.2.2 | **Collect Information** |  | 1d? | 2005-03-16 | 2005-03-16 |  | 2005-01-03 | 2005-01-03 | 1d? | 6d |  |  |  |  |
| 98 | 2.2.2.1 | Collect existing naming and filing conventions from GIST's attached to IMT's |  | 1d? | 2005-03-16 | 2005-03-16 |  |  |  |  | 6d | 0d |  |  | physical examples |
| 99 | 2.2.3 | **Conduct Analysis** |  | 2d? | 2005-03-17 | 2005-03-18 | 98 | 2005-01-04 | 2005-01-04 | 1d? | 6d |  |  |  |  |
| 100 | 2.2.3.1 | Review strengths & weaknesses of existing methodologies |  | 1d? | 2005-03-17 | 2005-03-17 |  |  |  |  | 6d | 0d |  |  | shared |
| 101 | 2.2.3.2 | Resolve overlap and conflicts |  | 1d? | 2005-03-18 | 2005-03-18 | 100 |  |  |  | 6d | 0d |  |  |  |
| 102 | 2.2.4 | **Develop Preliminary Requirements Specifications** |  | 2d? | 2005-03-21 | 2005-03-22 | 101 | 2005-01-05 | 2005-01-05 | 1d? | 6d |  |  |  |  |
| 103 | 2.2.4.1 | Draft naming convention guidelines |  | 1d? | 2005-03-21 | 2005-03-21 |  |  |  |  | 6d | 0d |  |  |  |
| 104 | 2.2.4.2 | Draft directory structure guidelines |  | 1d? | 2005-03-22 | 2005-03-22 | 103 |  |  |  | 6d | 0d |  |  |  |
| 105 | 2.2.5 | **Requirements Review and Validation** |  | 1d? | 2005-03-23 | 2005-03-23 | 104 | 2005-01-06 | 2005-01-06 | 1d? | 6d |  |  |  |  |
| 106 | 2.2.5.1 | Post draft guidelines for inter team review |  | 1d? | 2005-03-23 | 2005-03-23 |  |  |  |  | 6d |  |  |  |  |
| 107 | 2.2.5.2 | Edit draft guidelines based on input |  | 1d? | 2005-03-23 | 2005-03-23 |  |  |  |  | 6d |  |  |  |  |
| 108 | 2.2.5.3 | Post draft guidelines for external review |  | 1d? | 2005-03-23 | 2005-03-23 |  |  |  |  | 6d |  |  |  |  |
| 109 | 2.2.5.4 | Edit draft guidelines based on input |  | 1d? | 2005-03-23 | 2005-03-23 |  |  |  |  | 6d |  |  |  |  |
| 110 | 2.2.6 | **Prepare Sample Documents** |  | 1d? | 2005-03-16 | 2005-03-16 |  |  |  |  | 11d |  |  |  |  |
| 111 | 2.2.6.1 | Prepare Naming conventions |  | 1d? | 2005-03-16 | 2005-03-16 |  |  |  |  | 11d |  |  |  |  |
| 112 | 2.2.6.2 | Develop Directory structure |  | 1d? | 2005-03-16 | 2005-03-16 |  |  |  |  | 11d |  |  |  |  |
| 113 | 2.2.6.3 | Prepare Methods of work |  | 1d? | 2005-03-16 | 2005-03-16 |  |  |  |  | 11d |  |  |  |  |

| ID | WBS | Task | Duration | Start | Finish | Predecessors | Remaining | Baseline start | Baseline finish | Baseline duration | Total slack | Free slack | Resources | Work | Text1 |
| --- | --- | --- | --- | --- | --- | --- | --- | --- | --- | --- | --- | --- | --- | --- | --- |
| 114 | 2.2.7 | **Sample Documents Review and Validation** | 12d? | 2005-03-16 | 2005-03-31 |  |  |  |  |  | 0d |  |  |  |  |
| 115 | 2.2.7.1 | Post sample documents for inter team review | 1d? | 2005-03-16 | 2005-03-16 |  |  |  |  |  | 11d |  |  |  |  |
| 116 | 2.2.7.2 | Edit sample documents based on input | 1d? | 2005-03-16 | 2005-03-16 |  |  |  |  |  | 11d |  |  |  |  |
| 117 | 2.2.7.3 | Post sample documents for external review | 5d? | 2005-03-16 | 2005-03-22 |  |  | 2004-12-31 | 2005-01-17 | 12d? | 7d |  |  |  |  |
| 118 | 2.2.7.4 | Edit sample documents based on input | 12d? | 2005-03-16 | 2005-03-31 |  |  | 2004-12-31 | 2005-01-05 | 4d? | 0d |  |  |  |  |
| 119 | 2.3 | **Incident GIS Standard Product Definitions Requirements** | 65d? | 2005-02-09 A | 2005-05-11 |  | 65d? |  |  |  | -29d | 0d | Karen Folger | 712h |  |
| 120 | 2.3.1 | **Establish Std Products Subteam Business Practices** | 14d? | 2005-03-16 | 2005-04-04 |  |  |  |  |  | -2d | 0d |  | 8h | WBS |
| 121 | 2.3.1.1 | **Develop a Std Products Sub-team Communication Plan** | 1d? | 2005-03-16 | 2005-03-16 |  |  |  |  |  | 11d |  |  |  | Communication Plan |
| 122 | 2.3.1.1.1 | Define ground-rules for Sub-Team (internal) communication | 1d? | 2005-03-16 | 2005-03-16 |  |  |  |  |  | 11d |  |  |  |  |
| 123 | 2.3.1.1.2 | Define ground-rules for communication between the Sub-Team and other GSTOP Sub-Teams | 1d? | 2005-03-16 | 2005-03-16 |  |  |  |  |  | 11d |  |  |  |  |
| 124 | 2.3.1.1.3 | Define ground rules for communication between the Sub-Team and entities outside of the GSTOP Project | 1d? | 2005-03-16 | 2005-03-16 |  |  |  |  |  | 11d |  |  |  |  |
| 125 | 2.3.1.1.4 | Establish a process and schedule for Sub-Team (internal) progress report updates | 1d? | 2005-03-16 | 2005-03-16 |  |  |  |  |  | 11d |  |  |  |  |
| 126 | 2.3.1.1.5 | Establish a process and schedule for Sub-Team progress report updates to the GSTOP Team | 1d? | 2005-03-16 | 2005-03-16 |  |  |  |  |  | 11d |  |  |  |  |
| 127 | 2.3.1.2 | **Establish Review Processes** | 1d? | 2005-03-16 | 2005-03-16 |  |  |  |  |  | 11d |  |  |  | Std Products Review Process |
| 128 | 2.3.1.2.1 | Establish a process for Sub-Team (internal) review of std products definitions template | 1d? | 2005-03-16 | 2005-03-16 |  |  |  |  |  | 11d |  |  |  |  |
| 129 | 2.3.1.2.2 | Establish a process for Sub-Team (internal) review of std products definitions | 1d? | 2005-03-16 | 2005-03-16 |  |  |  |  |  | 11d |  |  |  |  |
| 130 | 2.3.1.2.3 | Establish a process for peer reviews | 1d? | 2005-03-16 | 2005-03-16 |  |  |  |  |  | 11d |  |  |  |  |
| 131 | 2.3.1.2.4 | Establish a process for periodic GSTOP Team reviews | 1d? | 2005-03-16 | 2005-03-16 |  |  |  |  |  | 11d |  |  |  |  |
| 132 | 2.3.1.2.5 | Establish a process for reviewing the final report | 1d? | 2005-03-16 | 2005-03-16 |  |  |  |  |  | 11d |  |  |  |  |
| 133 | 2.3.1.3 | **Establish Change Processes** | 1d? | 2005-03-16 | 2005-03-16 |  |  |  |  |  | 11d |  |  |  | Std Products Change Process |
| 134 | 2.3.1.3.1 | Establish a process for additions/deletions of std products mid-stream through the Project | 1d? | 2005-03-16 | 2005-03-16 |  |  |  |  |  | 11d |  |  |  |  |
| 135 | 2.3.1.3.2 | Establish a change process for the additions/deletion of standard products after the final recommendation has been submitted and prior to completion of the GSTOP project | 1d? | 2005-03-16 | 2005-03-16 |  |  |  |  |  | 11d |  |  |  |  |
| 136 | 2.3.1.3.3 | Establish a change process for the additions/deletion of standard products after the completion of the GSTOP project | 1d? | 2005-03-16 | 2005-03-16 |  |  |  |  |  | 11d |  |  |  |  |
| 137 | 2.3.1.4 | Review Business Practices Developed by Symbology SubTeam and agree or advise | 1d? | 2005-04-04 | 2005-04-04 | 23 |  |  |  |  | -2d | 0d | StdProd Subteam | 8h |  |

| ID | WBS | Task | Type | Duration | Start | Finish | Predecessors | Complete | Remaining | Total slack | Free slack | Constraint | Resources | Work | Text1 |
| --- | --- | --- | --- | --- | --- | --- | --- | --- | --- | --- | --- | --- | --- | --- | --- |
| 138 | 2.3.2 | **Define criteria for the acceptance of standard products definitions** |  | 2d? | 2005-03-16 | 2005-03-17 |  |  |  | 10d |  |  |  |  | Acceptance Criteria Set |
| 139 | 2.3.2.1 | Develop acceptance criteria for std products definitions |  | 1d? | 2005-03-16 | 2005-03-16 |  |  |  | 10d | 0d |  |  |  |  |
| 140 | 2.3.2.2 | Conduct a final review of selection criteria |  | 1d? | 2005-03-17 | 2005-03-17 | 139 |  |  | 10d |  |  |  |  | Standard Products Acceptance Criteria |
| 141 | 2.3.3 | **Define/Collect Information** |  | 25d? | 2005-02-09 A | 2005-03-16 |  |  | 25d? | -11d | 0d |  |  |  |  |
| 142 | 2.3.3.1 | Develop Standard Products Matrix to compare many versions of standard products. (GIST Draft Taskbook/GIST Course Workbook/PNWCG Product Objectives) | milestone | 0d? | 2005-02-09 A | 2005-02-09 A |  | 100% |  |  |  |  |  |  | Matrix Spreadsheet |
| 143 | 2.3.3.2 | Acquire DPRO Standards and incorporate into above matrix. | milestone | 0d? | 2005-03-01 A | 2005-03-01 A |  | 100% |  |  |  |  |  |  | Updated Matrix |
| 144 | 2.3.3.3 | Victoria Smith definitions/PNWCG definitions/DPRO defs. Compile these into a list for group to review. Cite source. | milestone | 0d? | 2005-03-01 A | 2005-03-01 A |  | 100% |  |  |  |  |  |  | List of Std Prods (draft) |
| 145 | 2.3.3.4 | Post for review including samples |  | 1d? | 2005-03-16 | 2005-03-16 | 144 |  |  | -25d | 0d |  |  |  | List posted to FTP site |
| 146 | 2.3.3.5 | Collect examples of new kinds of standard products that aren't in any of the existing definitions |  | 1d? | 2005-02-10 A | 2005-02-10 |  |  | 1d? | -1d | 0d | start no earlier than 2005-02-10 |  |  | Provide on ftp site |
| 147 | 2.3.4 | **Conduct Analysis** |  | 27d? | 2005-03-17 | 2005-04-22 | 141 |  |  | -29d | 0d |  |  | 160h |  |
| 148 | 2.3.4.1 | Define the meaning of product definitions - what goes into them? |  | 1d? | 2005-03-17 | 2005-03-17 |  |  |  | -3d | 0d |  |  |  |  |
| 149 | 2.3.4.2 | Create a draft template of what a product definition is |  | 1d? | 2005-03-23 | 2005-03-23 |  |  |  | -29d | 0d | finish no earlier than 2005-03-23 |  |  | Product Definition Template (draft) |
| 150 | 2.3.4.3 | Review existing standards definitions (Victoria/PNWCG/DPRO) & Identify discrepancies between groups defining standard |  | 10d | 2005-03-24 | 2005-04-06 | 149 |  |  | -29d | 0d |  |  |  | Discrepancy list |
| 151 | 2.3.4.4 | Highlight specific reasons for discrepancies (Fire Use vs. Type 1) if needed |  | 1d? | 2005-03-24 | 2005-03-24 | 149 |  |  | -20d | 0d |  |  |  |  |
| 152 | 2.3.4.5 | Bring these to the larger group for discussion and resolution |  | 10d | 2005-04-07 | 2005-04-20 | 151, 150, 149 |  |  | -29d | 0d |  | GSTOP Team; GTG | 160h |  |
| 153 | 2.3.4.6 | Gather responses from GSTOP and GTG; incorporte feedback |  | 1d? | 2005-04-21 | 2005-04-21 | 152 |  |  | -29d | 0d |  |  |  |  |
| 154 | 2.3.4.7 | Send out to wider folks for review (Field Test) |  | 1d? | 2005-04-22 | 2005-04-22 | 153 |  |  | -29d | 0d |  |  |  |  |
| 155 | 2.3.5 | **Develop Preliminary Package of Standard Products Definitions for Internal Review** |  | 1d? | 2005-04-25 | 2005-04-25 | 147 |  |  | -29d | 0d |  |  |  |  |
| 156 | 2.3.5.1 | Provide a package of draft products definitions and samples for review |  | 1d? | 2005-04-25 | 2005-04-25 |  |  |  | -29d | 0d |  |  |  | Preliminary package |
| 157 | 2.3.5.2 | Evaluate std products against acceptance criteria |  | 1d? | 2005-04-25 | 2005-04-25 |  |  |  | -29d | 0d |  |  |  |  |
| 158 | 2.3.5.3 | Find a storage location for GSTOP group review (NIFC site?) |  | 1d? | 2005-04-25 | 2005-04-25 |  |  |  | -29d | 0d |  |  |  | Location posted |
| 159 | 2.3.5.4 | Provide data location and review process to internal group |  | 1d? | 2005-04-25 | 2005-04-25 |  |  |  | -29d | 0d |  |  |  | Submission report |
| 160 | 2.3.6 | **Conduct outside peer review of the draft standard products definitions** |  | 4d? | 2005-04-26 | 2005-04-29 | 155 |  |  | -29d | 0d |  |  | 8h |  |
| 161 | 2.3.6.1 | Submit the draft standard symbols to the 5 federal fire management agencies and State agencies via the NWCG Geospatial Task Group (GTG); and to the DHS (FEMA), FAA, DOD, and GSTOP Team for peer review |  | 1d? | 2005-04-26 | 2005-04-26 |  |  |  | -29d | 0d |  | GTG | 8h | Submission Report |
| 162 | 2.3.6.2 | Review feedback of initial peer review |  | 1d? | 2005-04-27 | 2005-04-27 | 161 |  |  | -29d | 0d |  |  |  | Initial Peer Review Document |
| 163 | 2.3.6.3 | Identify required changes to draft standard products based on the initial peer review feedback |  | 1d? | 2005-04-28 | 2005-04-28 | 162 |  |  | -29d | 0d |  |  |  | List of required changes |
| 164 | 2.3.6.4 | Make required changes, as identified, to draft standard products |  | 1d? | 2005-04-29 | 2005-04-29 | 163 |  |  | -29d | 0d |  |  |  | Initial updated Products Definitions |

| ID | WBS | Task | Type | Duration | Start | Finish | Predecessors | Complete | Remaining | Baseline start | Baseline finish | Baseline duration | Total slack | Free slack | Constraint | Resources | Work | Actual work | Text1 |
| --- | --- | --- | --- | --- | --- | --- | --- | --- | --- | --- | --- | --- | --- | --- | --- | --- | --- | --- | --- |
| 165 | 2.3.7 | **Conduct final peer review of the draft standard products** |  | 6d? | 2005-05-02 | 2005-05-09 | 160 |  |  |  |  |  | -29d | 0d |  |  | 8h |  |  |
| 166 | 2.3.7.1 | Prepare draft standard products for final peer review |  | 1d? | 2005-05-02 | 2005-05-02 |  |  |  |  |  |  | -29d | 0d |  |  |  |  | Final Peer Review Package |
| 167 | 2.3.7.2 | Submit the draft standard products to the 5 federal fire management agencies and State agencies via the NWCG Geospatial Task Group (GTG); and to the HSA (FEMA), FAA, DOD, and GSTOP Team for peer review |  | 1d? | 2005-05-03 | 2005-05-03 | 166 |  |  |  |  |  | -29d | 0d |  | GTG | 8h |  | Submission Report |
| 168 | 2.3.7.3 | Review feedback of the final peer review |  | 1d? | 2005-05-04 | 2005-05-04 | 167 |  |  |  |  |  | -29d | 0d |  |  |  |  | Final Peer Review Document |
| 169 | 2.3.7.4 | Identify required changes to draft standard products based on the final peer review feedback |  | 1d? | 2005-05-05 | 2005-05-05 | 168 |  |  |  |  |  | -29d | 0d |  |  |  |  | List of required changes |
| 170 | 2.3.7.5 | Make required changes, as identified, to draft standard products |  | 1d? | 2005-05-06 | 2005-05-06 | 169 |  |  |  |  |  | -29d | 0d |  |  |  |  | final updated products list |
| 171 | 2.3.7.6 | Ratify the final draft standard symbols |  | 1d? | 2005-05-09 | 2005-05-09 | 170 |  |  |  |  |  | -29d | 0d |  |  |  |  | Final Draft Standard Productss List |
| 172 | 2.3.8 | **Finalize recommendation of standard Fire Mapping products** |  | 2d? | 2005-05-10 | 2005-05-11 | 165 |  |  |  |  |  | -29d | 0d |  |  | 8h |  |  |
| 173 | 2.3.8.1 | Create a report recommending the adoption of the draft standard product definitions |  | 1d? | 2005-05-10 | 2005-05-10 |  |  |  |  |  |  | -29d | 0d |  |  |  |  | Recommendation Report |
| 174 | 2.3.8.2 | Conduct a review of the report for completeness, accuracy, language, and grammar |  | 1d? | 2005-05-11 | 2005-05-11 | 173 |  |  |  |  |  | -29d | 0d |  | StdProd Subteam | 8h |  | Finalized Recommendation Report |
| 175 | 2.3.8.3 | Submit the report to GSTOP-PM | milestone | 0d | 2005-05-11 | 2005-05-11 | 174 |  |  |  |  |  | -29d | 0d |  |  |  |  | Report Submission |
| 176 | 2.3.8.4 | Find a permanent storage location for this package? National clearinghouse? |  | 1d? | 2005-05-10 | 2005-05-10 |  |  |  |  |  |  | -28d | 0d |  |  |  |  |  |
| 178 | 2.4 | **Incident GIST Minimum Qualifications Requirements** |  | 28.5d? | 2005-03-16 A | 2005-04-25 |  | 3% | 27.68d? | 2004-12-31 | 2005-01-06 | 5d? | -16.5d | 0d |  | Victoria Smith | 796h | 150.53h |  |
| 179 | 2.4.1 | **Establish Min GIST qualifications/GIS expectations Sub-Team business practices** |  | 13d? | 2005-03-16 | 2005-04-01 |  |  |  |  |  |  | -1d | 0d |  |  | 312h |  |  |
| 180 | 2.4.1.1 | **Develop a GIST Qual/GIST Min Expec Sub-team Communication Plan** |  | 13d? | 2005-03-16 | 2005-04-01 |  |  |  |  |  |  | -1d | 0d |  | GIST Qual/GIS Min Expec Subteam | 104h |  |  |
| 181 | 2.4.1.1.1 | Define ground-rules for Sub-Team (internal) communication |  | 13d? | 2005-03-16 | 2005-04-01 |  |  |  |  |  |  | -1d | 0d | finish no earlier than 2005-04-01 |  |  |  |  |
| 182 | 2.4.1.1.2 | Define ground-rules for communication between the GIST Qual/GIST Min Expec Sub-Team and other GSTOP Sub-Teams |  | 13d? | 2005-03-16 | 2005-04-01 |  |  |  |  |  |  | -1d | 0d | finish no earlier than 2005-04-01 |  |  |  |  |
| 183 | 2.4.1.1.3 | Define ground rules for communication between the Sub-Team and entities outside of the GSTOP Project |  | 13d? | 2005-03-16 | 2005-04-01 |  |  |  |  |  |  | -1d | 0d | finish no earlier than 2005-04-01 |  |  |  |  |
| 184 | 2.4.1.1.4 | Establish a process and schedule for Sub-Team (internal) progress report updates |  | 13d? | 2005-03-16 | 2005-04-01 |  |  |  |  |  |  | -1d | 0d | finish no earlier than 2005-04-01 |  |  |  |  |
| 185 | 2.4.1.1.5 | Establish a process and schedule for Sub-Team progress report updates to the GSTOP Team |  | 13d? | 2005-03-16 | 2005-04-01 |  |  |  |  |  |  | -1d | 0d | finish no earlier than 2005-04-01 |  |  |  |  |
| 186 | 2.4.1.2 | **Establish Review Processes** |  | 13d? | 2005-03-16 | 2005-04-01 |  |  |  |  |  |  | -1d | 0d |  | GIST Qual/GIS Min Expec Subteam | 104h |  |  |
| 187 | 2.4.1.2.1 | Establish a process for Sub-Team (internal) review of potential minimum GIST qualifications/GIS expectations |  | 13d? | 2005-03-16 | 2005-04-01 |  |  |  |  |  |  | -1d | 0d | finish no earlier than 2005-04-01 |  |  |  |  |
| 188 | 2.4.1.2.2 | Establish a process for Sub-Team (internal) review of the draft minimum GIST qualifications/GIS expectations |  | 13d? | 2005-03-16 | 2005-04-01 |  |  |  |  |  |  | -1d | 0d | finish no earlier than 2005-04-01 |  |  |  |  |
| 189 | 2.4.1.2.3 | Establish a process for peer reviews |  | 13d? | 2005-03-16 | 2005-04-01 |  |  |  |  |  |  | -1d | 0d | finish no earlier than 2005-04-01 |  |  |  |  |
| 190 | 2.4.1.2.4 | Establish a process for periodic GSTOP Team reviews |  | 13d? | 2005-03-16 | 2005-04-01 |  |  |  |  |  |  | -1d | 0d | finish no earlier than 2005-04-01 |  |  |  |  |
| 191 | 2.4.1.2.5 | Establish a process for reviewing the final report |  | 13d? | 2005-03-16 | 2005-04-01 |  |  |  |  |  |  | -1d | 0d | finish no earlier than 2005-04-01 |  |  |  |  |

| ID | WBS | Task | Duration | Start | Finish | Predecessors | Complete | Remaining | Total slack | Free slack | Constraint | Resources | Work | Actual work |
| --- | --- | --- | --- | --- | --- | --- | --- | --- | --- | --- | --- | --- | --- | --- |
| 192 | 2.4.1.3 | **Establish Change Processes** | 13d? | 2005-03-16 | 2005-04-01 |  |  |  | -1d | 0d |  | GIST Qual/GIS Min Expec Subteam | 104h |  |
| 193 | 2.4.1.3.1 | Establish a process for additions/deletions of potential minimum GIST qualifications/GIS expectations mid-stream through the project | 13d? | 2005-03-16 | 2005-04-01 |  |  |  | -1d | 0d | finish no earlier than 2005-04-01 |  |  |  |
| 194 | 2.4.1.3.2 | Establish a change process for the additions/deletion of minimum GIST qualifications/GIS expectations after the final recommendation has been submitted and prior to completion of the GSTOP project | 13d? | 2005-03-16 | 2005-04-01 |  |  |  | -1d | 0d | finish no earlier than 2005-04-01 |  |  |  |
| 195 | 2.4.1.3.3 | Establish a change process for the additions/deletion of minimum GIST qualifications/GIS expectations after the completion of the GSTOP project | 13d? | 2005-03-16 | 2005-04-01 |  |  |  | -1d | 0d | finish no earlier than 2005-04-01 |  |  |  |
| 196 | 2.4.2 | **Establish evaluation methods for minimum GIST qualifications/GIS expectations** | 1d? | 2005-03-16 | 2005-03-16 |  |  |  | 11d |  |  |  |  |  |
| 197 | 2.4.2.1 | Define method for evaluating minimum GIST qualifications/GIS expectations | 1d? | 2005-03-16 | 2005-03-16 |  |  |  | 11d |  |  |  |  |  |
| 198 | 2.4.2.2 | Conduct a final review of evaluation methods | 1d? | 2005-03-16 | 2005-03-16 |  |  |  | 11d |  |  |  |  |  |
| 199 | 2.4.3 | **Define criteria for the acceptance of minimum GIST qualifications/GIS expectations** | 1d? | 2005-03-16 | 2005-03-16 |  |  |  | 11d |  |  |  |  |  |
| 200 | 2.4.3.1 | Develop acceptance criteria for minimum GIST qualifications/GIS expectations | 1d? | 2005-03-16 | 2005-03-16 |  |  |  | 11d |  |  |  |  |  |
| 201 | 2.4.3.2 | Conduct a final review of selection criteria | 1d? | 2005-03-16 | 2005-03-16 |  |  |  | 11d |  |  |  |  |  |
| 202 | 2.4.4 | **Collect Information on minimum GIST qualifications and minimum GIS expectations on an incident** | 6.5d? | 2005-03-16 A | 2005-03-24 |  | 71% | 1.91d? | -0.5d | 0d |  |  | 176h | 144h |
| 203 | 2.4.4.1 | Gather documents and references (including white papers, memos, After Action Reviews, agency guidelines) | 6d? | 2005-03-16 A | 2005-03-23 A |  | 100% |  |  |  |  | GTAG; Firescope; NWCG Member Agencies | 144h | 144h |
| 204 | 2.4.4.2 | Obtain and review revised Taskbook | 0.5d? | 2005-03-24 | 2005-03-24 | 203 |  |  | -16.5d | 0d |  | John Guthrie; Victoria Smith | 8h |  |
| 205 | 2.4.4.3 | Scan or translate paper documents to electronic format | 1d? | 2005-03-16 | 2005-03-16 |  |  |  | -11d | 0d |  |  |  |  |
| 206 | 2.4.4.4 | Research current GIST/GIS standards | 1d? | 2005-03-16 | 2005-03-16 |  |  |  | -11d | 0d |  | FEMA; GACC guidelines; NWCG Agency | 24h |  |
| 207 | 2.4.5 | **Develop a list of GIST qualifications to be evaluated for acceptance as draft minimum standards** | 3d? | 2005-03-24 | 2005-03-29 | 202 |  |  | -16.5d | 0d |  |  | 8h |  |
| 208 | 2.4.5.1 | Compare the current GIST standards | 1d? | 2005-03-24 | 2005-03-25 |  |  |  | -16.5d | 0d |  | Elise Browne | 8h |  |
| 209 | 2.4.5.2 | Compile the GIST qualifications into a single list of potential minimum GIST qualifications | 1d? | 2005-03-25 | 2005-03-28 | 208 |  |  | -16.5d | 0d |  |  |  |  |
| 210 | 2.4.5.3 | Compile a list of GIST qualifications which are deemed to be beyond the minimum for future reference | 1d? | 2005-03-28 | 2005-03-29 | 209 |  |  | -16.5d | 0d |  |  |  |  |
| 211 | 2.4.6 | **Develop a list of GIS expectations to be evaluated for acceptance as draft minimum standards** | 3d? | 2005-03-24 | 2005-03-29 | 202 |  |  | -16.5d | 0d |  |  |  |  |
| 212 | 2.4.6.1 | Compare any current GIS expectation standards | 1d? | 2005-03-24 | 2005-03-25 |  |  |  | -16.5d | 0d |  |  |  |  |
| 213 | 2.4.6.2 | Compile the GIS expectations into a list of potential minimum GIS expectations on an incident | 1d? | 2005-03-25 | 2005-03-28 | 212 |  |  | -16.5d | 0d |  |  |  |  |
| 214 | 2.4.6.3 | Compile a list of GIS qualifications which are deemed to be beyond the minimum for future reference | 1d? | 2005-03-28 | 2005-03-29 | 213 |  |  | -16.5d | 0d |  |  |  |  |
| 215 | 2.4.7 | **Determine the draft standard minimum GIST qualifications** | 3d? | 2005-03-29 | 2005-04-01 | 207 |  |  | -16.5d | 0d |  |  |  |  |
| 216 | 2.4.7.1 | Evaluate each potential minimum GIST qualification using the evaluation methods in 2.4.2 | 1d? | 2005-03-29 | 2005-03-30 |  |  |  | -16.5d | 0d |  |  |  |  |
| 217 | 2.4.7.2 | Select the minimum GIST qualifications | 1d? | 2005-03-30 | 2005-03-31 | 216 |  |  | -16.5d | 0d |  |  |  |  |
| 218 | 2.4.7.3 | Conduct a completeness review of the draft minimum GIST qualifications | 1d? | 2005-03-31 | 2005-04-01 | 217 |  |  | -16.5d | 0d |  |  |  |  |

Notes:
- 192: Text1: Change Process for Minimum GIST qualifications/GIS expectations
- 196: Text1: Evaluation Methodology for Minimum GIST Qualifications/GIS Expectations
- 199: Text1: Acceptance Criteria Set
- 203: Text1: electronic format of original documents in folder on DisasterHelp site
- 205: using books, media (including internet and magazines) / Text1: electronic documents with quotes and bibliographic references
- 206: Text1: electronic format of original documents
- 208: Text1: matrix of similarities
- 209: Text1: list of minimum GIST qualifications for evaluation
- 210: Text1: list of other GIST qualifications (wish list)
- 212: Text1: matrix of similarities
- 213: Text1: list of minimum GIS expectations for evaluation
- 214: Text1: list of other GIS expectations (wish list)
- 215: Text1: Draft of minimum GIST qualifications standard
- 216: Text1: GIST qualifications evaluation document
- 217: Text1: Draft list of minimum GIST qualifications
- 218: Text1: Draft standard of the minimum GIST qualifications

| ID | WBS | Task | Duration | Start | Finish | Predecessors | Complete | Remaining | Baseline start | Baseline finish | Baseline duration | Total slack | Free slack | Resources | Work | Actual work |
| --- | --- | --- | --- | --- | --- | --- | --- | --- | --- | --- | --- | --- | --- | --- | --- | --- |
| 219 | 2.4.8 | **Determine the draft standard minimum GIS expectations** | 3d? | 2005-03-29 | 2005-04-01 | 211 |  |  |  |  |  | -16.5d | 0d |  |  |  |
| 220 | 2.4.8.1 | Evaluate each potential minimum GIS expectation using the evaluation methods in 2.4.2 | 1d? | 2005-03-29 | 2005-03-30 |  |  |  |  |  |  | -16.5d | 0d |  |  |  |
| 221 | 2.4.8.2 | Select the minimum GIS expectations | 1d? | 2005-03-30 | 2005-03-31 | 220 |  |  |  |  |  | -16.5d | 0d |  |  |  |
| 222 | 2.4.8.3 | Conduct a completeness review of the draft minimum GIS expectations | 1d? | 2005-03-31 | 2005-04-01 | 221 |  |  |  |  |  | -16.5d | 0d |  |  |  |
| 223 | 2.4.9 | **Conduct internal review of draft standard minimum GIST qualifications and GIS expectations** | 6d? | 2005-04-01 | 2005-04-11 | 215, 219 |  |  |  |  |  | -16.5d | 0d |  |  |  |
| 224 | 2.4.9.1 | Prepare draft standard minimum GIST qualifications and GIS expectations, including acceptance criteria | 1d? | 2005-04-01 | 2005-04-04 |  |  |  |  |  |  | -16.5d | 0d |  |  |  |
| 225 | 2.4.9.2 | Post draft standard to DisasterHelp website and notify GSTOP team for group review | 1d? | 2005-04-04 | 2005-04-05 | 224 |  |  |  |  |  | -16.5d | 0d |  |  |  |
| 226 | 2.4.9.3 | Provide data location and review process to internal group | 1d? | 2005-04-05 | 2005-04-06 | 225 |  |  |  |  |  | -16.5d | 0d |  |  |  |
| 227 | 2.4.9.4 | Review feedback of initial peer review | 1d? | 2005-04-06 | 2005-04-07 | 226 |  |  |  |  |  | -16.5d | 0d |  |  |  |
| 228 | 2.4.9.5 | Identify required changes to draft standard based on the initial peer review feedback | 1d? | 2005-04-07 | 2005-04-08 | 227 |  |  |  |  |  | -16.5d | 0d |  |  |  |
| 229 | 2.4.9.6 | Make required changes, as identified, to draft standard | 1d? | 2005-04-08 | 2005-04-11 | 228 |  |  |  |  |  | -16.5d | 0d |  |  |  |
| 230 | 2.4.10 | **Conduct final peer review of the draft standard minimum GIST qualifications and GIS expectations** | 7d? | 2005-04-11 | 2005-04-20 | 223 |  |  |  |  |  | -16.5d | 0d | GIST Qual/GIS Min Expec Subteam | 72h |  |
| 231 | 2.4.10.1 | Prepare survey or questionnaire to accompany draft standards for final peer review. | 1d? | 2005-04-11 | 2005-04-12 |  |  |  |  |  |  | -16.5d | 0d |  |  |  |
| 232 | 2.4.10.2 | Prepare draft standard minimum GIST Qualification/GIST expectations for final peer review, including the survey or questionnaire | 1d? | 2005-04-12 | 2005-04-13 | 231 |  |  |  |  |  | -16.5d | 0d |  |  |  |
| 233 | 2.4.10.3 | Submit the draft expectations to the 5 federal fire management agencies and State agencies via the NWCG Geospatial Task Group (GTG); and to the HSA (FEMA), FAA, DOD, and GSTOP Team for peer review. | 1d? | 2005-04-13 | 2005-04-14 | 232 |  |  |  |  |  | -16.5d | 0d | GTG | 8h |  |
| 234 | 2.4.10.4 | Review feedback of the final peer review, including questionnaire or survey | 1d? | 2005-04-14 | 2005-04-15 | 233 |  |  |  |  |  | -16.5d | 0d |  |  |  |
| 235 | 2.4.10.5 | Identify required changes to draft standard minimum GIST qualifications/GIS expectations based on the final peer review feedback | 1d? | 2005-04-15 | 2005-04-18 | 234 |  |  |  |  |  | -16.5d | 0d |  |  |  |
| 236 | 2.4.10.6 | Make required changes, as identified, to draft minimum GIST qualifications/GIS expectations symbols | 1d? | 2005-04-18 | 2005-04-19 | 235 |  |  |  |  |  | -16.5d | 0d |  |  |  |
| 237 | 2.4.10.7 | Ratify the final draft standard minimum GIST qualifications/GIS expectations | 1d? | 2005-04-19 | 2005-04-20 | 236 |  |  |  |  |  | -16.5d | 0d | GIST Qual/GIS Min Expec Subteam | 8h |  |
| 238 | 2.4.11 | **Finalize recommendation of standard Minimum GIST Qualifications and Minimum GIS Expectations on an Incident** | 3d? | 2005-04-20 | 2005-04-25 | 230 |  |  |  |  |  | -16.5d | 0d |  |  |  |
| 239 | 2.4.11.1 | Create a report recommending the adoption of the draft minimum GIST Qualifications/GIS Expectations | 1d? | 2005-04-20 | 2005-04-21 |  |  |  |  |  |  | -16.5d | 0d |  |  |  |
| 240 | 2.4.11.2 | Conduct a review of the report for completeness, accuracy, language, and grammar | 1d? | 2005-04-21 | 2005-04-22 | 239 |  |  |  |  |  | -16.5d | 0d |  |  |  |
| 241 | 2.4.11.3 | Submit the report to GSTOP-PM | 1d? | 2005-04-22 | 2005-04-25 | 240 |  |  |  |  |  | -16.5d | 0d |  |  |  |
| 242 | 2.5 | **Incident GIS Minimum Essential Datasets Requirements** | 44d? | 2005-02-10 A | 2005-04-12 |  | 5% | 41.8d? | 2004-12-31 | 2005-01-06 | 5d? | -5d | 0d | John Guthrie | 840h | 17.6h |
| 243 | 2.5.1 | **Establish MED Sub-Team business practices** | 25d? | 2005-02-10 A | 2005-03-16 |  |  | 25d? |  |  |  | 11d |  |  |  |  |
| 244 | 2.5.1.1 | **Develop a MED Sub-team Communication Plan** | 25d? | 2005-02-10 A | 2005-03-16 |  |  | 25d? | 2004-12-31 | 2005-01-18 | 13d? | 11d |  |  |  |  |
| 245 | 2.5.1.1.1 | **Define ground-rules for Sub-Team (internal) communication** | 1d? | 2005-02-10 A | 2005-02-10 |  |  | 1d? | 2004-12-31 | 2005-01-10 | 7d? | 12d |  |  |  |  |
| 246 | 2.5.1.1.1.1 | Define ground-rules for communication between the MED Sub-Team and other GSTOP Sub-Teams | 1d? | 2005-02-10 A | 2005-02-10 |  |  | 1d? | 2004-12-31 | 2004-12-31 | 1d? | -1d | 0d |  |  |  |
| 247 | 2.5.1.1.1.2 | Define ground rules for communication between the Sub-Team and entities outside of the GSTOP Project | 1d? | 2005-02-10 A | 2005-02-10 | 246 |  | 1d? | 2005-01-03 | 2005-01-03 | 1d? | -1d | 0d |  |  |  |
| 248 | 2.5.1.1.1.3 | Establish a process and schedule for Sub-Team (internal) progress report updates | 1d? | 2005-02-10 A | 2005-02-10 | 247 |  | 1d? | 2005-01-04 | 2005-01-04 | 1d? | -1d | 0d |  |  |  |
| 249 | 2.5.1.1.1.4 | Establish a process and schedule for Sub-Team progress report updates to the GSTOP Team | 1d? | 2005-02-10 A | 2005-02-10 | 248 |  | 1d? | 2005-01-05 | 2005-01-05 | 1d? | -1d | 0d |  |  |  |
| 250 | 2.5.1.1.1.5 | Establish Review Processes | 1d? | 2005-02-10 A | 2005-02-10 | 249 |  | 1d? | 2005-01-06 | 2005-01-06 | 1d? | -1d | 0d |  |  |  |
| 251 | 2.5.1.1.1.6 | Establish a process for Sub-Team (internal) review of potential MEDs | 1d? | 2005-02-10 A | 2005-02-10 | 250 |  | 1d? | 2005-01-07 | 2005-01-07 | 1d? | -1d | 0d |  |  |  |
| 252 | 2.5.1.1.1.7 | Establish a process for Sub-Team (internal) review of the draft standard MEDs | 1d? | 2005-02-10 A | 2005-02-10 | 251 |  | 1d? | 2005-01-10 | 2005-01-10 | 1d? | 12d |  |  |  |  |

Notes:
- 219: Text1: Draft of minimum GIS expectations standard
- 220: Text1: GIS expectations evaluation document
- 221: Text1: Draft list of minimum GIS expectations
- 222: Text1: Draft standard of the minimum GIS expectations
- 224: Text1: Initial peer review package
- 225: Text1: Location posted, review team notified
- 226: Text1: Review report
- 227: Text1: Initial peer review document
- 228: Text1: List of required changes
- 229: Text1: Initial updated draft standard minimum GIST qualifications and GIS expectations
- 231: Text1: Final Peer Review Questionnaire or survey
- 232: Text1: Final Peer Review Package
- 233: Text1: Submission Report
- 234: Text1: Final Peer Review Document
- 235: Text1: List of required changes
- 236: Text1: final updated list of minimum GIST qualifications and GIS expectations
- 237: Text1: Final Draft Standard Minimum GIST Qualifications/GIS Expectations
- 239: Text1: Recommendation Report
- 240: Text1: Finalized Recommendation Report
- 241: Text1: Report Submission
- 244: Text1: Communication Plan Document
- 245: Text1: Write Up
- 246: Text1: Write Up
- 247: Text1: Write Up
- 248: Text1: Write Up
- 249: Text1: Write Up
- 250: Text1: Review Process Document
- 251: Text1: Write Up
- 252: Text1: Write Up

| ID | WBS | Task | Duration | Start | Finish | Predecessors | Complete | Remaining | Baseline start | Baseline finish | Baseline duration | Total slack | Free slack | Constraint | Resources | Work | Text1 |
| --- | --- | --- | --- | --- | --- | --- | --- | --- | --- | --- | --- | --- | --- | --- | --- | --- | --- |
| 253 | 2.5.1.1.2 | **Establish a process for peer reviews** | 1d? | 2005-03-01 A | 2005-03-01 | 252 |  | 1d? | 2005-01-11 | 2005-01-12 | 2d? | 0d |  |  |  |  | Write Up |
| 254 | 2.5.1.1.2.1 | Establish a process for periodic GSTOP Team reviews | 1d? | 2005-03-01 A | 2005-03-01 |  |  | 1d? | 2005-01-11 | 2005-01-11 | 1d? | -1d | 0d |  |  |  | Write Up |
| 255 | 2.5.1.1.2.2 | Establish a process for reviewing the final report | 1d? | 2005-03-01 A | 2005-03-01 | 254 |  | 1d? | 2005-01-12 | 2005-01-12 | 1d? | -1d | 0d |  |  |  | Write Up |
| 256 | 2.5.1.1.3 | **Establish Change processes** | 12d? | 2005-03-01 A | 2005-03-16 | 255 |  | 12d? | 2005-01-13 | 2005-01-14 | 2d? | 11d |  |  |  |  | Change Process Document |
| 257 | 2.5.1.1.3.1 | Establish a process for additions/deletions of potential MEDs mid-stream through the Project | 1d? | 2005-03-01 A | 2005-03-01 |  |  | 1d? | 2005-01-13 | 2005-01-13 | 1d? | -1d | 0d |  |  |  | Write Up |
| 258 | 2.5.1.1.3.2 | Establish a change process for the additions/deletion of standard MEDs after the final recommendation has been submitted | 1d? | 2005-03-01 A | 2005-03-01 | 257 |  | 1d? | 2005-01-14 | 2005-01-14 | 1d? | 21d | 10d |  |  |  | Write Up |
| 259 | 2.5.1.1.3.3 | Establish a change process for the additions/deletion of standard MEDs after the final recommendation has been approved through the GSTOP Project | 1d? | 2005-03-16 | 2005-03-16 | 258 |  |  | 2005-01-17 | 2005-01-17 | 1d? | 11d |  |  |  |  | Write Up |
| 260 | 2.5.2 | **Establish MED evaluation methods** | 15d? | 2005-03-16 A | 2005-04-05 |  | 17% | 12.46d? |  |  |  | 0d |  |  | MED Subteam | 128h |  |
| 261 | 2.5.2.1 | Define method for evaluating fill MEDs | 13d? | 2005-03-18 A | 2005-04-05 |  |  | 13d? | 2004-12-31 | 2005-01-03 | 2d? | -3d | 0d |  |  |  | MED Evaluation Method |
| 262 | 2.5.2.2 | Determine GIS tasks to be done on an incident | 1d? | 2005-03-16 | 2005-03-16 |  |  |  |  |  |  | 11d |  |  |  |  |  |
| 263 | 2.5.2.3 | Determine GIS products needed per proposed GIS task | 1d? | 2005-03-16 | 2005-03-16 |  |  |  |  |  |  | 10.4d | 0d |  |  |  |  |
| 264 | 2.5.2.4 | Define criteria for the acceptance of MEDs as standards | 1d? | 2005-03-17 A | 2005-03-17 | 263 | 40% | 0.6d? | 2004-12-31 | 2004-12-31 | 1d? | 10d |  |  |  |  | Acceptance Criteria Document |
| 265 | 2.5.2.5 | Post draft Acceptance Critera for GSTOP Team review | 4d? | 2005-03-18 A | 2005-03-23 A |  | 100% |  |  |  |  |  |  |  |  |  |  |
| 266 | 2.5.2.6 | Review draft Acceptance Criteria | 1d? | 2005-03-28 | 2005-03-28 | 265 |  |  |  |  |  | -1d | 0d | finish no earlier than 2005-03-28 | GSTOP Team | 8h | GSTOP Team feedback |
| 267 | 2.5.2.7 | Update Acceptance Criteria for GSTOP Team input | 4d | 2005-03-29 | 2005-04-01 | 266 |  |  |  |  |  | -1d | 0d |  |  |  |  |
| 268 | 2.5.2.8 | Conduct a final review of selection criteria | 1d? | 2005-03-16 | 2005-03-16 |  |  |  | 2004-12-31 | 2004-12-31 | 1d? | 11d |  |  |  |  | MED Selection Criteria |
| 269 | 2.5.3 | **Develop a list of MEDs to be evaluated for acceptance as draft standards** | 25d? | 2005-03-01 A | 2005-04-04 |  |  | 25d? | 2004-12-31 | 2004-12-31 | 1d? | -1d | 0d |  | MED Subteam | 208h |  |
| 270 | 2.5.3.1 | Collect Fire mapping MEDs from the 5 federal fire management agencies (FS, BLM, NPS, FWS, BIA), state agencies, and USGS via the NWCG Geospatial Task Group (GTG) | 24d? | 2005-03-01 A | 2005-04-01 |  |  | 24d? | 2004-12-31 | 2004-12-31 | 1d? | 0d |  | finish no earlier than 2005-04-01 |  |  | MED image files |
| 271 | 2.5.3.2 | Collect Fire mapping MEDs from DHS (FEMA), FAA, and DOD | 1d? | 2005-03-23 A | 2005-03-23 |  |  | 1d? | 2004-12-31 | 2004-12-31 | 1d? | -1d | 0d |  | Eric | 8h | MED image files |
| 272 | 2.5.3.3 | Document potential sources for additional fire mapping MEDs | 1d? | 2005-03-16 | 2005-03-16 |  |  |  | 2004-12-31 | 2004-12-31 | 1d? | 5d |  |  |  |  | List of data sources |
| 273 | 2.5.3.4 | Compile MEDs into a single potential MED set | 1d? | 2005-04-04 | 2005-04-04 | 270, 271 |  |  | 2005-01-03 | 2005-01-03 | 1d? | -8d | 0d |  |  |  | Set of potential standard MEDs |
| 274 | 2.5.4 | **Determine the draft standard Raster MEDs** | 3d? | 2005-04-05 | 2005-04-07 | 269 |  |  | 2004-12-31 | 2004-12-31 | 1d? | -8d | 0d |  | MED Subteam | 24h |  |
| 275 | 2.5.4.1 | Evaluate each potential marker MED against the marker MED selection criteria | 1d? | 2005-04-05 | 2005-04-05 |  |  |  | 2004-12-31 | 2004-12-31 | 1d? | -8d | 0d |  |  |  | MED Evaluation Document |
| 276 | 2.5.4.2 | Sub-Team selection of the draft standard marker MEDs | 1d? | 2005-04-06 | 2005-04-06 | 275 |  |  | 2004-12-31 | 2004-12-31 | 1d? | -8d | 0d |  |  |  | Draft list of selected MEDs |
| 277 | 2.5.4.3 | Conduct a Sub-team completeness review of the draft standard marker MEDs | 1d? | 2005-04-07 | 2005-04-07 | 276 |  |  | 2004-12-31 | 2004-12-31 | 1d? | -8d | 0d |  |  |  | Draft Standard Marker MEDs Document |

| ID | WBS | Task | Type | Duration | Start | Finish | Predecessors | Baseline start | Baseline finish | Baseline duration | Total slack | Free slack | Resources | Work | Text1 |
| --- | --- | --- | --- | --- | --- | --- | --- | --- | --- | --- | --- | --- | --- | --- | --- |
| 278 | 2.5.5 | **Determine the draft standard Vector MEDs** |  | 3d? | 2005-03-16 | 2005-03-18 |  | 2004-12-31 | 2004-12-31 | 1d? | 6d |  | MED Subteam | 24h |  |
| 279 | 2.5.5.1 | Evaluate each potential line MED against the line MED selection criteria |  | 1d? | 2005-03-16 | 2005-03-16 |  | 2004-12-31 | 2004-12-31 | 1d? | 6d | 0d |  |  | MED Evaluation Document |
| 280 | 2.5.5.2 | Sub-Team selection of the draft standard line MEDs |  | 1d? | 2005-03-17 | 2005-03-17 | 279 | 2004-12-31 | 2004-12-31 | 1d? | 6d | 0d |  |  | Draft list of selected MEDs |
| 281 | 2.5.5.3 | Conduct a Sub-team completeness review of the draft standard line MEDs |  | 1d? | 2005-03-18 | 2005-03-18 | 280 | 2004-12-31 | 2004-12-31 | 1d? | 6d |  |  |  | Draft Standard Line MEDs Document |
| 282 | 2.5.6 | **Determine the draft extended vector and raster MEDs** |  | 3d? | 2005-04-08 | 2005-04-12 | 274, 278 |  |  |  | -8d | 0d | MED Subteam | 24h |  |
| 283 | 2.5.6.1 | Evaluate each potential extended MED against the extended MED selection criteria |  | 1d? | 2005-04-08 | 2005-04-08 |  |  |  |  | -8d | 0d |  |  | MED Evaluation Document |
| 284 | 2.5.6.2 | Sub-Team selection of the draft standard MEDs vs. extended MED list |  | 1d? | 2005-04-11 | 2005-04-11 | 283 |  |  |  | -8d | 0d |  |  | Draft list of selected MEDs |
| 285 | 2.5.6.3 | Conduct a Sub-team completeness review of the draft standard MEDs |  | 1d? | 2005-04-12 | 2005-04-12 | 284 |  |  |  | -8d | 0d |  |  | Draft Standard MEDs Document |
| 286 | 2.5.7 | **Conduct a Sub-team completeness review of the draft standard fill MEDs** |  | 1d? | 2005-03-16 | 2005-03-16 |  | 2004-12-31 | 2004-12-31 | 1d? | 11d |  | BLM publication shop | 16h | Draft Standard Fill MEDs Document |
| 287 | 2.5.7.1 | Conduct initial peer review of the draft standard marker, line, and fill MEDs |  | 1d? | 2005-03-16 | 2005-03-16 |  | 2004-12-31 | 2004-12-31 | 1d? | 11d |  | GSTOP Team | 8h |  |
| 288 | 2.5.7.2 | Prepare draft standard MEDs for initial peer review |  | 1d? | 2005-03-16 | 2005-03-16 |  | 2004-12-31 | 2004-12-31 | 1d? | 11d |  |  |  | Initial Peer Review Package |
| 289 | 2.5.7.3 | Submit the draft standard MEDs to the 5 federal fire management agencies, State agencies, and USGS via the NWCG Geospatial Task Group (GTG); and to DHS (FEMA), FAA, DOD, and GSTOP Team for peer review | milestone | 0d | 2005-03-16 | 2005-03-16 |  | 2004-12-31 | 2004-12-31 | 0d | 12d |  |  |  | Submission Report |
| 290 | 2.5.7.4 | Review feedback of initial peer review |  | 1d? | 2005-03-16 | 2005-03-16 |  | 2004-12-31 | 2004-12-31 | 1d? | 11d |  |  |  | Initial Peer Review Document |
| 291 | 2.5.7.5 | Identify required changes to draft standard MEDs based on the initial peer review feedback |  | 1d? | 2005-03-16 | 2005-03-16 |  | 2005-01-18 | 2005-01-19 | 1d? | 11d |  |  |  | List of required MED changes |
| 292 | 2.5.7.6 | Make required changes, as identified, to draft standard MEDs |  | 1d? | 2005-03-16 | 2005-03-16 |  | 2005-01-19 | 2005-01-19 | 1d? | 11d |  |  |  | Initial updated MEDs list |
| 293 | 2.5.8 | **Conduct final peer review of the draft standard marker, line, and fill MEDs** |  | 1d? | 2005-03-16 | 2005-03-16 |  | 2005-01-19 | 2005-01-19 | 1d? | 11d |  | NWCG Training Team | 56h |  |
| 294 | 2.5.8.1 | Prepare draft standard MEDs for final peer review |  | 1d? | 2005-03-16 | 2005-03-16 |  | 2005-01-19 | 2005-01-19 | 1d? | 11d |  | Victoria Smith; Deb Epps | 16h | Final Peer Review Package |
| 295 | 2.5.8.2 | Submit the draft standard MEDs to the 5 federal fire management agencies and State agencies via the NWCG Geospatial Task Group (GTG); and to the HSA (FEMA), FAA, DOD, and GSTOP Team for peer review |  | 1d? | 2005-03-16 | 2005-03-16 |  | 2005-01-19 | 2005-01-19 | 1d? | 11d |  | GSTOP Subteam(s) | 8h | Submission Report |
| 296 | 2.5.8.3 | Review feedback of the final peer review |  | 1d? | 2005-03-16 | 2005-03-16 |  | 2005-01-19 | 2005-01-19 | 1d? | 11d |  | GSTOP Subteam(s) | 8h | Final Peer Review Document |
| 297 | 2.5.8.4 | Identify required changes to draft standard MEDs based on the final peer review feedback |  | 1d? | 2005-03-16 | 2005-03-16 |  | 2005-01-19 | 2005-01-19 | 1d? | 11d |  | GSTOP Subteam(s) | 8h | List of required MED changes |
| 298 | 2.5.8.5 | Make required changes, as identified, to draft standard MEDs |  | 1d? | 2005-03-16 | 2005-03-16 |  | 2005-01-19 | 2005-01-19 | 1d? | 11d |  | GSTOP Subteam(s) | 8h | final updated MEDs list |
| 299 | 2.5.8.6 | Ratification of the final draft standard MEDs by the Sub-Team |  | 1d? | 2005-03-16 | 2005-03-16 |  | 2005-01-19 | 2005-01-19 | 1d? | 11d |  |  |  | Final Draft Standard MEDs List |
| 300 | 2.5.9 | **Finalize recommendation of standard Fire Mapping MEDs** |  | 1d? | 2005-03-16 | 2005-03-16 |  | 2005-01-19 | 2005-01-19 | 1d? | 11d |  |  | 8h |  |
| 301 | 2.5.9.1 | Create a report recommending the adoption of the draft standard MEDs |  | 1d? | 2005-03-16 | 2005-03-16 |  | 2005-01-19 | 2005-01-19 | 1d? | 11d |  | GSTOP Team | 8h | Recommendation Report |
| 302 | 2.5.9.2 | Conduct a Sub-Team review of the report |  | 1d? | 2005-03-16 | 2005-03-16 |  | 2005-01-19 | 2005-01-19 | 1d? | 11d |  |  |  | Finalized Recommendation Report |
| 303 | 2.5.9.3 | Submit the report to GSTOP-PM |  | 1d? | 2005-03-16 | 2005-03-16 |  | 2005-01-19 | 2005-01-19 | 1d? | 11d |  |  |  | Report Submission |

| ID | WBS | Task | Duration | Start | Finish | Predecessors | Total slack | Free slack | Resources | Work |
| --- | --- | --- | --- | --- | --- | --- | --- | --- | --- | --- |
| 305 | 2.6 | **Incident GIS Standard Data Sharing and Archiving Standards (02-08-2005)** | 1d? | 2005-03-16 | 2005-03-16 |  | 11d |  | Sean Triplett | 104h |
| 306 | 2.6.1 | **Define Information Needs (What do we need to gather?)** | 1d? | 2005-03-16 | 2005-03-16 |  | 11d |  |  | 32h |
| 307 | 2.6.1.1 | Compile existing archiving standards in use (e.g. data format, transfer mode) | 1d? | 2005-03-16 | 2005-03-16 |  | 11d |  | Business Lead; GTG Standards Committee | 16h |
| 308 | 2.6.1.2 | Identify how archiving is done at present time by ICS, military, other incident responders, project-management | 0.17d? | 2005-03-16 | 2005-03-16 |  | 11.83d |  | Internet Search; Military; etc.; survey GISTs; Plans Sections (Mary Kwart); Documents Sections | 8h |
| 309 | 2.6.1.3 | Gather NARA, Records Management requirements (review policies, lawsuits) e.g. physical location, acceptable media, supporting documentation | 0.25d? | 2005-03-16 | 2005-03-16 |  | 11.75d |  | Business Lead; FGDC; NARA; NWCG Member Agencies | 8h |
| 310 | 2.6.1.4 | Determine the least common denominator (shapefile) or possibility of multiple formats | 1d? | 2005-03-16 | 2005-03-16 |  | 11d |  |  |  |
| 311 | 2.6.2 | **Collect Information** | 1d? | 2005-03-16 | 2005-03-16 |  | 11d |  |  | 40h |
| 312 | 2.6.2.1 | Conduct literature review | 1d? | 2005-03-16 | 2005-03-16 |  | 11d |  | FGDC; GeoMAC; NPS I&M; NPS Focus; NARA | 40h |
| 313 | 2.6.3 | **Conduct Analysis** | 1d? | 2005-03-16 | 2005-03-16 |  | 11d |  |  |  |
| 314 | 2.6.3.1 | Compile, Synthesize requirements | 1d? | 2005-03-16 | 2005-03-16 |  | 11d |  |  |  |
| 315 | 2.6.4 | **Develop Preliminary Requirements Specifications** | 1d? | 2005-03-16 | 2005-03-16 |  | 11d |  |  | 8h |
| 316 | 2.6.4.1 | Proposal of SOP | 1d? | 2005-03-16 | 2005-03-16 |  | 11d |  | DataShareArcTrans Subteam | 8h |
| 317 | 2.6.5 | **Review and Validate Requirements** | 1d? | 2005-03-16 | 2005-03-16 |  | 11d |  |  | 16h |
| 318 | 2.6.5.1 | Sub-Team Review of SOP | 1d? | 2005-03-16 | 2005-03-16 |  | 11d |  | DataShareArcTrans Subteam | 8h |
| 319 | 2.6.5.2 | Revise, Edit Proposed SOP | 1d? | 2005-03-16 | 2005-03-16 |  | 11d |  | DataShareArcTrans Subteam | 8h |
| 320 | 2.6.5.3 | Submit to Project Manager for Team Review | 1d? | 2005-03-16 | 2005-03-16 |  | 11d |  |  |  |
| 321 | 2.7 | **Incident GIS Standard Documentation and Archiving** | 6d? | 2005-03-16 | 2005-03-23 |  | 6d |  | Sean Triplett | 216h |
| 322 | 2.7.1 | **Define Information Needs (What do we need to gather?)** | 1d? | 2005-03-16 | 2005-03-16 |  | 11d |  |  | 104h |
| 323 | 2.7.1.1 | Compile existing archiving standards in use (e.g. data format, transfer mode) | 1d? | 2005-03-16 | 2005-03-16 |  | 11d |  | GTG Standards Committee; Mary Kwart | 16h |
| 324 | 2.7.1.2 | Identify how archiving is done at present time by ICS, military, other incident responders, project-management | 1d? | 2005-03-16 | 2005-03-16 |  | 11d |  | Internet Search; Military; etc.; survey GISTs; Plans Sections (Mary Kwart); Documents Sections | 48h |
| 325 | 2.7.1.3 | Gather NARA, Records Management requirements (review policies, lawsuits) e.g. physical location, acceptable media, supporting documentation | 1d? | 2005-03-16 | 2005-03-16 |  | 11d |  | Business Lead; FGDC; NARA; agency guidance | 32h |
| 326 | 2.7.1.4 | Determine the least common denominator (shapefile) or possibility of multiple formats | 1d? | 2005-03-16 | 2005-03-16 |  | 11d |  | TBD | 8h |
| 327 | 2.7.2 | Collect Information: Conduct literature review | 1d? | 2005-03-16 | 2005-03-16 |  | 6d | 0d | FGDC; GeoMAC; NPS I&M; NPS Focus; NARA | 40h |
| 328 | 2.7.3 | Conduct Analysis: Compile, Synthesize requirements | 1d? | 2005-03-17 | 2005-03-17 | 327 | 6d | 0d |  |  |
| 329 | 2.7.4 | Develop Preliminary Requirements Specifications | 1d? | 2005-03-18 | 2005-03-18 | 328 | 6d | 0d | DataShareArcTrans Subteam | 8h |

Notes:
- 323: Brian Sorbel, Joe Frost, Susan Goodman / Text1: List of data types in use on incidents and standards
- 324: idea is to take advantage of "lessons learned." Have made contact with NORTHCOM (Military). / Text1: Matrix of incident/event data creators and indication of how they manage their data
- 325: Text1: list of data repositories, data warehouses, etc.
- 326: Should incident data be in a format compatible with GeoSpatial One-Stop, GEOMAC? / Text1: List of acceptable data forms for archiving.
- 327: Text1: Writeup of requirements for data repositories.
- 328: Text1: Writeup of common elements, differences, ideas worth pursuing.
- 329: Text1: Develop Proposed SOP

| ID | WBS | Task | Type | Duration | Start | Finish | Predecessors | Total slack | Free slack | Constraint | Resources | Work | Text1 |
| --- | --- | --- | --- | --- | --- | --- | --- | --- | --- | --- | --- | --- | --- |
| 330 | 2.7.5 | **Review and Validate Requirements** |  | 3d? | 2005-03-21 | 2005-03-23 | 329 | 6d |  |  |  | 16h |  |
| 331 | 2.7.5.1 | Sub-Team Review of SOP |  | 1d? | 2005-03-21 | 2005-03-21 |  | 6d | 0d |  | DataShareArcTrans Subteam | 8h | Writeup of results of Sub-Team review |
| 332 | 2.7.5.2 | Revise, Edit Proposed SOP |  | 1d? | 2005-03-22 | 2005-03-22 | 331 | 6d | 0d |  | DataShareArcTrans Subteam | 8h | Revised SOP |
| 333 | 2.7.5.3 | Submit to Project Manager for Team Review |  | 1d? | 2005-03-23 | 2005-03-23 | 332 | 6d |  |  |  |  |  |
| 335 | 2.8 | **Incident GIS Transition Procedures** |  | 9d? | 2005-03-16 | 2005-03-28 |  | 295d |  |  |  | 96h |  |
| 336 | 2.8.1 | **Define Information Needs (What do we need to gather?)** |  | 3d? | 2005-03-16 | 2005-03-18 |  | 295d | 0d |  |  | 56h |  |
| 337 | 2.8.1.1 | Determine "universe" of transitions: (team to team); (team to unit); (team to archive) |  | 1d? | 2005-03-16 | 2005-03-16 |  | 295d | 0d |  | Business Lead; FGDC; NARA; agency guidance | 32h | Annotated Hierarchical List |
| 338 | 2.8.1.2 | Compile procedures currently in use |  | 1d? | 2005-03-17 | 2005-03-17 | 337 | 295d | 0d |  | Other "team" environs (e.g. military); survey? Mary Kwart? | 16h | annotated list |
| 339 | 2.8.1.3 | Identify if existing procedures in use "somewhere out there" may be acceptible (e.g. NARA) |  | 1d? | 2005-03-18 | 2005-03-18 | 338 | 295d |  |  | DataShareArcTrans Subteam | 8h | writeup |
| 340 | 2.8.2 | **Evaluate Procedures** |  | 1d? | 2005-03-21 | 2005-03-21 | 336 | 295d | 0d |  |  | 8h |  |
| 341 | 2.8.2.1 | Identify test procedures for documentation and archiving |  | 1d? | 2005-03-21 | 2005-03-21 |  | 295d |  |  | DataShareArcTrans Subteam | 8h | writeup |
| 342 | 2.8.3 | Conduct Analysis: Test and identify strengths/weaknesses of existing procedures |  | 1d? | 2005-03-22 | 2005-03-22 | 340 | 295d | 0d |  | field teams; DataShareArcTrans Subteam | 16h | writieup of test |
| 343 | 2.8.4 | Develop Preliminary Requirements Specifications |  | 1d? | 2005-03-23 | 2005-03-23 | 342 | 295d | 0d |  |  |  | summarize test |
| 344 | 2.8.5 | **Review and Validate Requirements** |  | 3d? | 2005-03-24 | 2005-03-28 | 343 | 295d |  |  |  | 16h |  |
| 345 | 2.8.5.1 | Sub-Team Review of SOP |  | 1d? | 2005-03-24 | 2005-03-24 |  | 295d | 0d |  | DataShareArcTrans Subteam | 8h | Writeup of results of Sub-Team review |
| 346 | 2.8.5.2 | Revise, Edit Proposed SOP |  | 1d? | 2005-03-25 | 2005-03-25 | 345 | 295d | 0d |  | DataShareArcTrans Subteam | 8h | Revised SOP |
| 347 | 2.8.5.3 | Submit to Project Manager for Team Review |  | 1d? | 2005-03-28 | 2005-03-28 | 346 | 295d |  |  |  |  |  |
| 349 | 2.9 | MS1: Requirements for GIS SOPs are developed | milestone | 0d | 2005-03-31 | 2005-03-31 | 22, 92, 119, 178, 242, 305, 321 | -45d | 0d | must finish on 2005-03-31 | Project Mgr; GSTOP Exec Comm |  | progress report, project/communication plan |
| 350 | 3 | **Draft Incident GIS SOPs (>>chk for somewhat Incorporated into WBS 1)** |  | 148d? | 2004-10-20 | 2005-05-13 |  | 147.5d |  |  | GSTOP Team | 1280h |  |
| 351 | 3.1 | Develop template for GIS SOPs for all Subgroups |  | 1d? | 2004-10-20 | 2004-10-20 |  | 422d |  |  |  |  | Template SOP |
| 352 | 3.5 | Develop Preliminary SOP’s |  | 1d? | 2004-10-20 | 2004-10-20 |  | 422d |  |  |  |  |  |
| 353 | 3.6 | Review and Validate draft SOP’s |  | 1d? | 2004-10-20 | 2004-10-20 |  | 422d |  |  |  |  |  |
| 354 | 3.7 | Incorporate Feedback from reviewers |  | 1d? | 2004-10-20 | 2004-10-20 |  | 422d |  |  |  |  |  |
| 355 | 3.8 | Develop GSTOP Change Management Plan |  | 1d? | 2004-10-20 | 2004-10-20 |  | 422d |  |  |  |  |  |
| 356 | 3.9 | Review GSTOP Change Management Plan |  | 1d? | 2004-10-20 | 2004-10-20 |  | 422d |  |  |  |  |  |
| 357 | 3.7 | MS2: Draft SOPs are produced and ready for Field Test |  | 0.5d? | 2005-05-13 | 2005-05-13 |  | 0d |  | must finish on 2005-05-13 | Project Mgr; Business Lead | 8h | draft SOPs |

Notes:
- 337: is "unit to team" transfer covered in MED? Is transition to archive covered in team-to-unit?

| ID | WBS | Task | Type | Duration | Start | Finish | Baseline start | Baseline finish | Baseline duration | Total slack | Constraint | Resources | Work | Text1 |
| --- | --- | --- | --- | --- | --- | --- | --- | --- | --- | --- | --- | --- | --- | --- |
| 358 | 3.8 | **>>> Check this stuff too>>Might be part of Subteam plans** |  | 1d? | 2004-10-20 | 2004-10-20 |  |  |  | 422d |  |  | 88h |  |
| 359 | 3.8.1 | Review and Validate draft SOP’s for completeness |  | 0.5d? | 2004-10-20 | 2004-10-20 | 2005-01-19 | 2005-01-19 | 0.5d? | 422.5d |  | GSTOP Team; GTG; GTAG; Reviewers | 16h |  |
| 360 | 3.8.2 | Review and Validate draft SOP’s for GIS content |  | 1d? | 2004-10-20 | 2004-10-20 | 2005-01-19 | 2005-01-19 | 1d? | 422d |  | GSTOP Team; GTAG; Reviewers | 24h |  |
| 361 | 3.8.3 | Consolidate reviewers' inputs |  | 1d? | 2004-10-20 | 2004-10-20 | 2005-01-19 | 2005-01-19 | 1d? | 422d |  |  |  |  |
| 362 | 3.8.4 | Evaluate Feedback for inclusion in SOP revision |  | 1d? | 2004-10-20 | 2004-10-20 | 2005-01-19 | 2005-01-19 | 1d? | 422d |  | GSTOP Team; Independent Reviewer | 16h |  |
| 363 | 3.8.5 | Incorporate accepted feedback from reviewers |  | 1d? | 2004-10-20 | 2004-10-20 | 2005-01-19 | 2005-01-19 | 1d? | 422d |  | GSTOP Subteam(s) | 8h | Revised Draft SOPs |
| 364 | 3.8.6 | **Agencies' review of Draft SOPs** |  | 1d? | 2004-10-20 | 2004-10-20 | 2005-01-19 | 2005-01-19 | 1d? | 422d |  | all concerned/impacted parties | 16h |  |
| 365 | 3.8.6.1 | Create a cover letter and response process |  | 1d? | 2004-10-20 | 2004-10-20 | 2005-01-19 | 2005-01-19 | 1d? | 422d |  |  |  | cover letter |
| 366 | 3.8.6.2 | Review and Validate draft SOP’s |  | 1d? | 2004-10-20 | 2004-10-20 | 2005-01-19 | 2005-01-19 | 1d? | 422d |  | NWCG Member Agencies | 8h |  |
| 367 | 3.8.6.3 | Evaluate Feedback for inclusion in SOP revision |  | 1d? | 2004-10-20 | 2004-10-20 | 2005-01-19 | 2005-01-19 | 1d? | 422d |  |  |  |  |
| 368 | 3.8.6.4 | Incorporate Feedback from reviewers |  | 1d? | 2004-10-20 | 2004-10-20 | 2005-01-19 | 2005-01-19 | 1d? | 422d |  |  |  |  |
| 369 | 3.8.7 | Develop GSTOP Change Management Plan |  | 1d? | 2004-10-20 | 2004-10-20 | 2005-01-19 | 2005-01-19 | 1d? | 422d |  |  |  |  |
| 370 | 3.8.8 | Review GSTOP Change Management Plan |  | 1d? | 2004-10-20 | 2004-10-20 | 2005-01-19 | 2005-01-19 | 1d? | 422d |  | GTG Exec Comm | 8h |  |
| 371 | 3.8.9 | PRELIMINARY GIS SOP’s READY FOR FIELD TESTING | milestone | 0d | 2004-10-20 | 2004-10-20 | 2005-01-18 | 2005-01-18 | 0d | 423d |  |  |  |  |
| 373 | 4 | **Incident GIS SOPs Field Test** |  | 302d? | 2004-10-20 | 2005-12-15 |  |  |  | 121d |  | IMT Teams | 2440h |  |
| 374 | 4.1 | Develop Quality Assurance and Field Test Plan |  | 1d? | 2004-10-20 | 2004-10-20 |  |  |  | 422d |  | Subteam Lead | 8h |  |
| 375 | 4.2 | Develop Questionnaire |  | 1d? | 2004-10-20 | 2004-10-20 |  |  |  | 422d |  |  |  |  |
| 376 | 4.3 | Execute Quality Assurance and Field Test Plan |  | 1d? | 2004-10-20 | 2004-10-20 |  |  |  | 422d |  | Subteam Lead | 8h |  |
| 377 | 4.4 | Collect written/survey results from the field test |  | 1d? | 2004-10-20 | 2004-10-20 |  |  |  | 422d |  |  |  |  |
| 378 | 4.5 | Conduct interviews with GISTs to measure success of Draft SOPs |  | 1d? | 2004-10-20 | 2004-10-20 |  |  |  | 422d |  |  |  |  |
| 379 | 4.6 | Conduct interviews with SIT Unit Leaders to measure success of Draft SOPs |  | 1d? | 2004-10-20 | 2004-10-20 |  |  |  | 422d |  |  |  |  |
| 380 | 4.7 | Analyze Quality Assurance and Field Test Plan Results |  | 1d? | 2004-10-20 | 2004-10-20 |  |  |  | 422d |  |  |  |  |
| 381 | 4.8 | Conduct Field Test of GIS SOP Requirements |  | 0.5d? | 2004-10-20 | 2004-10-20 |  |  |  | 422.5d |  | Business Community; Business Lead | 8h |  |
| 382 | 4.9 | MS3: Requirements are reviewed and tested by business community | milestone | 0d | 2005-12-15 | 2005-12-15 |  |  |  | 0d | must finish on 2005-12-15 | Business Lead; Business Community; Project Mgr |  | buiness community issues document |

| ID | WBS | Task | Type | Duration | Start | Finish | Predecessors | Complete | Remaining | Total slack | Constraint | Resources | Work | Actual work | Text1 |
| --- | --- | --- | --- | --- | --- | --- | --- | --- | --- | --- | --- | --- | --- | --- | --- |
| 385 | 5 | **Final Incident GIS SOPs** |  | 260d? | 2005-06-03 | 2006-06-01 | 21 |  |  | 1d |  | GSTOP Team | 2080h |  |  |
| 386 | 5.1 | Analyze feedback on Incident GIS SOPs |  | 1d? | 2005-06-03 | 2005-06-03 |  |  |  | 260d |  |  |  |  |  |
| 387 | 5.2 | Update and finalize Incident GIS SOPs |  | 1d? | 2005-06-03 | 2005-06-03 |  |  |  | 260d |  |  |  |  |  |
| 388 | 5.3 | Deliver Final Incident GIS SOPs to Executive Committee |  | 1d? | 2005-06-03 | 2005-06-03 |  |  |  | 260d |  |  |  |  |  |
| 389 | 5.4 | Deliver Final Incident GIS SOPs to Incident Based Automation Project |  | 1d? | 2005-06-03 | 2005-06-03 |  |  |  | 260d |  |  |  |  |  |
| 390 | 5.5 | MS5: GIS SOPs are finalized | milestone | 0d | 2006-05-15 | 2006-05-15 |  |  |  | 0d | must finish on 2006-05-15 | Project Mgr; GSTOP Exec Comm |  |  | final GIS SOPs |
| 392 | 5.6 | MS6: Draft recommendation for SOP implementation | milestone | 0d | 2006-06-01 | 2006-06-01 |  |  |  | 0d | must finish on 2006-06-01 | GSTOP Team; GSTOP Exec Comm |  |  | GIS SOP Implementation Recommendations |
| 393 | 6 | **GSTOP Project Management** |  | 423d? | 2004-10-20 A | 2006-06-02 |  | 30% | 296.1d? | 0d |  | Sue McLellan | 7512h | 360h |  |
| 394 | 6.1 | **Manage GSTOP Project** |  | 147d? | 2004-10-20 A | 2005-05-12 |  | 38% | 91.88d? | 276d |  |  | 744h | 360h |  |
| 395 | 6.1.1 | Implement GSTOP Project Communication Plan |  | 1d? | 2004-10-20 | 2004-10-20 |  |  |  | 422d |  | Business Lead | 8h |  |  |
| 396 | 6.1.2 | **Conduct Periodic Team Meetings** |  | 78d | 2005-01-25 A | 2005-05-12 |  | 50% | 39d | 276d |  | Project Mgr | 720h | 360h |  |
| 397 | 6.1.2.1 | Conduct January Team Meeting (Portland) |  | 3d | 2005-01-25 A | 2005-01-27 A |  | 100% |  |  | start no earlier than 2005-01-25 | GSTOP Team; Project Mgr | 48h | 48h |  |
| 398 | 6.1.2.2 | Conduct May Team Meeting (Denver) |  | 3d | 2005-05-10 | 2005-05-12 |  |  |  | 276d | start no earlier than 2005-05-10 | GSTOP Team; Project Mgr | 48h |  |  |
| 399 | 6.1.3 | **Report to Executive Committee** |  | 105d | 2004-10-20 A | 2005-03-16 |  |  | 105d | 318d |  |  | 16h |  |  |
| 400 | 6.1.3.1 | Q1 2005 Executive Briefing | milestone | 0d | 2005-03-16 A | 2005-03-16 A |  | 100% |  |  |  | Project Mgr; GTG Exec Comm |  |  | Executive Report |
| 401 | 6.1.3.2 | Q2 2005 Executive Briefing |  | 1d | 2004-10-20 | 2004-10-20 |  |  |  | 422d |  | Project Mgr; GTG Exec Comm | 16h |  | Executive Report |
| 402 | 6.2 | **Closeout GSTOP Project** |  | 423d? | 2004-10-20 | 2006-06-02 |  |  |  | 0d |  | GTG Exec Comm | 3384h |  |  |
| 403 | 6.2.1 | Prepare GSTOP Team Recommendations |  | 1d? | 2004-10-20 | 2004-10-20 |  |  |  | 422d |  |  |  |  |  |
| 404 | 6.2.2 | Document Lessons Learned |  | 1d? | 2004-10-20 | 2004-10-20 |  |  |  | 422d |  |  |  |  |  |
| 405 | 6.2.3 | GSTOP Project Complete | milestone | 0d | 2006-06-02 | 2006-06-02 |  |  |  | 0d | finish no earlier than 2006-06-02 |  |  |  |  |
