# GSTOP_rev 1

Schedule from MS Project, 2004-10-20 to 2006-06-02, status date 2005-03-23, A marks actual dates.
GSTOP Project Plan

## Calendars

- Standard: Mon-Fri 08:00-12:00, 13:00-17:00; Sat-Sun off.

## Resources

| Resource |
| --- |
| GTG |
| GTG Exec Comm |
| Symbol Subteam |
| NWCG Training Team |
| GSTOP Team |
| NWCG Member Agencies |
| Reviewers |
| GSTOP Subteam(s) |
| all concerned/impacted parties |
| Business Community |
| BLM publication shop |
| Business Lead |
| Business Lead |
| FGDC |
| NARA |
| GeoMAC |
| NPS I&M |
| NPS Focus |
| IRMWT |
| Project Mgr |
| Sean Triplett |
| IMT Teams |
| GTAG |
| Firescope |
| NWCG Agency |
| FEMA |
| GACC guidelines |
| Ken Bottle |
| Subteam Lead |
| Victoria Smith |
| Deb Epps |
| Independent Reviewer |
| GSTOP Exec Comm |
| John Guthrie |
| Karen Folger |
| Sherry Durst |
| Kim Kelly |
| Luther Arizana |
| Emmor Nile |
| Sue McLellan |
| StdProd Subteam |
| GIST Qual/GIS Min Expec Subteam |
| Elise Browne |
| MED Subteam |
| Eric |
| DataShareArcTrans Subteam |
| GTG Standards Committee |
| Internet Search |
| Military |
| etc. |
| survey GISTs |
| Plans Sections (Mary Kwart) |
| Documents Sections |
| Mary Kwart |
| agency guidance |
| TBD |
| Sub-Team |
| Other "team" environs (e.g. military) |
| survey? Mary Kwart? |
| field teams |
| Susan Goodman |
| Other "team" environs |
| survey |
| NamConvSubteam |
| BLM Pulications |
| NWCG Working teams |
| NWCG PMO |
| Project Mgt |
| IMT Planning Section |
| Technical Specialists |
| NIIMS Group |
| Department of Homeland Security (DHS) |
| ESRI |

## Schedule

| ID | WBS | Task | Duration | Start | Finish | Predecessors | Complete | Remaining | Baseline start | Baseline finish | Baseline duration | Total slack | Free slack | Constraint | Resources | Work | Actual work | Text1 |
| --- | --- | --- | --- | --- | --- | --- | --- | --- | --- | --- | --- | --- | --- | --- | --- | --- | --- | --- |
| 1 | 1 | **Initiate the GSTOP Project** | 105d? | 2004-10-20 A | 2005-03-15 A |  | 100% |  | 2004-11-30 | 2004-12-01 | 2d |  |  |  | GTG Exec Comm | 5504h | 5504h |  |
| 2 | 1.1 | GSTOP Executive Committee Formed | 6d | 2004-12-01 A | 2004-12-08 A |  | 100% |  | 2004-12-01 | 2004-12-01 | 1d |  |  | finish no earlier than 2004-12-08 | IRMWT | 48h | 48h |  |
| 3 | 1.2 | GSTOP Project Manager Identified | 1d | 2004-10-20 A | 2004-10-20 A |  | 100% |  | 2004-11-30 | 2004-12-01 | 2d |  |  | finish no earlier than 2004-10-20 | GTG Exec Comm | 8h | 8h |  |
| 4 | 1.3 | GSTOP Project Charter Approved | 31d | 2004-10-20 A | 2004-12-01 A |  | 100% |  | 2004-12-01 | 2004-12-01 | 1d |  |  |  | NWCG Member Agencies | 248h | 248h | Project Charter |
| 5 | 1.4 | Secure GSTOP Project Funding | 68d | 2004-12-01 A | 2005-03-04 A |  | 100% |  | 2004-12-01 | 2004-12-01 | 1d |  |  | finish no earlier than 2005-03-04 | NWCG Member Agencies | 544h | 544h |  |
| 6 | 1.5 | **Identify GSTOP Project Team** | 74d? | 2004-12-02 A | 2005-03-15 A |  | 100% |  | 2004-12-01 | 2004-12-01 | 1d |  |  |  | GTG Exec Comm | 3816h | 3816h | Team Roster |
| 7 | 1.5.1 | **Form the GSTOP Team** | 74d? | 2004-12-02 A | 2005-03-15 A | 4 | 100% |  | 2004-12-01 | 2004-12-31 | 22d? |  |  |  | GTG Exec Comm | 3224h | 3224h |  |
| 8 | 1.5.1.1 | GSTOP Project Business Lead Identified | 29d | 2004-12-15 A | 2005-01-24 A |  | 100% |  | 2004-12-31 | 2004-12-31 | 0d |  |  | finish no earlier than 2005-01-24 | Project Mgr | 232h | 232h |  |
| 9 | 1.5.1.2 | Define and Assign Project Subteams and Leads | 5d? | 2004-12-02 A | 2004-12-08 A |  | 100% |  | 2004-12-01 | 2004-12-01 | 1d? |  |  |  | Project Mgr | 40h | 40h |  |
| 10 | 1.5.1.3 | Develop Project Team Operating Principles & Guidelines | 5d? | 2004-12-02 A | 2004-12-08 A |  | 100% |  | 2004-12-01 | 2004-12-01 | 1d? |  |  |  | Project Mgr | 40h | 40h | Operating Principles Doc |
| 11 | 1.5.1.4 | **Develop the GSTOP Project Management Plans** | 74d? | 2004-12-02 A | 2005-03-15 A |  | 100% |  | 2004-12-01 | 2004-12-06 | 4d? |  |  |  | Project Mgr | 1976h | 1976h |  |
| 12 | 1.5.1.4.1 | Review Charter and resolve any ambiguities/issues | 51d? | 2004-12-02 A | 2005-02-10 A |  | 100% |  | 2004-12-01 | 2004-12-01 | 1d? |  |  |  | Project Mgr | 408h | 408h | Updated Charter |
| 13 | 1.5.1.4.2 | Develop Intial Project Work Plan | 50d? | 2004-12-02 A | 2005-02-09 A |  | 100% |  | 2004-12-01 | 2004-12-01 | 1d? |  |  |  | Project Mgr | 400h | 400h | Work Plan |
| 14 | 1.5.1.4.3 | Develop Intial Project Communication Plan | 72d | 2004-12-06 A | 2005-03-15 A |  | 100% |  | 2004-12-06 | 2004-12-06 | 1d |  |  | finish no earlier than 2005-03-15 | Business Lead | 576h | 576h | Communication Plan |
| 15 | 1.5.1.4.4 | Develop Intial Project Responsibility Matrix | 1d? | 2004-12-02 A | 2004-12-02 A |  | 100% |  | 2004-12-01 | 2004-12-01 | 1d? |  |  |  |  |  |  |  |
| 16 | 1.5.1.4.5 | Develop Intial Project Resource Plan | 31d? | 2004-12-02 A | 2005-01-13 A |  | 100% |  | 2004-12-01 | 2004-12-01 | 1d? |  |  |  |  |  |  | Staffing Plan |
| 17 | 1.5.1.5 | **Setup the project team's structures for communication** | 42d? | 2004-12-02 A | 2005-01-28 A |  | 100% |  | 2004-12-01 | 2004-12-01 | 1d? |  |  |  | Business Lead | 344h | 344h |  |
| 18 | 1.5.1.5.1 | Create GSTOP private team workspace | 1d? | 2004-12-02 A | 2004-12-02 A |  | 100% |  | 2004-12-01 | 2004-12-01 | 1d? |  |  |  | Sean Triplett | 8h | 8h | Accessible Workspace |
| 19 | 1.5.1.5.2 | Develop Project Status Report Template | 42d? | 2004-12-02 A | 2005-01-28 A |  | 100% |  | 2004-12-01 | 2004-12-01 | 1d? |  |  |  |  |  |  |  |
| 20 | 2 | **GSTOP Requirements** | 142d? | 2004-12-01 A | 2005-06-16 | 1 | 18% | 115.99d? | 2004-12-31 | 2005-01-18 | 13d? | 251d |  |  | GSTOP Team | 8223.33h | 1123.82h |  |
| 21 | 2.1 | **Incident GIS Standard Symbology** | 142d? | 2004-12-01 A | 2005-06-16 |  | 19% | 114.46d? | 2004-12-31 | 2005-01-05 | 4d? | -54d | 0d |  | Ken Bottle | 2528h | 220.31h |  |
| 22 | 2.1.1 | **Establish Symbols Sub-Team business practices** | 58d? | 2005-01-12 A | 2005-04-01 |  |  | 58d? | 2004-12-31 | 2004-12-31 | 1d? | 0d |  |  |  | 424h |  |  |
| 23 | 2.1.1.1 | **Develop a Symbol Sub-team Communication Plan** | 53d? | 2005-01-12 A | 2005-03-25 |  |  | 53d? | 2004-12-31 | 2004-12-31 | 1d? | 4d |  |  | Ken Bottle | 424h |  | Communication Plan |
| 24 | 2.1.1.1.1 | Define ground-rules for Sub-Team (internal) communication | 53d? | 2005-01-12 A | 2005-03-25 |  |  | 53d? | 2004-12-31 | 2004-12-31 | 1d? | 4d |  | finish no earlier than 2005-03-25 |  |  |  |  |
| 25 | 2.1.1.1.2 | Define ground-rules for communication between the Symbol Sub-Team and other GSTOP Sub-Teams | 53d? | 2005-01-12 A | 2005-03-25 |  |  | 53d? | 2004-12-31 | 2004-12-31 | 1d? | 4d |  | finish no earlier than 2005-03-25 |  |  |  |  |
| 26 | 2.1.1.1.3 | Define ground rules for communication between the Sub-Team and entities outside of the GSTOP Project | 53d? | 2005-01-12 A | 2005-03-25 |  |  | 53d? | 2004-12-31 | 2004-12-31 | 1d? | 4d |  | finish no earlier than 2005-03-25 |  |  |  |  |
| 27 | 2.1.1.1.4 | Establish a process and schedule for Sub-Team (internal) progress report updates | 53d? | 2005-01-12 A | 2005-03-25 |  |  | 53d? | 2004-12-31 | 2004-12-31 | 1d? | 4d |  | finish no earlier than 2005-03-25 |  |  |  |  |
| 28 | 2.1.1.1.5 | Establish a process and schedule for Sub-Team progress report updates to the GSTOP Team | 53d? | 2005-01-12 A | 2005-03-25 |  |  | 53d? | 2004-12-31 | 2004-12-31 | 1d? | 4d |  | finish no earlier than 2005-03-25 |  |  |  |  |

| ID | WBS | Task | Duration | Start | Finish | Predecessors | Remaining | Baseline start | Baseline finish | Baseline duration | Total slack | Free slack | Constraint | Resources | Work | Text1 |
| --- | --- | --- | --- | --- | --- | --- | --- | --- | --- | --- | --- | --- | --- | --- | --- | --- |
| 29 | 2.1.1.2 | **Establish Review Processes** | 58d? | 2005-01-12 A | 2005-04-01 |  | 58d? | 2004-12-31 | 2004-12-31 | 1d? | 0d |  |  |  |  | Symbol Set Review Process |
| 30 | 2.1.1.2.1 | Establish a process for Sub-Team (internal) review of potential symbols | 58d? | 2005-01-12 A | 2005-04-01 |  | 58d? | 2004-12-31 | 2004-12-31 | 1d? | 0d |  | finish no earlier than 2005-04-01 |  |  |  |
| 31 | 2.1.1.2.2 | Establish a process for Sub-Team (internal) review of the draft standard symbols | 58d? | 2005-01-12 A | 2005-04-01 |  | 58d? | 2004-12-31 | 2004-12-31 | 1d? | 0d |  | finish no earlier than 2005-04-01 |  |  |  |
| 32 | 2.1.1.2.3 | Establish a process for peer reviews | 58d? | 2005-01-12 A | 2005-04-01 |  | 58d? | 2004-12-31 | 2004-12-31 | 1d? | 0d |  | finish no earlier than 2005-04-01 |  |  |  |
| 33 | 2.1.1.2.4 | Establish a process for periodic GSTOP Team reviews | 58d? | 2005-01-12 A | 2005-04-01 |  | 58d? | 2004-12-31 | 2004-12-31 | 1d? | 0d |  | finish no earlier than 2005-04-01 |  |  |  |
| 34 | 2.1.1.2.5 | Establish a process for reviewing the final report | 58d? | 2005-01-12 A | 2005-04-01 |  | 58d? | 2004-12-31 | 2004-12-31 | 1d? | 0d |  | finish no earlier than 2005-04-01 |  |  |  |
| 35 | 2.1.1.3 | **Establish Change processes** | 58d? | 2005-01-12 A | 2005-04-01 |  | 58d? | 2004-12-31 | 2004-12-31 | 1d? | 0d |  |  |  |  | Symbol Set Change Process |
| 36 | 2.1.1.3.1 | Establish a process for additions/deletions of potential symbols mid-stream through the Project | 58d? | 2005-01-12 A | 2005-04-01 |  | 58d? | 2004-12-31 | 2004-12-31 | 1d? | -58d | 0d |  |  |  |  |
| 37 | 2.1.1.3.2 | Establish a change process for the additions/deletion of standard symbols after the final recommendation has been submitted and prior to completion of the GSTOP project | 58d? | 2005-01-12 A | 2005-04-01 | 36 | 58d? | 2004-12-31 | 2004-12-31 | 1d? | -58d | 0d |  |  |  |  |
| 38 | 2.1.1.3.3 | Establish a change process for the additions/deletion of standard symbols after the completion of the GSTOP project | 58d? | 2005-01-12 A | 2005-04-01 | 37 | 58d? | 2004-12-31 | 2004-12-31 | 1d? | -1d | 0d |  |  |  |  |
| 39 | 2.1.2 | **Develop GIS Standard Symbology SOP Requirements** | 49d? | 2005-02-01 A | 2005-04-08 |  | 49d? |  |  |  | -5d | 0d |  |  | 408h |  |
| 40 | 2.1.2.1 | **Establish symbol evaluation methods** | 12d? | 2005-03-17 | 2005-04-01 |  |  | 2004-12-31 | 2004-12-31 | 1d? | -7d | 0d |  |  |  |  |
| 41 | 2.1.2.1.1 | Define method for evaluating marker symbols | 12d? | 2005-03-17 | 2005-04-01 |  |  | 2004-12-31 | 2004-12-31 | 1d? | -7d | 0d | finish no earlier than 2005-04-01 |  |  |  |
| 42 | 2.1.2.1.2 | Define method for evaluating line symbols | 12d? | 2005-03-17 | 2005-04-01 |  |  | 2004-12-31 | 2004-12-31 | 1d? | -7d | 0d | finish no earlier than 2005-04-01 |  |  |  |
| 43 | 2.1.2.1.3 | Define method for evaluating fill symbols | 12d? | 2005-03-17 | 2005-04-01 |  |  | 2004-12-31 | 2004-12-31 | 1d? | -7d | 0d | finish no earlier than 2005-04-01 |  |  |  |
| 44 | 2.1.2.1.4 | Conduct a final review of evaluation methods | 12d? | 2005-03-17 | 2005-04-01 |  |  | 2004-12-31 | 2004-12-31 | 1d? | -7d | 0d | finish no earlier than 2005-04-01 |  |  | Standard Symbol Evaluation Methodology |
| 45 | 2.1.2.2 | **Define criteria for the acceptance of symbols as standards** | 17d? | 2005-03-17 | 2005-04-08 |  |  | 2004-12-31 | 2004-12-31 | 1d? | -12d | 0d |  | John Guthrie; Karen Folger; Ken Bottle | 408h |  |
| 46 | 2.1.2.2.1 | Develop acceptance criteria for marker symbols | 17d? | 2005-03-17 | 2005-04-08 |  |  | 2004-12-31 | 2004-12-31 | 1d? | -12d | 0d | finish no earlier than 2005-04-08 |  |  |  |
| 47 | 2.1.2.2.2 | Develop acceptance criteria for line symbols | 17d? | 2005-03-17 | 2005-04-08 |  |  | 2004-12-31 | 2004-12-31 | 1d? | -12d | 0d | finish no earlier than 2005-04-08 |  |  |  |
| 48 | 2.1.2.2.3 | Develop acceptance criteria for fill symbols | 17d? | 2005-03-17 | 2005-04-08 |  |  | 2004-12-31 | 2004-12-31 | 1d? | -12d | 0d | finish no earlier than 2005-04-08 |  |  |  |
| 49 | 2.1.2.2.4 | Conduct a final review of selection criteria | 17d? | 2005-03-17 | 2005-04-08 |  |  | 2004-12-31 | 2004-12-31 | 1d? | -12d | 0d | finish no earlier than 2005-04-08 |  |  | Standard Symbol Acceptance Criteria |
| 50 | 2.1.2.3 | **Establish file format for symbols** | 44d? | 2005-02-01 A | 2005-04-01 |  | 44d? | 2004-12-31 | 2004-12-31 | 1d? | 0d |  |  |  |  |  |
| 51 | 2.1.2.3.1 | Define acceptable formats of symbols for evaluation | 44d? | 2005-02-01 A | 2005-04-01 |  | 44d? | 2004-12-31 | 2004-12-31 | 1d? | 0d |  | finish no earlier than 2005-04-01 |  |  |  |
| 52 | 2.4.1.2 | Define format of recommended standard symbols | 44d? | 2005-02-01 A | 2005-04-01 |  | 44d? | 2004-12-31 | 2004-12-31 | 1d? | 0d |  | finish no earlier than 2005-04-01 |  |  |  |

| ID | WBS | Task | Type | Duration | Start | Finish | Predecessors | Complete | Remaining | Baseline start | Baseline finish | Baseline duration | Total slack | Free slack | Constraint | Resources | Work | Text1 |
| --- | --- | --- | --- | --- | --- | --- | --- | --- | --- | --- | --- | --- | --- | --- | --- | --- | --- | --- |
| 53 | 2.1.3 | **Develop Draft GIS Standard Symbology SOPs** |  | 125d? | 2004-12-01 A | 2005-05-24 | 39 | 81% | 24.09d? |  |  |  | -38d | 0d |  |  | 464h |  |
| 54 | 2.1.3.1 | **Develop a list of symbols to be evaluated for acceptance as draft standards** |  | 101d? | 2004-12-01 A | 2005-04-20 |  | 94% | 6.24d? | 2004-12-31 | 2004-12-31 | 1d? | -20d | 0d |  |  | 168h |  |
| 55 | 2.1.3.1.1 | Collect Fire mapping symbols from the Fireline Handbook |  | 81d? | 2004-12-01 A | 2005-03-23 A |  | 100% |  | 2004-12-31 | 2004-12-31 | 1d? |  |  |  |  |  | symbol image files |
| 56 | 2.1.3.1.2 | Collect Fire mapping symbols suggestions from the 5 federal fire management agencies (FS, BLM, NPS, FWS, BIA) and state agencies |  | 81d? | 2004-12-01 A | 2005-03-23 A |  | 100% |  | 2004-12-31 | 2004-12-31 | 1d? |  |  |  |  |  | symbol image files |
| 57 | 2.1.3.1.3 | Collect Fire mapping symbols suggestions from the BIA |  | 7d? | 2005-04-11 | 2005-04-19 | 56 |  |  | 2004-12-31 | 2004-12-31 | 1d? | -55d | 0d | finish no earlier than 2005-04-01 | Kim Kelly; Luther Arizana | 112h | symbol image files |
| 58 | 2.1.3.1.4 | Collect Fire mapping symbols from HSA (FEMA), FAA |  | 81d? | 2004-12-01 A | 2005-03-23 A |  | 100% |  | 2004-12-31 | 2004-12-31 | 1d? |  |  |  |  |  | symbol image files |
| 59 | 2.1.3.1.5 | Collect Fire mapping symbols from HSA (FEMA), FAA, and DOD |  | 7d? | 2005-04-11 | 2005-04-19 | 58 |  |  | 2004-12-31 | 2004-12-31 | 1d? | -54d | 0d | finish no earlier than 2005-04-01 | Sherry Durst | 56h | symbol image files |
| 60 | 2.1.3.1.6 | Document potential sources for additional fire mapping symbols |  | 1d? | 2005-04-11 | 2005-04-11 |  |  |  | 2004-12-31 | 2004-12-31 | 1d? | -48d | 0d |  |  |  | List of data sources |
| 61 | 2.1.3.1.7 | Compile symbols into a single potential symbol set |  | 1d? | 2005-04-20 | 2005-04-20 | 55, 56, 57, 58 |  |  | 2004-12-31 | 2004-12-31 | 1d? | -55d | 0d |  |  |  | Set of potential standard symbols |
| 62 | 2.1.3.2 | **Determine the draft standard marker symbols** |  | 8d? | 2005-04-21 | 2005-05-02 | 54 |  |  | 2004-12-31 | 2004-12-31 | 1d? | -55d | 0d |  |  | 72h |  |
| 63 | 2.1.3.2.1 | Evaluate each potential marker symbol against the marker symbol selection criteria |  | 1d? | 2005-04-21 | 2005-04-21 |  |  |  | 2004-12-31 | 2004-12-31 | 1d? | -48d | 0d |  |  |  | Marker Symbol Evaluation Document |
| 64 | 2.1.3.2.2 | Selection the draft standard marker symbols |  | 1d? | 2005-04-21 | 2005-04-21 |  |  |  | 2004-12-31 | 2004-12-31 | 1d? | -48d | 0d |  | Symbol Subteam | 8h | Draft list of selected marker symbols |
| 65 | 2.1.3.2.3 | Conduct a completeness review of the draft standard marker symbols |  | 8d? | 2005-04-21 | 2005-05-02 |  |  |  | 2004-12-31 | 2004-12-31 | 1d? | -55d | 0d | finish no earlier than 2005-04-14 | Symbol Subteam | 64h | Draft Standard Marker Symbols document |
| 66 | 2.1.3.3 | **Determine the draft standard line symbols** |  | 8d? | 2005-04-21 | 2005-05-02 | 54 |  |  | 2004-12-31 | 2004-12-31 | 1d? | -55d | 0d |  |  | 72h |  |
| 67 | 2.1.3.3.1 | Evaluate each potential line symbol against the line symbol selection criteria |  | 1d? | 2005-04-21 | 2005-04-21 |  |  |  | 2004-12-31 | 2004-12-31 | 1d? | -48d | 0d |  |  |  | Line Symbol Evaluation Document |
| 68 | 2.1.3.3.2 | Select the draft standard line symbols |  | 1d? | 2005-04-21 | 2005-04-21 |  |  |  | 2004-12-31 | 2004-12-31 | 1d? | -48d | 0d |  | Symbol Subteam | 8h | Draft list of selected Line symbols |
| 69 | 2.1.3.3.3 | Conduct a completeness review of the draft standard line symbols |  | 8d? | 2005-04-21 | 2005-05-02 |  |  |  | 2004-12-31 | 2004-12-31 | 1d? | -55d | 0d | finish no earlier than 2005-04-14 | Symbol Subteam | 64h | Draft Standard Line Symbols document |
| 70 | 2.1.3.4 | **Determine the draft standard fill symbols** |  | 8d? | 2005-04-21 | 2005-05-02 | 54 |  |  | 2004-12-31 | 2004-12-31 | 1d? | -55d | 0d |  |  | 72h |  |
| 71 | 2.1.3.4.1 | Evaluate each potential fill symbol against the fill symbol selection criteria |  | 1d? | 2005-04-21 | 2005-04-21 |  |  |  | 2004-12-31 | 2004-12-31 | 1d? | -48d | 0d |  |  |  | Fill Symbol Evaluation Document |
| 72 | 2.1.3.4.2 | Select the draft standard fill symbols |  | 1d? | 2005-04-21 | 2005-04-21 |  |  |  | 2004-12-31 | 2004-12-31 | 1d? | -48d | 0d |  | Symbol Subteam | 8h | Draft list of selected fill symbols |
| 73 | 2.1.3.4.3 | Conduct a completeness review of the draft standard fill symbols |  | 8d? | 2005-04-21 | 2005-05-02 |  |  |  | 2004-12-31 | 2004-12-31 | 1d? | -55d | 0d | finish no earlier than 2005-04-14 | Symbol Subteam | 64h | Draft Standard fill Symbols document |
| 74 | 2.1.3.5 | **Conduct initial peer review of the draft standard marker, line, and fill symbols** |  | 16d? | 2005-05-03 | 2005-05-24 | 62, 66, 70 |  |  | 2004-12-31 | 2005-01-05 | 4d? | -55d | 0d |  |  | 80h |  |
| 75 | 2.1.3.5.1 | Prepare draft standard symbols for initial peer review |  | 1d? | 2005-05-03 | 2005-05-03 |  |  |  | 2004-12-31 | 2004-12-31 | 1d? | -55d | 0d |  |  |  | Initial Peer Review Package |
| 76 | 2.1.3.5.2 | Submit the draft standard symbols to the 5 federal fire management agencies and State agencies via the NWCG Geospatial Task Group (GTG); and to the HSA (FEMA), FAA, DOD, and GSTOP Team for peer review | milestone | 0d | 2005-05-03 | 2005-05-03 | 75 |  |  | 2004-12-31 | 2004-12-31 | 1d? | -55d | 0d |  |  |  | Submission Report |
| 77 | 2.1.3.5.3 | Review draft Standard Symbols |  | 5d | 2005-05-04 | 2005-05-10 | 76 |  |  |  |  |  | -45d | 0d |  | GSTOP Team; GTG | 80h | Initial Feedback on Standard Symbols |
| 78 | 2.1.3.5.4 | Review feedback of initial peer review |  | 2d | 2005-05-18 | 2005-05-19 | 76FS+10d |  |  | 2005-01-03 | 2005-01-03 | 1d? | -55d | 0d |  |  |  | Initial Peer Review Document |
| 79 | 2.1.3.5.5 | Identify required changes to draft standard symbols based on the initial peer review feedback |  | 2d | 2005-05-20 | 2005-05-23 | 78 |  |  | 2005-01-04 | 2005-01-04 | 1d? | -55d | 0d |  |  |  | List of required symbol changes |
| 80 | 2.1.3.5.6 | Make required changes, as identified, to draft standard symbols |  | 1d? | 2005-05-24 | 2005-05-24 | 79 |  |  | 2005-01-05 | 2005-01-05 | 1d? | -55d | 0d |  |  |  | Initial updated Symbols list |
| 81 | 2.1.3.6 | Prepare draft SOPs for field review |  | 1d? | 2005-04-19 | 2005-04-19 | 376 |  |  |  |  |  | -13d | 0d |  |  |  |  |

| ID | WBS | Task | Type | Duration | Start | Finish | Predecessors | Complete | Remaining | Baseline start | Baseline finish | Baseline duration | Total slack | Free slack | Resources | Work | Actual work | Text1 |
| --- | --- | --- | --- | --- | --- | --- | --- | --- | --- | --- | --- | --- | --- | --- | --- | --- | --- | --- |
| 82 | 2.1.4 | **Conduct final peer review of the draft standard marker, line and fill symbols** |  | 17d? | 2005-05-25 | 2005-06-16 | 74 |  |  | 2004-12-31 | 2004-12-31 | 1d? | -55d | 0d |  | 88h |  |  |
| 83 | 2.1.4.1 | Prepare draft standard symbols for final peer review |  | 1d? | 2005-05-25 | 2005-05-25 |  |  |  | 2004-12-31 | 2004-12-31 | 1d? | -55d | 0d |  |  |  | Final Peer Review Package |
| 84 | 2.1.4.2 | Submit the draft standard symbols to the 5 federal fire management agencies and State agencies via the NWCG Geospatial Task Group (GTG); and to the HSA (FEMA), FAA, DOD, and GSTOP Team for peer review | milestone | 0d | 2005-05-25 | 2005-05-25 | 83 |  |  | 2004-12-31 | 2004-12-31 | 1d? | -55d | 0d |  |  |  | Submission Report |
| 85 | 2.1.4.3 | Review draft Standard Symbols |  | 10d | 2005-05-26 | 2005-06-08 | 84 |  |  |  |  |  | -55d | 0d | Reviewers | 80h |  | Final Feedback on Standard Symbols |
| 86 | 2.1.4.4 | Review feedback of the final peer review |  | 1d? | 2005-06-09 | 2005-06-09 | 85 |  |  | 2004-12-31 | 2004-12-31 | 1d? | -55d | 0d |  |  |  | Final Peer Review Document |
| 87 | 2.1.4.5 | Identify required changes to draft standard symbols based on the final peer review feedback |  | 2d | 2005-06-10 | 2005-06-13 | 86 |  |  | 2004-12-31 | 2004-12-31 | 1d? | -55d | 0d |  |  |  | List of required symbol changes |
| 88 | 2.1.4.6 | Make required changes, as identified, to draft standard symbols |  | 2d | 2005-06-14 | 2005-06-15 | 87 |  |  | 2004-12-31 | 2004-12-31 | 1d? | -55d | 0d |  |  |  | final updated symbols list |
| 89 | 2.1.4.7 | Ratify the final draft standard symbols |  | 1d? | 2005-06-16 | 2005-06-16 | 88 |  |  | 2004-12-31 | 2004-12-31 | 1d? | -55d | 0d | Symbol Subteam | 8h |  | Final Draft Standard Symbols List |
| 90 | 2.1.5 | **Finalize recommendation of standard Fire Mapping symbols** |  | 2d? | 2005-03-16 | 2005-03-17 |  |  |  | 2004-12-31 | 2004-12-31 | 1d? | 10d |  |  | 8h |  |  |
| 91 | 2.1.5.1 | Create a report recommending the adoption of the draft standard symbols |  | 1d? | 2005-03-16 | 2005-03-16 |  |  |  | 2004-12-31 | 2004-12-31 | 1d? | 10d | 0d |  |  |  | Recommendation Report |
| 92 | 2.1.5.2 | Conduct a review of the report |  | 1d? | 2005-03-17 | 2005-03-17 | 91 |  |  | 2004-12-31 | 2004-12-31 | 1d? | 10d | 0d | Symbol Subteam | 8h |  | Finalized Recommendation Report |
| 93 | 2.1.5.3 | Submit the report to GSTOP-PM | milestone | 0d | 2005-03-17 | 2005-03-17 | 92 |  |  | 2004-12-31 | 2004-12-31 | 1d | 10d |  |  |  |  | Report Submission |
| 94 | 2.2 | **Incident GIS Standard Naming Conventions** |  | 81d? | 2005-01-25 A | 2005-05-17 |  | 21% | 64.3d? | 2004-12-31 | 2005-01-06 | 5d? | -28d | 0d | Emmor Nile | 848h | 181.61h |  |
| 95 | 2.2.1 | **Develop GIS Naming Convention/Directory Structure Subteam Practices** |  | 1d? | 2005-03-16 | 2005-03-16 |  |  |  |  |  |  | 11d |  |  |  |  |  |
| 96 | 2.2.1.1 | Set objectives for work plan |  | 1d? | 2005-03-16 | 2005-03-16 |  |  |  |  |  |  | 11d |  |  |  |  | document |
| 97 | 2.2.1.2 | Define ground rules for sub team |  | 1d? | 2005-03-16 | 2005-03-16 |  |  |  |  |  |  | 11d |  |  |  |  | document |
| 98 | 2.2.1.3 | Define common ground with other sub teams |  | 1d? | 2005-03-16 | 2005-03-16 |  |  |  |  |  |  | 11d |  |  |  |  | communications agreement |
| 99 | 2.2.2 | **Develop GIS Standard Naming Convention SOP Requirements** |  | 62d? | 2005-01-25 A | 2005-04-20 |  | 53% | 29.18d? |  |  |  | -9d | 0d |  | 64h | 48h |  |
| 100 | 2.2.2.1 | Define Information Needs (What do we need to gather?) |  | 1d? | 2005-03-16 | 2005-03-16 |  |  |  | 2004-12-31 | 2004-12-31 | 1d? | -25d | 0d |  |  |  |  |
| 101 | 2.2.2.2 | Collect existing naming and filing conventions from GIST's attached to IMT's |  | 1d? | 2005-03-17 | 2005-03-17 | 100 |  |  |  |  |  | -25d | 0d |  |  |  | physical examples |
| 102 | 2.2.2.3 | **Conduct Analysis** |  | 2d? | 2005-03-16 | 2005-03-17 |  |  |  | 2005-01-04 | 2005-01-04 | 1d? | -25d | 0d |  |  |  |  |
| 103 | 2.2.2.3.1 | Review strengths & weaknesses of existing methodologies |  | 1d? | 2005-03-16 | 2005-03-16 |  |  |  |  |  |  | -25d | 0d |  |  |  | shared |
| 104 | 2.2.2.3.2 | Resolve overlap and conflicts |  | 1d? | 2005-03-17 | 2005-03-17 | 103 |  |  |  |  |  | -25d | 0d |  |  |  |  |
| 105 | 2.2.2.4 | **Develop Preliminary Requirements for GIS Naming Convention and Directory Structure** |  | 3d? | 2005-01-25 A | 2005-01-27 A | 104 | 100% |  | 2005-01-05 | 2005-01-05 | 1d? |  |  |  | 48h | 48h | GIS Naming Convention Guidelines |
| 106 | 2.2.2.4.1 | Draft naming convention guidelines/requirements |  | 3d? | 2005-01-25 A | 2005-01-27 A |  | 100% |  |  |  |  |  |  | NamConvSubteam | 24h | 24h |  |
| 107 | 2.2.2.4.2 | Draft directory structure guidelines/requirements |  | 3d? | 2005-01-25 A | 2005-01-27 A | 106 | 100% |  |  |  |  |  |  | NamConvSubteam | 24h | 24h |  |

| ID | WBS | Task | Type | Duration | Start | Finish | Predecessors | Complete | Remaining | Baseline start | Baseline finish | Baseline duration | Total slack | Free slack | Constraint | Resources | Work |
| --- | --- | --- | --- | --- | --- | --- | --- | --- | --- | --- | --- | --- | --- | --- | --- | --- | --- |
| 108 | 2.2.2.5 | **Review and Validate Requirements** |  | 11d? | 2005-04-05 A | 2005-04-19 | 107 | 50% | 5.5d? | 2005-01-06 | 2005-01-06 | 1d? | -8d | 0d |  |  | 16h |
| 109 | 2.2.2.5.1 | Post draft guidelines/requirements for GIS Naming Convention and Directory Structure for inter team review |  | 3d? | 2005-04-05 A | 2005-04-07 A |  | 100% |  |  |  |  |  |  |  |  |  |
| 110 | 2.2.2.5.2 | Review of draft guidelines/Requirements for GIS Naming Convention and Directory Structure |  | 1d | 2005-04-15 | 2005-04-15 | 109 |  |  |  |  |  | -49d | 0d | finish no earlier than 2005-04-15 | GSTOP Team | 8h |
| 111 | 2.2.2.5.3 | Edit draft guidelines/Requirements based on team input |  | 1d | 2005-04-18 | 2005-04-18 | 110 |  |  |  |  |  | -49d | 0d |  | NamConvSubteam | 8h |
| 112 | 2.2.2.5.4 | Post draft guidelines/Requirements for external review |  | 1d? | 2005-04-19 | 2005-04-19 | 111 |  |  |  |  |  | -49d | 0d |  |  |  |
| 113 | 2.2.2.6 | Draft GIS Naming Convention/Directory Structure Requirements developed | milestone | 1d? | 2005-04-20 | 2005-04-20 | 108 |  |  |  |  |  | -49d | 0d |  |  |  |
| 114 | 2.2.3 | **Develop Draft GIS Standard Naming Convention SOPs** |  | 55d? | 2005-02-10 A | 2005-04-27 | 99 | 17% | 45.83d? |  |  |  | -33d | 0d |  |  |  |
| 115 | 2.2.3.1 | **Prepare Sample of Naming Conventions and Directory Structure** |  | 52d? | 2005-02-10 A | 2005-04-22 |  | 33% | 34.67d? |  |  |  | -33d | 0d |  |  |  |
| 116 | 2.2.3.1.1 | Prepare Naming conventions |  | 1d? | 2005-02-10 A | 2005-02-10 A |  | 100% |  |  |  |  |  |  |  |  |  |
| 117 | 2.2.3.1.2 | Develop Directory structure | milestone | 0d? | 2005-02-10 A | 2005-02-10 A |  | 100% |  |  |  |  |  |  |  |  |  |
| 118 | 2.2.3.1.3 | Prepare Methods of work |  | 1d? | 2005-04-21 | 2005-04-21 |  |  |  |  |  |  | -33d | 0d |  |  |  |
| 119 | 2.2.3.1.4 | Prepare draft SOPs for field review |  | 1d? | 2005-04-22 | 2005-04-22 | 116, 117, 118, 376 |  |  |  |  |  | -33d | 0d |  |  |  |
| 120 | 2.2.3.2 | **Sample Documents/draft SOPs Review and Validation** |  | 3d? | 2005-04-25 | 2005-04-27 | 115 |  |  |  |  |  | -33d | 0d |  |  |  |
| 121 | 2.2.3.2.1 | Post sample documents for inter team review |  | 1d? | 2005-04-25 | 2005-04-25 |  |  |  |  |  |  | -33d | 0d |  |  |  |
| 122 | 2.2.3.2.2 | Edit sample documents based on input |  | 1d? | 2005-04-26 | 2005-04-26 | 121 |  |  |  |  |  | -33d | 0d |  |  |  |
| 123 | 2.2.3.2.3 | Draft GIS Naming Convention/Directory Structure SOPs developed | milestone | 1d? | 2005-04-27 | 2005-04-27 | 122 |  |  |  |  |  | -33d | 0d |  |  |  |
| 124 | 2.2.4 | **Conduct External Review of GIS Naming Standard/Directory Structure SOP requirements and draft SOPs** |  | 12d? | 2005-04-28 | 2005-05-13 | 114 |  |  |  |  |  | -33d | 0d |  |  | 128h |
| 125 | 2.2.4.1 | Design External Review of guidelines/requirements for GIS Naming Standards and Directory Structure |  | 2d? | 2005-04-28 | 2005-04-29 | 112 |  |  |  |  |  | -28.5d | 0d |  | Emmor Nile | 16h |
| 126 | 2.2.4.2 | Post sample documents/SOPs for external review |  | 5d? | 2005-05-02 | 2005-05-06 | 125 |  |  | 2004-12-31 | 2005-01-17 | 12d? | -28.5d | 0d |  |  |  |
| 127 | 2.2.4.3 | Conduct External review of Guidelines/Requirements and draft SOPs |  | 0.5d? | 2005-05-09 | 2005-05-09 | 126 |  |  |  |  |  | -28.5d | 0d |  | GTG; Reviewers | 8h |
| 128 | 2.2.4.4 | Edit draft guidelines/Requirements based on input |  | 1d? | 2005-04-28 | 2005-04-28 |  |  |  |  |  |  | -22d | 0d |  | NamConvSubteam | 8h |
| 129 | 2.2.4.5 | Edit sample documents/SOPs based on input |  | 12d? | 2005-04-28 | 2005-05-13 |  |  |  | 2004-12-31 | 2005-01-05 | 4d? | -33d | 0d |  | NamConvSubteam | 96h |
| 130 | 2.2.5 | **Finalize recommendation of GIS Standard Naming Conventions** |  | 2d? | 2005-05-16 | 2005-05-17 | 124 |  |  | 2004-12-31 | 2004-12-31 | 1d? | -33d | 0d |  |  | 8h |
| 131 | 2.2.5.1 | Create a report recommending the adoption of the standard |  | 1d? | 2005-05-16 | 2005-05-16 |  |  |  | 2004-12-31 | 2004-12-31 | 1d? | -33d | 0d |  |  |  |
| 132 | 2.2.5.2 | Conduct a review of the report |  | 1d? | 2005-05-17 | 2005-05-17 | 131 |  |  | 2004-12-31 | 2004-12-31 | 1d? | -33d | 0d |  | NamConvSubteam | 8h |
| 133 | 2.2.5.3 | Submit the report to GSTOP-PM | milestone | 0d | 2005-05-17 | 2005-05-17 | 132 |  |  | 2004-12-31 | 2004-12-31 | 1d | -33d | 0d |  |  |  |

Notes:
- 116: Text1: doc on disaster help
- 117: Text1: doc on disaster help
- 125: Text1: Plan for external review of GIS Naming Standards/Directory Structure requirements
- 128: Text1: final requirements
- 129: Text1: final SOPs
- 131: Text1: Recommendation Report
- 132: Text1: Finalized Recommendation Report
- 133: Text1: Report Submission

| ID | WBS | Task | Type | Duration | Start | Finish | Predecessors | Complete | Remaining | Total slack | Free slack | Constraint | Resources | Work | Text1 |
| --- | --- | --- | --- | --- | --- | --- | --- | --- | --- | --- | --- | --- | --- | --- | --- |
| 134 | 2.3 | **Incident GIS Standard Product Definitions** |  | 65d? | 2005-02-09 A | 2005-05-11 |  |  | 65d? | -29d | 0d |  | Karen Folger | 704h |  |
| 135 | 2.3.1 | **Develop GIS Standard Product Definitions SOP Requirements** |  | 52d? | 2005-02-09 A | 2005-04-22 |  |  | 52d? | -16d | 0d |  |  | 160h |  |
| 136 | 2.3.1.1 | **Define criteria for the acceptance of standard products definitions** |  | 2d? | 2005-03-16 | 2005-03-17 |  |  |  | 10d |  |  |  |  | Acceptance Criteria Set |
| 137 | 2.3.1.1.1 | Develop acceptance criteria for std products definitions |  | 1d? | 2005-03-16 | 2005-03-16 |  |  |  | 10d | 0d |  |  |  |  |
| 138 | 2.3.1.1.2 | Conduct a final review of selection criteria |  | 1d? | 2005-03-17 | 2005-03-17 | 137 |  |  | 10d |  |  |  |  | Standard Products Acceptance Criteria |
| 139 | 2.3.1.2 | **Define/Collect Information** |  | 25d? | 2005-02-09 A | 2005-03-16 |  |  | 25d? | -11d | 0d |  |  |  |  |
| 140 | 2.3.1.2.1 | Develop Standard Products Matrix to compare many versions of standard products. (GIST Draft Taskbook/GIST Course Workbook/PNWCG Product Objectives) | milestone | 0d? | 2005-02-09 A | 2005-02-09 A |  | 100% |  |  |  |  |  |  | Matrix Spreadsheet |
| 141 | 2.3.1.2.2 | Acquire DPRO Standards and incorporate into above matrix. | milestone | 0d? | 2005-03-01 A | 2005-03-01 A |  | 100% |  |  |  |  |  |  | Updated Matrix |
| 142 | 2.3.1.2.3 | Victoria Smith definitions/PNWCG definitions/DPRO defs. Compile these into a list for group to review. Cite source. | milestone | 0d? | 2005-03-01 A | 2005-03-01 A |  | 100% |  |  |  |  |  |  | List of Std Prods (draft) |
| 143 | 2.3.1.2.4 | Post for review including samples |  | 1d? | 2005-03-16 | 2005-03-16 | 142 |  |  | -25d | 0d |  |  |  | List posted to FTP site |
| 144 | 2.3.1.2.5 | Collect examples of new kinds of standard products that aren't in any of the existing definitions |  | 1d? | 2005-02-10 A | 2005-02-10 |  |  | 1d? | -1d | 0d | start no earlier than 2005-02-10 |  |  | Provide on ftp site |
| 145 | 2.3.1.3 | **Conduct Analysis** |  | 27d? | 2005-03-17 | 2005-04-22 | 139 |  |  | -29d | 0d |  |  | 160h |  |
| 146 | 2.3.1.3.1 | Define the meaning of product definitions - what goes into them? |  | 1d? | 2005-03-17 | 2005-03-17 |  |  |  | -3d | 0d |  |  |  |  |
| 147 | 2.3.1.3.2 | Create a draft template of what a product definition is |  | 1d? | 2005-03-23 | 2005-03-23 |  |  |  | -29d | 0d | finish no earlier than 2005-03-23 |  |  | Product Definition Template (draft) |
| 148 | 2.3.1.3.3 | Review existing standards definitions (Victoria/PNWCG/DPRO) & Identify discrepancies between groups defining standard |  | 10d | 2005-03-24 | 2005-04-06 | 147 |  |  | -29d | 0d |  |  |  | Discrepancy list |
| 149 | 2.3.1.3.4 | Highlight specific reasons for discrepancies (Fire Use vs. Type 1) if needed |  | 1d? | 2005-03-24 | 2005-03-24 | 147 |  |  | -20d | 0d |  |  |  |  |
| 150 | 2.3.1.3.5 | Bring these to the larger group for discussion and resolution |  | 10d | 2005-04-07 | 2005-04-20 | 149, 148, 147 |  |  | -29d | 0d |  | GSTOP Team; GTG | 160h |  |
| 151 | 2.3.1.3.6 | Gather responses from GSTOP and GTG; incorporte feedback |  | 1d? | 2005-04-21 | 2005-04-21 | 150 |  |  | -29d | 0d |  |  |  |  |
| 152 | 2.3.1.3.7 | Send out to wider folks for review (Field Test) |  | 1d? | 2005-04-22 | 2005-04-22 | 151 |  |  | -29d | 0d |  |  |  |  |
| 153 | 2.3.2 | **Develop draft GIS Standard Product Definition SOPs** |  | 1d? | 2005-04-25 | 2005-04-25 | 145 |  |  | -29d | 0d |  |  |  | Preliminary Package of Standard Products Definitions |
| 154 | 2.3.2.1 | Provide a package of draft products definitions and samples for review |  | 1d? | 2005-04-25 | 2005-04-25 |  |  |  | -29d | 0d |  |  |  | Preliminary package |
| 155 | 2.3.2.2 | Evaluate std products against acceptance criteria |  | 1d? | 2005-04-25 | 2005-04-25 |  |  |  | -29d | 0d |  |  |  |  |
| 156 | 2.3.2.3 | Provide data location and review process to internal group |  | 1d? | 2005-04-25 | 2005-04-25 |  |  |  | -29d | 0d |  |  |  | Submission report |
| 157 | 2.3.2.4 | Prepare draft SOPs for review |  | 1d? | 2005-04-25 | 2005-04-25 | 376 |  |  | -29d | 0d |  |  |  |  |

| ID | WBS | Task | Type | Duration | Start | Finish | Predecessors | Complete | Remaining | Baseline start | Baseline finish | Baseline duration | Total slack | Free slack | Resources | Work | Actual work |
| --- | --- | --- | --- | --- | --- | --- | --- | --- | --- | --- | --- | --- | --- | --- | --- | --- | --- |
| 158 | 2.3.3 | **Conduct External Review of draft GIS Standard Product Definition SOPs** |  | 10d? | 2005-04-26 | 2005-05-09 | 153 |  |  |  |  |  | -29d | 0d |  | 16h |  |
| 159 | 2.3.3.1 | **Conduct outside peer review of the draft standard products definitions** |  | 4d? | 2005-04-26 | 2005-04-29 |  |  |  |  |  |  | -29d | 0d |  | 8h |  |
| 160 | 2.3.3.1.1 | Submit the draft standard symbols to the 5 federal fire management agencies and State agencies via the NWCG Geospatial Task Group (GTG); and to the DHS (FEMA), FAA, DOD, and GSTOP Team for peer review |  | 1d? | 2005-04-26 | 2005-04-26 |  |  |  |  |  |  | -29d | 0d | GTG | 8h |  |
| 161 | 2.3.3.1.2 | Review feedback of initial peer review |  | 1d? | 2005-04-27 | 2005-04-27 | 160 |  |  |  |  |  | -29d | 0d |  |  |  |
| 162 | 2.3.3.1.3 | Identify required changes to draft standard products based on the initial peer review feedback |  | 1d? | 2005-04-28 | 2005-04-28 | 161 |  |  |  |  |  | -29d | 0d |  |  |  |
| 163 | 2.3.3.1.4 | Make required changes, as identified, to draft standard products |  | 1d? | 2005-04-29 | 2005-04-29 | 162 |  |  |  |  |  | -29d | 0d |  |  |  |
| 164 | 2.3.3.2 | **Conduct final peer review of the draft standard products** |  | 6d? | 2005-05-02 | 2005-05-09 | 159 |  |  |  |  |  | -29d | 0d |  | 8h |  |
| 165 | 2.3.3.2.1 | Prepare draft standard products for final peer review |  | 1d? | 2005-05-02 | 2005-05-02 |  |  |  |  |  |  | -29d | 0d |  |  |  |
| 166 | 2.3.3.2.2 | Submit the draft standard products to the 5 federal fire management agencies and State agencies via the NWCG Geospatial Task Group (GTG); and to the HSA (FEMA), FAA, DOD, and GSTOP Team for peer review |  | 1d? | 2005-05-03 | 2005-05-03 | 165 |  |  |  |  |  | -29d | 0d | GTG | 8h |  |
| 167 | 2.3.3.2.3 | Review feedback of the final peer review |  | 1d? | 2005-05-04 | 2005-05-04 | 166 |  |  |  |  |  | -29d | 0d |  |  |  |
| 168 | 2.3.3.2.4 | Identify required changes to draft standard products based on the final peer review feedback |  | 1d? | 2005-05-05 | 2005-05-05 | 167 |  |  |  |  |  | -29d | 0d |  |  |  |
| 169 | 2.3.3.2.5 | Make required changes, as identified, to draft standard products |  | 1d? | 2005-05-06 | 2005-05-06 | 168 |  |  |  |  |  | -29d | 0d |  |  |  |
| 170 | 2.3.3.2.6 | Ratify the final draft standard symbols |  | 1d? | 2005-05-09 | 2005-05-09 | 169 |  |  |  |  |  | -29d | 0d |  |  |  |
| 171 | 2.3.4 | **Finalize recommendation of standard Fire Mapping products** |  | 2d? | 2005-05-10 | 2005-05-11 | 164 |  |  |  |  |  | -29d | 0d |  | 8h |  |
| 172 | 2.3.4.1 | Create a report recommending the adoption of the draft standard product definitions |  | 1d? | 2005-05-10 | 2005-05-10 |  |  |  |  |  |  | -29d | 0d |  |  |  |
| 173 | 2.3.4.2 | Conduct a review of the report for completeness, accuracy, language, and grammar |  | 1d? | 2005-05-11 | 2005-05-11 | 172 |  |  |  |  |  | -29d | 0d | StdProd Subteam | 8h |  |
| 174 | 2.3.4.3 | Submit the report to GSTOP-PM | milestone | 0d | 2005-05-11 | 2005-05-11 | 173 |  |  |  |  |  | -29d | 0d |  |  |  |
| 175 | 2.3.4.4 | Find a permanent storage location for this package? National clearinghouse? |  | 1d? | 2005-05-10 | 2005-05-10 |  |  |  |  |  |  | -28d | 0d |  |  |  |
| 176 | 2.4 | **Incident GIST Minimum Qualifications & GIS Expectations** |  | 28.5d? | 2005-03-16 A | 2005-04-25 |  | 17% | 23.54d? | 2004-12-31 | 2005-01-06 | 5d? | -16.5d | 0d | Victoria Smith | 484h | 183.65h |
| 177 | 2.4.1 | **Develop Requirements for determining the GIST Minimum Qualifications & GIS Expectations** |  | 6.5d? | 2005-03-16 A | 2005-03-24 |  | 48% | 3.38d? |  |  |  | -0.5d | 0d |  | 176h | 144h |
| 178 | 2.4.1.1 | **Establish evaluation methods for minimum GIST qualifications/GIS expectations** |  | 1d? | 2005-03-16 | 2005-03-16 |  |  |  |  |  |  | -11d | 0d |  |  |  |
| 179 | 2.4.1.1.1 | Define method for evaluating minimum GIST qualifications/GIS expectations |  | 1d? | 2005-03-16 | 2005-03-16 |  |  |  |  |  |  | -11d | 0d |  |  |  |
| 180 | 2.4.1.1.2 | Conduct a final review of evaluation methods |  | 1d? | 2005-03-16 | 2005-03-16 |  |  |  |  |  |  | -11d | 0d |  |  |  |
| 181 | 2.4.1.2 | **Define criteria for the acceptance of minimum GIST qualifications/GIS expectations** |  | 1d? | 2005-03-16 | 2005-03-16 |  |  |  |  |  |  | -11d | 0d |  |  |  |
| 182 | 2.4.1.2.1 | Develop acceptance criteria for minimum GIST qualifications/GIS expectations |  | 1d? | 2005-03-16 | 2005-03-16 |  |  |  |  |  |  | -11d | 0d |  |  |  |
| 183 | 2.4.1.2.2 | Conduct a final review of selection criteria |  | 1d? | 2005-03-16 | 2005-03-16 |  |  |  |  |  |  | -11d | 0d |  |  |  |

Notes:
- 160: Text1: Submission Report
- 161: Text1: Initial Peer Review Document
- 162: Text1: List of required changes
- 163: Text1: Initial updated Products Definitions
- 165: Text1: Final Peer Review Package
- 166: Text1: Submission Report
- 167: Text1: Final Peer Review Document
- 168: Text1: List of required changes
- 169: Text1: final updated products list
- 170: Text1: Final Draft Standard Productss List
- 172: Text1: Recommendation Report
- 173: Text1: Finalized Recommendation Report
- 174: Text1: Report Submission
- 178: Text1: Evaluation Methodology for Minimum GIST Qualifications/GIS Expectations
- 181: Text1: Acceptance Criteria Set

| ID | WBS | Task | Duration | Start | Finish | Predecessors | Complete | Remaining | Total slack | Free slack | Resources | Work | Actual work |
| --- | --- | --- | --- | --- | --- | --- | --- | --- | --- | --- | --- | --- | --- |
| 184 | 2.4.1.3 | **Collect Information on minimum GIST qualifications and minimum GIS expectations on an incident** | 6.5d? | 2005-03-16 A | 2005-03-24 |  | 71% | 1.91d? | -0.5d | 0d |  | 176h | 144h |
| 185 | 2.4.1.3.1 | Gather documents and references (including white papers, memos, After Action Reviews, agency guidelines) | 6d? | 2005-03-16 A | 2005-03-23 A |  | 100% |  |  |  | GTAG; Firescope; NWCG Member Agencies | 144h | 144h |
| 186 | 2.4.1.3.2 | Obtain and review revised Taskbook | 0.5d? | 2005-03-24 | 2005-03-24 | 185 |  |  | -16.5d | 0d | John Guthrie; Victoria Smith | 8h |  |
| 187 | 2.4.1.3.3 | Scan or translate paper documents to electronic format | 1d? | 2005-03-16 | 2005-03-16 |  |  |  | -11d | 0d |  |  |  |
| 188 | 2.4.1.3.4 | Research current GIST/GIS standards | 1d? | 2005-03-16 | 2005-03-16 |  |  |  | -11d | 0d | FEMA; GACC guidelines; NWCG Agency | 24h |  |
| 189 | 2.4.2 | **Develop draft of GIST Minimum Qualifications & Expecations** | 12d? | 2005-03-24 | 2005-04-11 | 177 |  |  | -16.5d | 0d |  | 8h |  |
| 190 | 2.4.2.1 | **Develop a list of GIST qualifications to be evaluated for acceptance as draft minimum standards** | 3d? | 2005-03-24 | 2005-03-29 | 184 |  |  | -16.5d | 0d |  | 8h |  |
| 191 | 2.4.2.1.1 | Compare the current GIST standards | 1d? | 2005-03-24 | 2005-03-25 |  |  |  | -16.5d | 0d | Elise Browne | 8h |  |
| 192 | 2.4.2.1.2 | Compile the GIST qualifications into a single list of potential minimum GIST qualifications | 1d? | 2005-03-25 | 2005-03-28 | 191 |  |  | -16.5d | 0d |  |  |  |
| 193 | 2.4.2.1.3 | Compile a list of GIST qualifications which are deemed to be beyond the minimum for future reference | 1d? | 2005-03-28 | 2005-03-29 | 192 |  |  | -16.5d | 0d |  |  |  |
| 194 | 2.4.2.2 | **Determine the draft standard minimum GIST qualifications** | 3d? | 2005-03-29 | 2005-04-01 | 190 |  |  | -16.5d | 0d |  |  |  |
| 195 | 2.4.2.2.1 | Evaluate each potential minimum GIST qualification using the approved evaluation methods | 1d? | 2005-03-29 | 2005-03-30 | 178 |  |  | -16.5d | 0d |  |  |  |
| 196 | 2.4.2.2.2 | Select the minimum GIST qualifications | 1d? | 2005-03-30 | 2005-03-31 | 195 |  |  | -16.5d | 0d |  |  |  |
| 197 | 2.4.2.2.3 | Conduct a completeness review of the draft minimum GIST qualifications | 1d? | 2005-03-31 | 2005-04-01 | 196 |  |  | -16.5d | 0d |  |  |  |
| 198 | 2.4.2.3 | **Conduct internal review of draft standard minimum GIST qualifications & GIS expectations** | 6d? | 2005-04-01 | 2005-04-11 | 194 |  |  | -16.5d | 0d |  |  |  |
| 199 | 2.4.2.3.1 | Prepare draft standard minimum GIST qualifications and GIS expectations, including acceptance criteria | 1d? | 2005-04-01 | 2005-04-04 |  |  |  | -16.5d | 0d |  |  |  |
| 200 | 2.4.2.3.2 | Post draft standard to DisasterHelp website and notify GSTOP team for group review | 1d? | 2005-04-04 | 2005-04-05 | 199 |  |  | -16.5d | 0d |  |  |  |
| 201 | 2.4.2.3.3 | Provide data location and review process to internal group | 1d? | 2005-04-05 | 2005-04-06 | 200 |  |  | -16.5d | 0d |  |  |  |
| 202 | 2.4.2.3.4 | Review feedback of initial peer review | 1d? | 2005-04-06 | 2005-04-07 | 201 |  |  | -16.5d | 0d |  |  |  |
| 203 | 2.4.2.3.5 | Identify required changes to draft standard based on the initial peer review feedback | 1d? | 2005-04-07 | 2005-04-08 | 202 |  |  | -16.5d | 0d |  |  |  |
| 204 | 2.4.2.3.6 | Make required changes, as identified, to draft standard | 1d? | 2005-04-08 | 2005-04-11 | 203 |  |  | -16.5d | 0d |  |  |  |
| 205 | 2.4.3 | **Conduct final peer review of the draft standard minimum GIST qualifications & GIS expectations** | 7d? | 2005-04-11 | 2005-04-20 | 189 |  |  | -16.5d | 0d | GIST Qual/GIS Min Expec Subteam | 72h |  |
| 206 | 2.4.3.1 | Prepare survey or questionnaire to accompany draft standards for final peer review. | 1d? | 2005-04-11 | 2005-04-12 |  |  |  | -16.5d | 0d |  |  |  |
| 207 | 2.4.3.2 | Prepare draft standard minimum GIST Qualification/GIST expectations for final peer review, including the survey of results | 1d? | 2005-04-12 | 2005-04-13 | 206 |  |  | -16.5d | 0d |  |  |  |
| 208 | 2.4.3.3 | Submit the draft expectations to the 5 federal fire management agencies and State agencies via the NWCG Geospatial Task Group (GTG); and to the HSA (FEMA), FAA, DOD, and GSTOP Team for peer review. | 1d? | 2005-04-13 | 2005-04-14 | 207 |  |  | -16.5d | 0d | GTG | 8h |  |
| 209 | 2.4.3.4 | Review feedback of the final peer review, including survey of results | 1d? | 2005-04-14 | 2005-04-15 | 208 |  |  | -16.5d | 0d |  |  |  |
| 210 | 2.4.3.5 | Identify required changes to draft standard minimum GIST qualifications/GIS expectations based on the final peer review feedback | 1d? | 2005-04-15 | 2005-04-18 | 209 |  |  | -16.5d | 0d |  |  |  |
| 211 | 2.4.3.6 | Make required changes, as identified, to draft minimum GIST qualifications/GIS expectations symbols | 1d? | 2005-04-18 | 2005-04-19 | 210 |  |  | -16.5d | 0d |  |  |  |
| 212 | 2.4.3.7 | Ratify the final draft standard minimum GIST qualifications/GIS expectations | 1d? | 2005-04-19 | 2005-04-20 | 211 |  |  | -16.5d | 0d | GIST Qual/GIS Min Expec Subteam | 8h |  |

Notes:
- 185: Text1: electronic format of original documents in folder on DisasterHelp site
- 187: using books, media (including internet and magazines) / Text1: electronic documents with quotes and bibliographic references
- 188: Text1: electronic format of original documents
- 191: Text1: matrix of similarities
- 192: Text1: list of minimum GIST qualifications for evaluation
- 193: Text1: list of other GIST qualifications (wish list)
- 194: Text1: Draft of minimum GIST qualifications standard
- 195: Text1: GIST qualifications evaluation document
- 196: Text1: Draft list of minimum GIST qualifications
- 197: Text1: Draft standard of the minimum GIST qualifications
- 199: Text1: Initial peer review package
- 200: Text1: Location posted, review team notified
- 201: Text1: Review report
- 202: Text1: Initial peer review document
- 203: Text1: List of required changes
- 204: Text1: Initial updated draft standard minimum GIST qualifications and GIS expectations
- 206: Text1: Final Peer Review Survey
- 207: Text1: Final Peer Review Package
- 208: Text1: Submission Report
- 209: Text1: Final Peer Review Document
- 210: Text1: List of required changes
- 211: Text1: final updated list of minimum GIST qualifications and GIS expectations
- 212: Text1: Final Draft Standard Minimum GIST Qualifications/GIS Expectations

| ID | WBS | Task | Duration | Start | Finish | Predecessors | Complete | Remaining | Baseline start | Baseline finish | Baseline duration | Total slack | Free slack | Constraint | Resources | Work | Actual work | Text1 |
| --- | --- | --- | --- | --- | --- | --- | --- | --- | --- | --- | --- | --- | --- | --- | --- | --- | --- | --- |
| 213 | 2.4.4 | **Finalize recommendation for standard Minimum GIST Qualifications & GIS Expectations on an Incident** | 3d? | 2005-04-20 | 2005-04-25 | 205 |  |  |  |  |  | -16.5d | 0d |  |  |  |  |  |
| 214 | 2.4.4.1 | Create a report recommending the adoption of the draft minimum GIST Qualifications/GIS Expectations | 1d? | 2005-04-20 | 2005-04-21 |  |  |  |  |  |  | -16.5d | 0d |  |  |  |  | Recommendation Report |
| 215 | 2.4.4.2 | Conduct a review of the report for completeness, accuracy, language, and grammar | 1d? | 2005-04-21 | 2005-04-22 | 214 |  |  |  |  |  | -16.5d | 0d |  |  |  |  | Finalized Recommendation Report |
| 216 | 2.4.4.3 | Submit the report to GSTOP-PM | 1d? | 2005-04-22 | 2005-04-25 | 215 |  |  |  |  |  | -16.5d | 0d |  |  |  |  | Report Submission |
| 217 | 2.5 | **Incident GIS Minimum Essential Datasets** | 53d? | 2005-02-10 A | 2005-04-25 |  | 4% | 51.09d? | 2004-12-31 | 2005-01-06 | 5d? | -12d | 0d |  | John Guthrie | 912h | 15.28h |  |
| 218 | 2.5.1 | **Establish MED Sub-Team business practices** | 25d? | 2005-02-10 A | 2005-03-16 |  |  | 25d? |  |  |  | 11d |  |  |  |  |  |  |
| 219 | 2.5.1.1 | **Develop a MED Sub-team Communication Plan** | 25d? | 2005-02-10 A | 2005-03-16 |  |  | 25d? | 2004-12-31 | 2005-01-18 | 13d? | 11d |  |  |  |  |  | Communication Plan Document |
| 220 | 2.5.1.1.1 | Define ground-rules for Sub-Team (internal) communication | 1d? | 2005-03-16 | 2005-03-16 |  |  |  | 2004-12-31 | 2005-01-10 | 7d? | 11d |  |  |  |  |  | Write Up |
| 221 | 2.5.1.1.2 | Define ground-rules for communication between the MED Sub-Team and other GSTOP Sub-Teams | 1d? | 2005-02-10 A | 2005-02-10 |  |  | 1d? | 2004-12-31 | 2004-12-31 | 1d? | 35d |  |  |  |  |  | Write Up |
| 222 | 2.5.1.1.3 | Define ground rules for communication between the Sub-Team and entities outside of the GSTOP Project | 1d? | 2005-02-10 A | 2005-02-10 |  |  | 1d? | 2005-01-03 | 2005-01-03 | 1d? | 35d |  |  |  |  |  | Write Up |
| 223 | 2.5.1.1.4 | Establish a process and schedule for Sub-Team (internal) progress report updates | 1d? | 2005-02-10 A | 2005-02-10 |  |  | 1d? | 2005-01-04 | 2005-01-04 | 1d? | 35d |  |  |  |  |  | Write Up |
| 224 | 2.5.1.1.5 | Establish a process and schedule for Sub-Team progress report updates to the GSTOP Team | 1d? | 2005-02-10 A | 2005-02-10 |  |  | 1d? | 2005-01-05 | 2005-01-05 | 1d? | 35d |  |  |  |  |  | Write Up |
| 225 | 2.5.1.2 | **Establish Review Processes** | 25d? | 2005-02-10 A | 2005-03-16 |  |  | 25d? | 2005-01-06 | 2005-01-06 | 1d? | 11d |  |  |  |  |  | Review Process Document |
| 226 | 2.5.1.2.1 | Establish a process for Sub-Team (internal) review of potential MEDs | 1d? | 2005-02-10 A | 2005-02-10 |  |  | 1d? | 2005-01-07 | 2005-01-07 | 1d? | -1d | 0d |  |  |  |  | Write Up |
| 227 | 2.5.1.2.2 | Establish a process for Sub-Team (internal) review of the draft standard MEDs | 1d? | 2005-02-10 A | 2005-02-10 | 226 |  | 1d? | 2005-01-10 | 2005-01-10 | 1d? | 34d | 23d |  |  |  |  | Write Up |
| 228 | 2.5.1.2.3 | Establish a process for peer reviews | 1d? | 2005-03-16 | 2005-03-16 | 227 |  |  | 2005-01-11 | 2005-01-12 | 2d? | 11d |  |  |  |  |  | Write Up |
| 229 | 2.5.1.2.4 | Establish a process for periodic GSTOP Team reviews | 1d? | 2005-03-01 A | 2005-03-01 |  |  | 1d? | 2005-01-11 | 2005-01-11 | 1d? | -1d | 0d |  |  |  |  | Write Up |
| 230 | 2.5.1.2.5 | Establish a process for reviewing the final report | 1d? | 2005-03-01 A | 2005-03-01 | 229 |  | 1d? | 2005-01-12 | 2005-01-12 | 1d? | -1d | 0d |  |  |  |  | Write Up |
| 231 | 2.5.1.3 | **Establish Change processes** | 12d? | 2005-03-01 A | 2005-03-16 | 230 |  | 12d? | 2005-01-13 | 2005-01-14 | 2d? | 11d |  |  |  |  |  | Change Process Document |
| 232 | 2.5.1.3.1 | Establish a process for additions/deletions of potential MEDs mid-stream through the Project | 1d? | 2005-03-01 A | 2005-03-01 |  |  | 1d? | 2005-01-13 | 2005-01-13 | 1d? | -1d | 0d |  |  |  |  | Write Up |
| 233 | 2.5.1.3.2 | Establish a change process for the additions/deletion of standard MEDs after the final recommendation has been submitted | 1d? | 2005-03-01 A | 2005-03-01 | 232 |  | 1d? | 2005-01-14 | 2005-01-14 | 1d? | 21d | 10d |  |  |  |  | Write Up |
| 234 | 2.5.1.3.3 | Establish a change process for the additions/deletion of standard MEDs after the final recommendation has been approved through the GSTOP Team | 1d? | 2005-03-16 | 2005-03-16 | 233 |  |  | 2005-01-17 | 2005-01-17 | 1d? | 11d |  |  |  |  |  | Write Up |
| 235 | 2.5.2 | **Develop requirements for GIS Minimum Essential Datasets SOPs** | 29d? | 2005-03-01 A | 2005-04-08 |  | 5% | 27.55d? |  |  |  | -1d | 0d |  |  | 352h |  |  |
| 236 | 2.5.2.1 | **Establish MED evaluation methods** | 18d? | 2005-03-16 A | 2005-04-08 |  | 14% | 15.52d? |  |  |  | -1d | 0d |  | MED Subteam | 152h |  | Evaluation Methodology Document |
| 237 | 2.5.2.1.1 | **Define High level criteria for the acceptance of MEDs as standards** | 17d? | 2005-03-17 A | 2005-04-08 |  |  | 17d? |  |  |  | -1d | 0d |  |  |  |  | Acceptance Criteria Document |
| 238 | 2.5.2.1.1.1 | Determine incident tasks and required deliverables | 1d? | 2005-03-17 A | 2005-03-17 |  |  | 1d? |  |  |  | -1d | 0d |  |  |  |  | Deliverables spreadsheet |
| 239 | 2.5.2.1.1.2 | Determine data availability criteria | 3d | 2005-04-05 A | 2005-04-07 |  |  | 3d |  |  |  | -17d | 0d |  |  |  |  | Data Availability Criteria |
| 240 | 2.5.2.1.1.3 | Develop accuracy standards for databases | 1d? | 2005-04-08 | 2005-04-08 | 239 |  |  |  |  |  | -17d | 0d |  |  |  |  | Accuracy Standards statement |
| 241 | 2.5.2.1.2 | Define method for evaluating MEDs | 13d? | 2005-03-18 A | 2005-04-05 |  |  | 13d? | 2004-12-31 | 2005-01-03 | 2d? | -14d | 0d |  |  |  |  | MED Evaluation Method |
| 242 | 2.5.2.1.3 | Develop acceptance criteria for raster MEDs | 1d? | 2005-03-16 | 2005-03-16 |  |  |  |  |  |  | 0d |  |  |  |  |  | Writeup |
| 243 | 2.5.2.1.4 | Post draft Acceptance Critera for GSTOP Team review | 4d? | 2005-03-18 A | 2005-03-23 A |  | 100% |  |  |  |  |  |  |  |  |  |  |  |
| 244 | 2.5.2.1.5 | Review draft Acceptance Criteria | 1d? | 2005-03-28 | 2005-03-28 | 243 |  |  |  |  |  | -13d | 0d | finish no earlier than 2005-03-28 | GSTOP Team | 8h |  | GSTOP Team feedback |
| 245 | 2.5.2.1.6 | Update Acceptance Criteria for GSTOP Team input | 4d | 2005-03-29 | 2005-04-01 | 244 |  |  |  |  |  | -13d | 0d |  |  |  |  |  |
| 246 | 2.5.2.1.7 | Conduct a final review of selection criteria | 1d? | 2005-04-04 | 2005-04-04 | 245 |  |  | 2004-12-31 | 2004-12-31 | 1d? | -13d | 0d |  |  |  |  | MED Selection Criteria |

| ID | WBS | Task | Type | Duration | Start | Finish | Predecessors | Remaining | Baseline start | Baseline finish | Baseline duration | Total slack | Free slack | Constraint | Resources | Work | Text1 |
| --- | --- | --- | --- | --- | --- | --- | --- | --- | --- | --- | --- | --- | --- | --- | --- | --- | --- |
| 247 | 2.5.2.2 | **Develop a list of MEDs to be evaluated for acceptance as draft standards** |  | 25d? | 2005-03-01 A | 2005-04-04 |  | 25d? | 2004-12-31 | 2004-12-31 | 1d? | -1d | 0d |  | MED Subteam | 200h |  |
| 248 | 2.5.2.2.1 | Determine what datasets are required for each deliverable |  | 24d | 2005-03-01 A | 2005-04-01 |  | 24d |  |  |  | -12d | 0d | start no earlier than 2005-03-01 |  |  | Deliverables Spreadsheet (revised) |
| 249 | 2.5.2.2.2 | Collect Standard Product Definition from GSTOP subteam to evaluate for potential MEDs |  | 24d? | 2005-03-01 A | 2005-04-01 |  | 24d? | 2004-12-31 | 2004-12-31 | 1d? | 0d |  | finish no earlier than 2005-04-01 |  |  | Table of data needed for maps |
| 250 | 2.5.2.2.3 | Document potential sources for additional fire mapping MEDs |  | 1d? | 2005-04-04 | 2005-04-04 | 249 |  | 2004-12-31 | 2004-12-31 | 1d? | -13d | 0d |  |  |  | List of data sources |
| 251 | 2.5.2.2.4 | Compile MEDs into a single potential MED set |  | 1d? | 2005-04-04 | 2005-04-04 | 249 |  | 2005-01-03 | 2005-01-03 | 1d? | -13d | 0d |  |  |  | Set of potential standard MEDs |
| 252 | 2.5.2.2.5 | Define methods a GIST should yuse to determine if dataset meets Accuracy Standards |  | 1d? | 2005-03-16 | 2005-03-16 |  |  |  |  |  | 0d |  |  |  |  | Dataset Evaluation Process Document |
| 253 | 2.5.3 | **Develop draft SOPs for GIS Minimum Essential Datasets** |  | 9d? | 2005-04-11 | 2005-04-21 | 235 |  |  |  |  | -17d | 0d |  |  | 72h |  |
| 254 | 2.5.3.1 | **Determine the draft standard Raster MEDs** |  | 3d? | 2005-04-11 | 2005-04-13 | 247 |  | 2004-12-31 | 2004-12-31 | 1d? | -17d | 0d |  | MED Subteam | 24h |  |
| 255 | 2.5.3.1.1 | Evaluate each potential marker MED against the MED selection criteria |  | 1d? | 2005-04-11 | 2005-04-11 |  |  | 2004-12-31 | 2004-12-31 | 1d? | -17d | 0d |  |  |  | MED Evaluation Document |
| 256 | 2.5.3.1.2 | Sub-Team selection of the draft standards for MEDs vs. extended MED list |  | 1d? | 2005-04-12 | 2005-04-12 | 255 |  | 2004-12-31 | 2004-12-31 | 1d? | -17d | 0d |  |  |  | Draft list of selected MEDs |
| 257 | 2.5.3.1.3 | Conduct a Sub-team completeness review of the draft standard MEDs |  | 1d? | 2005-04-13 | 2005-04-13 | 256 |  | 2004-12-31 | 2004-12-31 | 1d? | -17d | 0d |  |  |  | Draft Standard MEDs Document |
| 258 | 2.5.3.2 | **Conduct a Sub-team completeness review of the draft standard and extended MEDs** |  | 5d? | 2005-04-14 | 2005-04-20 | 254 |  | 2004-12-31 | 2004-12-31 | 1d? | -17d | 0d |  | BLM publication shop | 48h | Draft Standard Fill MEDs Document |
| 259 | 2.5.3.2.1 | Prepare draft standard MEDs for initial peer review |  | 1d? | 2005-04-14 | 2005-04-14 |  |  | 2004-12-31 | 2004-12-31 | 1d? | -17d | 0d |  |  |  | Initial Peer Review Package |
| 260 | 2.5.3.2.2 | Submit the draft standard MEDs to the 5 federal fire management agencies, State agencies, and USGS via the NWCG Geospatial Task Group (GTG); and to DHS (FEMA), FAA, DOD, and GSTOP Team for peer review | milestone | 0d | 2005-04-14 | 2005-04-14 | 259 |  | 2004-12-31 | 2004-12-31 | 0d | -17d | 0d |  |  |  | Submission Report |
| 261 | 2.5.3.2.3 | Conduct initial peer review of the draft standard and extended MEDs |  | 1d? | 2005-04-15 | 2005-04-15 | 260 |  | 2004-12-31 | 2004-12-31 | 1d? | -17d | 0d |  | GSTOP Team | 8h |  |
| 262 | 2.5.3.2.4 | Review feedback of initial peer review |  | 1d? | 2005-04-18 | 2005-04-18 | 261 |  | 2004-12-31 | 2004-12-31 | 1d? | -17d | 0d |  |  |  | Initial Peer Review Document |
| 263 | 2.5.3.2.5 | Identify required changes to draft standard MEDs based on the initial peer review feedback |  | 1d? | 2005-04-19 | 2005-04-19 | 262 |  | 2005-01-18 | 2005-01-19 | 1d? | -17d | 0d |  |  |  | List of required MED changes |
| 264 | 2.5.3.2.6 | Make required changes, as identified, to draft standard MEDs |  | 1d? | 2005-04-20 | 2005-04-20 | 263 |  | 2005-01-19 | 2005-01-19 | 1d? | -17d | 0d |  |  |  | Initial updated MEDs list |
| 265 | 2.5.3.3 | Prepare draft SOPs for field test |  | 1d? | 2005-04-21 | 2005-04-21 | 258 |  |  |  |  | -17d | 0d |  |  |  |  |
| 266 | 2.5.4 | **Conduct final peer review of the draft standard marker, line, and fill MEDs** |  | 1d? | 2005-04-22 | 2005-04-22 | 253 |  | 2005-01-19 | 2005-01-19 | 1d? | -17d | 0d |  | NWCG Training Team | 56h |  |
| 267 | 2.5.4.1 | Prepare draft standard MEDs for final peer review |  | 1d? | 2005-04-22 | 2005-04-22 |  |  | 2005-01-19 | 2005-01-19 | 1d? | -17d | 0d |  | Victoria Smith; Deb Epps | 16h | Final Peer Review Package |
| 268 | 2.5.4.2 | Submit the draft standard MEDs to the 5 federal fire management agencies and State agencies via the NWCG Geospatial Task Group (GTG); and to the HSA (FEMA), FAA, DOD, and GSTOP Team for peer review |  | 1d? | 2005-04-22 | 2005-04-22 |  |  | 2005-01-19 | 2005-01-19 | 1d? | -17d | 0d |  | GSTOP Subteam(s) | 8h | Submission Report |
| 269 | 2.5.4.3 | Review feedback of the final peer review |  | 1d? | 2005-04-22 | 2005-04-22 |  |  | 2005-01-19 | 2005-01-19 | 1d? | -17d | 0d |  | GSTOP Subteam(s) | 8h | Final Peer Review Document |
| 270 | 2.5.4.4 | Identify required changes to draft standard MEDs based on the final peer review feedback |  | 1d? | 2005-04-22 | 2005-04-22 |  |  | 2005-01-19 | 2005-01-19 | 1d? | -17d | 0d |  | GSTOP Subteam(s) | 8h | List of required MED changes |
| 271 | 2.5.4.5 | Make required changes, as identified, to draft standard MEDs |  | 1d? | 2005-04-22 | 2005-04-22 |  |  | 2005-01-19 | 2005-01-19 | 1d? | -17d | 0d |  | GSTOP Subteam(s) | 8h | final updated MEDs list |
| 272 | 2.5.4.6 | Ratification of the final draft standard MEDs by the Sub-Team |  | 1d? | 2005-04-22 | 2005-04-22 |  |  | 2005-01-19 | 2005-01-19 | 1d? | -17d | 0d |  |  |  | Final Draft Standard MEDs List |

| ID | WBS | Task | Type | Duration | Start | Finish | Predecessors | Complete | Remaining | Baseline start | Baseline finish | Baseline duration | Total slack | Free slack | Constraint | Resources | Work | Actual work |
| --- | --- | --- | --- | --- | --- | --- | --- | --- | --- | --- | --- | --- | --- | --- | --- | --- | --- | --- |
| 273 | 2.5.5 | **Finalize recommendation of standard Fire Mapping MEDs** |  | 1d? | 2005-04-25 | 2005-04-25 | 266 |  |  | 2005-01-19 | 2005-01-19 | 1d? | -17d | 0d |  |  | 8h |  |
| 274 | 2.5.5.1 | Create a report recommending the adoption of the draft standard MEDs |  | 1d? | 2005-04-25 | 2005-04-25 |  |  |  | 2005-01-19 | 2005-01-19 | 1d? | -17d | 0d |  | GSTOP Team | 8h |  |
| 275 | 2.5.5.2 | Conduct a Sub-Team review of the report |  | 1d? | 2005-04-25 | 2005-04-25 |  |  |  | 2005-01-19 | 2005-01-19 | 1d? | -17d | 0d |  |  |  |  |
| 276 | 2.5.5.3 | Submit the report to GSTOP-PM |  | 1d? | 2005-04-25 | 2005-04-25 |  |  |  | 2005-01-19 | 2005-01-19 | 1d? | -17d | 0d |  |  |  |  |
| 277 | 2.6 | **Incident GIS Standard Data Sharing and Archiving Standards** |  | 8.42d? | 2005-03-16 | 2005-03-28 |  |  |  |  |  |  | 3.58d |  |  | Sean Triplett | 163.33h |  |
| 278 | 2.6.1 | **Develop requirements for GIS Standard Data Sharing and Archiving Standards SOPs** |  | 4.42d? | 2005-03-16 | 2005-03-22 |  |  |  |  |  |  | 3.58d | 0d |  |  | 72h |  |
| 279 | 2.6.1.1 | **Define Information Needs (What do we need to gather?)** |  | 2.42d? | 2005-03-16 | 2005-03-18 |  |  |  |  |  |  | 3.58d | 0d |  |  | 32h |  |
| 280 | 2.6.1.1.1 | Compile existing archiving standards in use (e.g. data format, transfer mode) |  | 1d? | 2005-03-16 | 2005-03-16 |  |  |  |  |  |  | 3.58d | 0d |  | Business Lead; GTG Standards Committee | 16h |  |
| 281 | 2.6.1.1.2 | Identify how archiving is done at present time by ICS, military, other incident responders, project-management |  | 0.17d? | 2005-03-17 | 2005-03-17 | 280 |  |  |  |  |  | 3.58d | 0d |  | Internet Search; Military; etc.; survey GISTs; Plans Sections (Mary Kwart); Documents Sections | 8h |  |
| 282 | 2.6.1.1.3 | Gather NARA, Records Management requirements (review policies, lawsuits) e.g. physical location, acceptable media, supporting documentation |  | 0.25d? | 2005-03-17 | 2005-03-17 | 281 |  |  |  |  |  | 3.58d | 0d |  | Business Lead; FGDC; NARA; NWCG Member Agencies | 8h |  |
| 283 | 2.6.1.1.4 | Determine the least common denominator (shapefile) or possibility of multiple formats |  | 1d? | 2005-03-17 | 2005-03-18 | 282 |  |  |  |  |  | 3.58d |  |  |  |  |  |
| 284 | 2.6.1.2 | Collect Information: Conduct literature review |  | 1d? | 2005-03-18 | 2005-03-21 | 279 |  |  |  |  |  | 3.58d | 0d |  | FGDC; GeoMAC; NPS I&M; NPS Focus; NARA | 40h |  |
| 285 | 2.6.1.3 | Conduct Analysis: Compile & Synthesize Requirements |  | 1d? | 2005-03-21 | 2005-03-22 | 284 |  |  |  |  |  | 3.58d |  |  |  |  |  |
| 286 | 2.6.2 | **Develop draft SOPs for GIS Standard Data Sharing and Archiving Standards** |  | 4d? | 2005-03-22 | 2005-03-28 | 278 |  |  |  |  |  | 3.58d |  |  |  | 24h |  |
| 287 | 2.6.2.1 | Develop Preliminary SOPs |  | 1d? | 2005-03-22 | 2005-03-23 |  |  |  |  |  |  | 3.58d | 0d |  | DataShareArcTrans Subteam | 8h |  |
| 288 | 2.6.2.2 | Sub-Team Review of SOP |  | 1d? | 2005-03-23 | 2005-03-24 | 287 |  |  |  |  |  | 3.58d | 0d |  | DataShareArcTrans Subteam | 8h |  |
| 289 | 2.6.2.3 | Revise, Edit Proposed SOP |  | 1d? | 2005-03-24 | 2005-03-25 | 288 |  |  |  |  |  | 3.58d | 0d |  | DataShareArcTrans Subteam | 8h |  |
| 290 | 2.6.2.4 | Submit to Project Manager for Team Review |  | 1d? | 2005-03-25 | 2005-03-28 | 289 |  |  |  |  |  | 3.58d |  |  |  |  |  |
| 291 | 2.7 | **Incident GIS Standard Documentation and Archiving** |  | 23d? | 2005-03-16 A | 2005-04-15 |  | 32% | 15.64d? |  |  |  | -5d | 0d |  | Sean Triplett | 1088h | 218.88h |
| 292 | 2.7.1 | **Develop requirements for GIS Standard Documentation and Archiving SOPs** |  | 20d? | 2005-03-16 A | 2005-04-12 |  | 54% | 9.19d? |  |  |  | -2d | 0d |  |  | 760h | 160h |
| 293 | 2.7.1.1 | **Define Information Needs (What do we need to gather?)** |  | 18d? | 2005-03-16 A | 2005-04-08 |  | 59% | 7.41d? |  |  |  | 0d |  |  |  | 712h | 160h |
| 294 | 2.7.1.1.1 | Compile existing archiving standards in use (e.g. data format, transfer mode) |  | 10d? | 2005-03-23 A | 2005-04-05 A |  | 100% |  |  |  |  |  |  |  | GTG Standards Committee; Mary Kwart | 160h | 160h |
| 295 | 2.7.1.1.2 | Identify how archiving is done at present time by ICS, military, other incident responders, project-management |  | 13d? | 2005-03-23 A | 2005-04-08 | 294 |  | 13d? |  |  |  | 0d |  | finish no earlier than 2005-04-08 | Internet Search; Military; survey GISTs; Plans Sections (Mary Kwart); Documents Sections | 520h |  |
| 296 | 2.7.1.1.3 | ?? Gather NARA, Records Management requirements (review policies, lawsuits) e.g. physical location, acceptable media, supporting documentation |  | 1d | 2005-03-16 | 2005-03-16 |  |  |  |  |  |  | 6d |  |  | Business Lead; FGDC; NARA; agency guidance | 32h |  |
| 297 | 2.7.1.1.4 | Determine the least common denominator (shapefile) or possibility of multiple formats |  | 10d? | 2005-03-23 A | 2005-04-05 A | 294, 295, 296 | 100% |  |  |  |  |  |  |  |  |  |  |
| 298 | 2.7.1.2 | Review Documentation Unit Leader Task book and Job Aid |  | 1d? | 2005-03-16 | 2005-03-16 |  |  |  |  |  |  | 6d |  |  | FGDC; GeoMAC; NPS I&M; NPS Focus; NARA | 40h |  |
| 299 | 2.7.1.3 | Conduct Analysis: Compile, Synthesize requirements |  | 1d? | 2005-04-11 | 2005-04-11 | 298, 293 |  |  |  |  |  | -11d | 0d |  |  |  |  |
| 300 | 2.7.1.4 | Document Preliminary Requirements Specifications |  | 1d? | 2005-04-12 | 2005-04-12 | 299 |  |  |  |  |  | -11d | 0d |  | DataShareArcTrans Subteam | 8h |  |
| 301 | 2.7.1.5 | Post subteam Requirements for GSTOP Team Review | milestone | 0d | 2005-04-12 | 2005-04-12 | 300 |  |  |  |  |  | -11d | 0d |  |  |  |  |

Notes:
- 274: Text1: Recommendation Report
- 275: Text1: Finalized Recommendation Report
- 276: Text1: Report Submission
- 293: Text1: Spreadsheet
- 294: Brian Sorbel, Joe Frost, Susan Goodman / Text1: List of data types in use on incidents and standards
- 295: idea is to take advantage of "lessons learned." Have made contact with NORTHCOM (Military). / Text1: Matrix of incident/event data creators and indication of how they manage their data
- 296: Text1: list of data repositories, data warehouses, etc.
- 297: Should incident data be in a format compatible with GeoSpatial One-Stop, GEOMAC? / Text1: List of acceptable data forms for archiving.
- 298: Text1: Writeup of requirements for data repositories.
- 299: Text1: Writeup of common elements, differences, ideas worth pursuing.
- 300: Text1: Develop Proposed SOP
- 301: Text1: Information Needs for GIS Standard Documentation and Archiving

| ID | WBS | Task | Type | Duration | Start | Finish | Predecessors | Complete | Remaining | Baseline start | Baseline finish | Baseline duration | Total slack | Free slack | Resources | Work | Actual work | Text1 |
| --- | --- | --- | --- | --- | --- | --- | --- | --- | --- | --- | --- | --- | --- | --- | --- | --- | --- | --- |
| 302 | 2.7.2 | **Develop draft SOPs for GIS Standard Documentation and Archiving** |  | 3d? | 2005-04-13 | 2005-04-15 | 292 |  |  |  |  |  | -11d | 0d |  | 24h |  |  |
| 303 | 2.7.2.1 | Develop Preliminary SOPs |  | 1d? | 2005-04-13 | 2005-04-13 |  |  |  |  |  |  | -11d | 0d | DataShareArcTrans Subteam | 8h |  |  |
| 304 | 2.7.2.2 | Sub-Team Review of SOP |  | 1d? | 2005-04-14 | 2005-04-14 | 303 |  |  |  |  |  | -11d | 0d | DataShareArcTrans Subteam | 8h |  | Writeup of results of Sub-Team review |
| 305 | 2.7.2.3 | Revise, Edit Proposed SOP |  | 1d? | 2005-04-15 | 2005-04-15 | 304 |  |  |  |  |  | -11d | 0d | DataShareArcTrans Subteam | 8h |  | Revised SOP |
| 306 | 2.7.2.4 | Submit to Project Manager for Team Review | milestone | 0d | 2005-04-15 | 2005-04-15 | 305 |  |  |  |  |  | -11d | 0d |  |  |  | GIS Standard Documentation and Archiving draft SOPs |
| 307 | 2.7.3 | **Conduct External Review of GIS Standard Data Sharing and Archiving Standards SOP requirements and draft SOPs** |  | 12d? | 2005-03-16 | 2005-03-31 |  |  |  |  |  |  | -2d | 0d |  | 112h |  |  |
| 308 | 2.7.3.1 | Design External Review of guidelines/requirements for GIS Standard Documentation and Archiving SOPs |  | 2d? | 2005-03-16 | 2005-03-17 |  |  |  |  |  |  | 2.5d | 0d |  |  |  | Plan for external review of GIS Transition Procedures |
| 309 | 2.7.3.2 | Post sample documents/SOPs for external review |  | 5d? | 2005-03-18 | 2005-03-24 | 308 |  |  | 2004-12-31 | 2005-01-17 | 12d? | 2.5d | 0d |  |  |  |  |
| 310 | 2.7.3.3 | Conduct External review of Guidelines/Requirements and draft SOPs |  | 0.5d? | 2005-03-25 | 2005-03-25 | 309 |  |  |  |  |  | 2.5d |  | GTG; Reviewers | 8h |  |  |
| 311 | 2.7.3.4 | Edit draft guidelines/Requirements based on input |  | 1d? | 2005-03-16 | 2005-03-16 |  |  |  |  |  |  | 9d |  | Sub-Team | 8h |  | final requirements |
| 312 | 2.7.3.5 | Edit sample documents/SOPs based on input |  | 12d? | 2005-03-16 | 2005-03-31 |  |  |  | 2004-12-31 | 2005-01-05 | 4d? | -2d | 0d | Sub-Team | 96h |  | final SOPs |
| 313 | 2.7.4 | **Finalize recommendation of GIS Standard Documentation and Archiving** |  | 2d? | 2005-04-01 | 2005-04-04 | 307 |  |  | 2004-12-31 | 2004-12-31 | 1d? | -2d | 0d |  | 8h |  |  |
| 314 | 2.7.4.1 | Create a report recommending the adoption of the standard |  | 1d? | 2005-04-01 | 2005-04-01 |  |  |  | 2004-12-31 | 2004-12-31 | 1d? | -2d | 0d |  |  |  | Recommendation Report |
| 315 | 2.7.4.2 | Conduct a review of the report |  | 1d? | 2005-04-04 | 2005-04-04 | 314 |  |  | 2004-12-31 | 2004-12-31 | 1d? | -2d | 0d | Sub-Team | 8h |  | Finalized Recommendation Report |
| 316 | 2.7.4.3 | Submit the report to GSTOP-PM | milestone | 0d | 2005-04-04 | 2005-04-04 | 315 |  |  | 2004-12-31 | 2004-12-31 | 1d | -2d | 0d |  |  |  | Report Submission |
| 317 | 2.8 | **Incident GIS Transition Procedures** |  | 65d? | 2005-03-16 A | 2005-06-14 |  | 26% | 48.23d? |  |  |  | 253d |  |  | 360h | 96h |  |
| 318 | 2.8.1 | **Develop requirements for GIS Transition Procedures** |  | 17d? | 2005-03-18 A | 2005-04-11 |  | 63% | 6.26d? |  |  |  | -5d | 0d |  | 200h | 96h |  |
| 319 | 2.8.1.1 | **Define Information Needs (What do we need to gather?)** |  | 12d? | 2005-03-18 A | 2005-04-04 |  | 86% | 1.71d? |  |  |  | 0d |  |  | 160h | 96h |  |
| 320 | 2.8.1.1.1 | Determine "universe" of transitions: (team to team); (team to unit); (team to archive) |  | 1d? | 2005-03-23 A | 2005-03-23 |  |  | 1d? |  |  |  | -1d | 0d | Business Lead; FGDC; NARA; agency guidance | 32h |  | Annotated Hierarchical List |
| 321 | 2.8.1.1.2 | Conduct interviews and compile procedures documents currently in use |  | 1d? | 2005-03-23 A | 2005-03-23 | 320 |  | 1d? |  |  |  | 1d |  | Other "team" environs; Mary Kwart; Military; survey | 32h |  | annotated list |
| 322 | 2.8.1.1.3 | Identify if existing procedures in use "somewhere out there" may be acceptible (e.g. NARA) |  | 12d? | 2005-03-18 A | 2005-04-04 A | 321 | 100% |  |  |  |  |  |  | DataShareArcTrans Subteam | 96h | 96h | writeup |
| 323 | 2.8.1.2 | Evaluate Procedures: Identify test procedures for documentation and archiving |  | 1d? | 2005-04-05 | 2005-04-05 | 319 |  |  |  |  |  | -7d | 0d | DataShareArcTrans Subteam | 8h |  | writeup |
| 324 | 2.8.1.3 | Conduct Analysis: Test and identify strengths/weaknesses of existing procedures |  | 1d? | 2005-04-06 | 2005-04-06 | 323 |  |  |  |  |  | -7d | 0d | field teams; DataShareArcTrans Subteam | 16h |  | writieup of test |
| 325 | 2.8.1.4 | Develop Preliminary Requirements Specifications |  | 1d? | 2005-04-07 | 2005-04-07 | 324 |  |  |  |  |  | -7d | 0d |  |  |  | summarize test |

Notes:
- 320: is "unit to team" transfer covered in MED? Is transition to archive covered in team-to-unit?

| ID | WBS | Task | Type | Duration | Start | Finish | Predecessors | Baseline start | Baseline finish | Baseline duration | Total slack | Free slack | Resources | Work | Text1 |
| --- | --- | --- | --- | --- | --- | --- | --- | --- | --- | --- | --- | --- | --- | --- | --- |
| 326 | 2.8.1.5 | **Review and Validate Requirements** |  | 2d? | 2005-04-08 | 2005-04-11 | 325 |  |  |  | -7d | 0d |  | 16h |  |
| 327 | 2.8.1.5.1 | Sub-Team Review of Requirements |  | 1d? | 2005-04-08 | 2005-04-08 |  |  |  |  | -7d | 0d | DataShareArcTrans Subteam | 8h | draft GIS Transition requirements |
| 328 | 2.8.1.5.2 | Revise, Edit requirements |  | 1d? | 2005-04-11 | 2005-04-11 | 327 |  |  |  | -7d | 0d | DataShareArcTrans Subteam | 8h | final GIS Transition requirements |
| 329 | 2.8.1.5.3 | Submit to Project Manager for Team Review | milestone | 0d | 2005-04-11 | 2005-04-11 | 328 |  |  |  | -7d | 0d |  |  |  |
| 330 | 2.8.2 | **Develop Preliminary SOP’s** |  | 5d? | 2005-06-08 | 2005-06-14 | 372, 318 |  |  |  | 253d |  |  | 40h |  |
| 331 | 2.8.2.1 | Create draft GIS Transition SOPs |  | 1d? | 2005-06-08 | 2005-06-08 |  |  |  |  | 253d | 0d | DataShareArcTrans Subteam | 8h | draft GIS Transition SOPs |
| 332 | 2.8.2.2 | Review draft GIS Transition SOPs |  | 1d? | 2005-06-09 | 2005-06-09 | 331 |  |  |  | 253d | 0d | DataShareArcTrans Subteam | 8h | Writeup of results of Sub-Team review |
| 333 | 2.8.2.3 | Revise, Edit draft GIS Transition SOPs |  | 1d? | 2005-06-10 | 2005-06-10 | 332 |  |  |  | 253d | 0d | DataShareArcTrans Subteam | 8h | Draft GIS Transition SOPs |
| 334 | 2.8.2.4 | Submit to Project Manager for Team Review | milestone | 0d | 2005-06-10 | 2005-06-10 | 333 |  |  |  | 253d | 0d |  |  |  |
| 335 | 2.8.2.5 | Review Draft GIS Transition SOPs |  | 1d? | 2005-06-13 | 2005-06-13 | 334 |  |  |  | 253d | 0d | GSTOP Team | 8h | comments on draft Transition SOPs |
| 336 | 2.8.2.6 | Revise, Edit GIS Transition SOPs |  | 1d? | 2005-06-14 | 2005-06-14 | 335 |  |  |  | 253d |  | DataShareArcTrans Subteam | 8h | Proposed GIS Transition SOPs |
| 337 | 2.8.3 | **Conduct External Review of GIS Transition Procedures SOP requirements and draft SOPs** |  | 12d? | 2005-03-16 | 2005-03-31 |  |  |  |  | 290d | 0d |  | 112h |  |
| 338 | 2.8.3.1 | Design External Review of guidelines/requirements for GIS Transition Procedures |  | 2d? | 2005-03-16 | 2005-03-17 |  |  |  |  | 294.5d | 0d |  |  | Plan for external review of GIS Transition Procedures |
| 339 | 2.8.3.2 | Post sample documents/SOPs for external review |  | 5d? | 2005-03-18 | 2005-03-24 | 338 | 2004-12-31 | 2005-01-17 | 12d? | 294.5d | 0d |  |  |  |
| 340 | 2.8.3.3 | Conduct External review of Guidelines/Requirements and draft SOPs |  | 0.5d? | 2005-03-25 | 2005-03-25 | 339 |  |  |  | 294.5d |  | GTG; Reviewers | 8h |  |
| 341 | 2.8.3.4 | Edit draft guidelines/Requirements based on input |  | 1d? | 2005-03-16 | 2005-03-16 |  |  |  |  | 301d |  | Sub-Team | 8h | final requirements |
| 342 | 2.8.3.5 | Edit sample documents/SOPs based on input |  | 12d? | 2005-03-16 | 2005-03-31 |  | 2004-12-31 | 2005-01-05 | 4d? | 290d |  | Sub-Team | 96h | final SOPs |
| 343 | 2.8.4 | **Finalize recommendation of GIS Transition Procedures** |  | 2d? | 2005-04-01 | 2005-04-04 | 337 | 2004-12-31 | 2004-12-31 | 1d? | 290d |  |  | 8h |  |
| 344 | 2.8.4.1 | Create a report recommending the adoption of the standard |  | 1d? | 2005-04-01 | 2005-04-01 |  | 2004-12-31 | 2004-12-31 | 1d? | 290d | 0d |  |  | Recommendation Report |
| 345 | 2.8.4.2 | Conduct a review of the report |  | 1d? | 2005-04-04 | 2005-04-04 | 344 | 2004-12-31 | 2004-12-31 | 1d? | 290d | 0d | Sub-Team | 8h | Finalized Recommendation Report |
| 346 | 2.8.4.3 | Submit the report to GSTOP-PM | milestone | 0d | 2005-04-04 | 2005-04-04 | 345 | 2004-12-31 | 2004-12-31 | 1d | 290d |  |  |  | Report Submission |
| 347 | 3 | **Agency Review of Incident GIS SOPs** |  | 185d? | 2005-06-07 | 2006-02-20 | 381 |  |  |  | -167d | 0d | GSTOP Team | 4440h |  |
| 348 | 3.1 | Design common review processes for GIS SOP peer review |  | 1d? | 2005-06-07 | 2005-06-07 |  |  |  |  | 17d |  |  |  |  |
| 349 | 3.2 | **Review and Validate draft SOP’s** |  | 1d? | 2005-06-07 | 2005-06-07 |  |  |  |  | 17d |  |  | 40h |  |
| 350 | 3.2.1 | Review and Validate draft SOP’s for completeness |  | 0.5d? | 2005-06-07 | 2005-06-07 |  | 2005-01-19 | 2005-01-19 | 0.5d? | 17.5d |  | GSTOP Team; GTG; GTAG; Reviewers | 16h |  |
| 351 | 3.2.2 | Review and Validate draft SOP’s for GIS content |  | 1d? | 2005-06-07 | 2005-06-07 |  | 2005-01-19 | 2005-01-19 | 1d? | 17d |  | GSTOP Team; GTAG; Reviewers | 24h |  |

| ID | WBS | Task | Type | Duration | Start | Finish | Predecessors | Complete | Remaining | Baseline start | Baseline finish | Baseline duration | Total slack | Free slack | Constraint | Resources | Work | Actual work | Text1 |
| --- | --- | --- | --- | --- | --- | --- | --- | --- | --- | --- | --- | --- | --- | --- | --- | --- | --- | --- | --- |
| 352 | 3.3 | **Agencies' review of Draft SOPs** |  | 182d? | 2005-06-07 | 2006-02-15 |  |  |  | 2005-01-19 | 2005-01-19 | 1d? | -167d | 0d |  | all concerned/impacted parties | 2896h |  |  |
| 353 | 3.3.1 | Create a cover letter and response process |  | 1d? | 2005-06-07 | 2005-06-07 |  |  |  | 2005-01-19 | 2005-01-19 | 1d? | -167d | 0d |  |  |  |  | cover letter |
| 354 | 3.3.2 | Distribute draft SOPs for Agency review |  | 1d? | 2005-06-08 | 2005-06-08 | 353 |  |  |  |  |  | -167d | 0d |  |  |  |  |  |
| 355 | 3.3.3 | Review and Validate draft SOP’s |  | 180d | 2005-06-09 | 2006-02-15 | 354 |  |  | 2005-01-19 | 2005-01-19 | 1d? | -167d | 0d |  | NWCG Member Agencies | 1440h |  |  |
| 356 | 3.4 | **Incorporate Feedback from reviewers** |  | 3d? | 2006-02-16 | 2006-02-20 | 352 |  |  |  |  |  | -167d | 0d |  |  | 24h |  |  |
| 357 | 3.4.1 | Consolidate reviewers' inputs |  | 1d? | 2006-02-16 | 2006-02-16 |  |  |  | 2005-01-19 | 2005-01-19 | 1d? | -167d | 0d |  |  |  |  |  |
| 358 | 3.4.2 | Evaluate Feedback for inclusion in SOP revision |  | 1d? | 2006-02-17 | 2006-02-17 | 357 |  |  | 2005-01-19 | 2005-01-19 | 1d? | -167d | 0d |  | GSTOP Team; Independent Reviewer | 16h |  |  |
| 359 | 3.4.3 | Update draft SOPs for accepted feedback from reviewers |  | 1d? | 2006-02-20 | 2006-02-20 | 358 |  |  | 2005-01-19 | 2005-01-19 | 1d? | -167d | 0d |  | GSTOP Subteam(s) | 8h |  | Revised Draft SOPs |
| 361 | 4 | **Field Test of Incident GIS SOPs (including business requirements)** |  | 1d? | 2005-06-07 | 2005-06-07 | 381 |  |  |  |  |  | 17d |  |  | IMT Teams | 32h |  |  |
| 362 | 4.1 | Develop a list of GSTOP deliverable reviewers |  | 1d? | 2005-06-07 | 2005-06-07 |  |  |  |  |  |  | 17d |  |  | Business Lead | 8h |  | List of GSTOP reviewers |
| 363 | 4.2 | **Develop Quality Assurance and Field Test Plan** |  | 1d? | 2005-06-07 | 2005-06-07 |  |  |  |  |  |  | 17d |  |  | Subteam Lead | 8h |  |  |
| 364 | 4.2.1 | Develop survey instrument to capture field test feedback |  | 1d? | 2005-06-07 | 2005-06-07 |  |  |  |  |  |  | 17d |  |  |  |  |  | GSTOP Field Test results survey |
| 365 | 4.3 | **Execute Quality Assurance and Field Test Plan** |  | 1d? | 2005-06-07 | 2005-06-07 |  |  |  |  |  |  | 17d |  |  | Subteam Lead | 8h |  |  |
| 366 | 4.3.1 | Conduct interviews with GISTs to measure success of Draft SOPs |  | 1d? | 2005-06-07 | 2005-06-07 |  |  |  |  |  |  | 17d |  |  |  |  |  |  |
| 367 | 4.3.2 | Conduct interviews with SIT Unit Leaders to measure success of Draft SOPs |  | 1d? | 2005-06-07 | 2005-06-07 |  |  |  |  |  |  | 17d |  |  |  |  |  |  |
| 368 | 4.4 | Collect written/survey results from the field test |  | 1d? | 2005-06-07 | 2005-06-07 |  |  |  |  |  |  | 17d |  |  |  |  |  |  |
| 369 | 4.5 | Analyze Quality Assurance and Field Test Plan Results |  | 1d? | 2005-06-07 | 2005-06-07 |  |  |  |  |  |  | 17d |  |  |  |  |  |  |
| 370 | 5 | **GSTOP Requirements Milestones** |  | 101d? | 2005-02-10 A | 2005-07-01 |  | 99% | 0d? |  |  |  | 120d |  |  | Project Mgr | 3592h | 3592h |  |
| 371 | 5.1 | MS1: Requirements for GIS SOPs are developed | milestone | 0d | 2005-03-31 | 2005-03-31 | 21, 94, 134, 176, 217, 277, 291, 329 |  |  |  |  |  | -55d | 0d | must finish on 2005-03-31 | Project Mgr; GSTOP Exec Comm |  |  | progress report, project/communication plan |
| 372 | 5.2 | **Develop template for GIS SOPs** |  | 84d? | 2005-02-10 A | 2005-06-07 A |  | 100% |  |  |  |  |  |  |  | Project Mgr; Susan Goodman; Kim Kelly | 2520h | 2520h | Template SOP |
| 373 | 5.2.1 | Review current formats and compile representative selections |  | 37d? | 2005-02-10 A | 2005-04-01 A |  | 100% |  |  |  |  |  |  |  | Sue McLellan | 296h | 296h |  |
| 374 | 5.2.2 | Itemize standard SOP content |  | 2d? | 2005-03-31 A | 2005-04-01 A | 373 | 100% |  |  |  |  |  |  |  | Sue McLellan | 16h | 16h |  |
| 375 | 5.2.3 | Review content for completeness |  | 10d? | 2005-04-04 A | 2005-04-15 A | 374 | 100% |  |  |  |  |  |  | finish no earlier than 2005-04-15 | GSTOP Team | 80h | 80h |  |
| 376 | 5.2.4 | Design standard GIS SOP format |  | 1d? | 2005-04-18 A | 2005-04-18 A | 375 | 100% |  |  |  |  |  |  |  | BLM Pulications | 8h | 8h | GIS SOP template |
| 377 | 5.2.5 | Provide sample SOPs for publishing |  | 1d? | 2005-04-19 A | 2005-04-19 A | 376 | 100% |  |  |  |  |  |  |  | GSTOP Team | 8h | 8h |  |
| 378 | 5.2.6 | Mockup final GIS SOPs for GTG Team Review |  | 1d? | 2005-04-20 A | 2005-04-20 A | 377 | 100% |  |  |  |  |  |  |  | BLM Pulications | 8h | 8h | Draft SOP's |
| 379 | 5.2.7 | Review final GIS SOP mockup |  | 1d? | 2005-04-21 A | 2005-04-21 A | 378 | 100% |  |  |  |  |  |  |  | GSTOP Team | 8h | 8h |  |
| 380 | 5.2.8 | Final formatting and publication of draft SOPs for Field Test |  | 10d | 2005-05-25 A | 2005-06-07 A | 302, 53, 114, 153, 189, 253, 286 | 100% |  |  |  |  |  |  |  | BLM Pulications | 80h | 80h |  |
| 381 | 5.3 | MS2: Draft SOPs are produced and ready for Field Test |  | 16.5d? | 2005-05-13 A | 2005-06-06 A | 380 | 100% |  |  |  |  |  |  | must finish on 2005-05-13 | Project Mgr; Business Lead | 264h | 264h | draft SOPs |
| 383 | 5.4 | MS3: Requirements are reviewed and tested by business community | milestone | 0d | 2005-07-01 A | 2005-07-01 | 361, 347 |  | 0d |  |  |  | 120d | 0d | must finish on 2005-12-15 | Business Lead; Business Community; Project Mgr |  |  | buiness community issues document |

| ID | WBS | Task | Type | Duration | Start | Finish | Predecessors | Complete | Remaining | Total slack | Free slack | Constraint | Resources | Work | Actual work |
| --- | --- | --- | --- | --- | --- | --- | --- | --- | --- | --- | --- | --- | --- | --- | --- |
| 385 | 6 | **Final Incident GIS SOPs** |  | 240d? | 2005-07-01 | 2006-06-01 | 383 |  |  | 1d |  |  | GSTOP Team | 1936h |  |
| 386 | 6.1 | Determine what changes need to be made to the Incident GIS SOPs |  | 1d? | 2005-07-01 | 2005-07-01 |  |  |  | 240d |  |  | GSTOP Subteam(s) | 8h |  |
| 387 | 6.2 | Update and finalize all Incident GIS SOPs |  | 1d? | 2005-07-01 | 2005-07-01 |  |  |  | 240d |  |  | GSTOP Subteam(s) | 8h |  |
| 388 | 6.3 | MS5: GIS SOPs are finalized | milestone | 0d | 2006-05-15 | 2006-05-15 | 90, 130, 213, 273, 313, 343, 171 |  |  | 0d |  | must finish on 2006-05-15 | Project Mgr; GSTOP Exec Comm |  |  |
| 389 | 6.4 | Deliver Final Incident GIS SOPs to Executive Committee | milestone | 0d | 2006-05-15 | 2006-05-15 | 388 |  |  | 14d |  |  |  |  |  |
| 390 | 6.5 | Deliver Final Incident GIS SOPs to Incident Based Automation Project | milestone | 0d | 2006-05-15 | 2006-05-15 | 388 |  |  | 14d |  |  |  |  |  |
| 391 | 6.6 | **Prepare delivery package for final SOPs to GTG** |  | 1d? | 2005-07-01 | 2005-07-01 |  |  |  | 240d |  |  |  |  |  |
| 392 | 6.6.1 | Prepare GIS SOP Implementation Plan |  | 1d? | 2005-07-01 | 2005-07-01 |  |  |  | 240d |  |  |  |  |  |
| 393 | 6.6.2 | **Prepare GIS SOP Change Management Plan** |  | 1d? | 2005-07-01 | 2005-07-01 |  |  |  | 240d |  |  |  |  |  |
| 394 | 6.6.2.1 | Develop GIS SOP Change Management Plan |  | 1d? | 2005-07-01 | 2005-07-01 |  |  |  | 240d |  |  |  |  |  |
| 395 | 6.6.2.2 | Review GIS SOP Change Management Plan |  | 1d? | 2005-07-01 | 2005-07-01 |  |  |  | 240d |  |  |  |  |  |
| 396 | 6.7 | MS6: Draft recommendation for SOP implementation | milestone | 0d | 2006-06-01 | 2006-06-01 |  |  |  | 0d |  | must finish on 2006-06-01 | GSTOP Team; GSTOP Exec Comm |  |  |
| 397 | 7 | **GSTOP Project Management** |  | 423d? | 2004-10-20 A | 2006-06-02 |  | 40% | 253.8d? | 0d |  |  | Sue McLellan | 4120h | 720h |
| 398 | 7.1 | **Establish Subteam Business Practices** |  | 120d? | 2004-10-20 A | 2005-04-05 |  |  | 120d? | 303d |  |  |  | 8h |  |
| 399 | 7.1.1 | Review Business Practices Developed by Symbology SubTeam (communication, review process and change process) |  | 1d? | 2005-04-04 A | 2005-04-04 | 22 |  | 1d? | 303d | 0d |  | GSTOP Team | 8h |  |
| 400 | 7.1.2 | Finalize Sub-Team business practices |  | 1d? | 2005-04-05 | 2005-04-05 | 399 |  |  | 303d |  |  |  |  |  |
| 401 | 7.1.3 | Complete Team Operating Principles for document management (standard title page, headers/footers, naming convention, document location, etc.) |  | 1d? | 2004-10-20 | 2004-10-20 |  |  |  | 422d |  |  |  |  |  |
| 402 | 7.2 | Establish a process for providing feedback to Wildland Fire Agency Management from the GSTOP team |  | 1d? | 2004-10-20 | 2004-10-20 |  |  |  | 422d |  |  |  |  |  |
| 403 | 7.3 | **Conduct Periodic Team Meetings** |  | 78d | 2005-01-25 A | 2005-05-12 A |  | 100% |  |  |  |  | Project Mgr | 720h | 720h |
| 404 | 7.3.1 | January Team Meeting (Portland) |  | 3d | 2005-01-25 A | 2005-01-27 A |  | 100% |  |  |  | start no earlier than 2005-01-25 | GSTOP Team; Project Mgr | 48h | 48h |
| 405 | 7.3.2 | May Team Meeting (Denver) |  | 3d | 2005-05-10 A | 2005-05-12 A |  | 100% |  |  |  | start no earlier than 2005-05-10 | GSTOP Team; Project Mgr | 48h | 48h |
| 406 | 7.4 | **Develop GIS SOP Implementation Plan** |  | 1d? | 2004-10-20 | 2004-10-20 |  |  |  | 422d |  |  |  |  |  |
| 407 | 7.4.1 | Develop and implement GSTOP SOP User education and distribution strategy |  | 1d? | 2004-10-20 | 2004-10-20 |  |  |  | 422d |  |  |  |  |  |
| 408 | 7.4.2 | Ensure incorporation of GSTOP deliverables into national and local training programs |  | 1d? | 2004-10-20 | 2004-10-20 |  |  |  | 422d |  |  |  |  |  |

Notes:
- 388: Text1: final GIS SOPs
- 396: Text1: GIS SOP Implementation Recommendations
- 399: Text1: Sub-Team Business Practices
- 401: Text1: GSTOP document management guidelines
- 402: Text1: GSTOP communication process (to Wildland Fire Agency Management)
- 405: Text1: Draft Sops
- 407: comm plan section 7: GSTOP SOP Users Strategy

| ID | WBS | Task | Type | Duration | Start | Finish | Predecessors | Complete | Remaining | Total slack | Constraint | Resources | Work | Actual work |
| --- | --- | --- | --- | --- | --- | --- | --- | --- | --- | --- | --- | --- | --- | --- |
| 409 | 7.5 | **Closeout GSTOP Project** |  | 1d? | 2006-06-02 | 2006-06-02 | 396 |  |  | 0d |  | GTG Exec Comm | 8h |  |
| 410 | 7.5.1 | Convey final GSTOP deliverables to fire mapping tool development team (ESRI) |  | 1d? | 2006-06-02 | 2006-06-02 |  |  |  | 0d |  |  |  |  |
| 411 | 7.5.2 | Prepare GSTOP Team Recommendations |  | 1d? | 2006-06-02 | 2006-06-02 |  |  |  | 0d |  |  |  |  |
| 412 | 7.5.3 | Document Lessons Learned |  | 1d? | 2006-06-02 | 2006-06-02 |  |  |  | 0d |  |  |  |  |
| 413 | 7.5.4 | GSTOP Project Complete | milestone | 0d | 2006-06-02 | 2006-06-02 |  |  |  | 0d | finish no earlier than 2006-06-02 |  |  |  |
| 414 | 8 | **Implement GSTOP Project Communication Plan** |  | 356d? | 2004-10-20 A | 2006-03-01 |  |  | 354.46d? | 67d |  | Business Lead | 15360h | 697.65h |
| 415 | 8.1 | **Create processes and methods for communication to stakeholders** |  | 168d? | 2004-10-20 A | 2005-06-10 |  |  | 168d? | 255d |  | Project Mgr | 8360h |  |
| 416 | 8.1.1 | **Establish communications with other projects/teams/agencies** |  | 114d? | 2004-12-01 A | 2005-05-09 |  |  | 114d? | 279d |  | GSTOP Team; IRMWT; NWCG Training Team; NWCG Working teams; NWCG PMO | 6840h |  |
| 417 | 8.1.1.1 | Establish interproject liaison and communication agreement and schedule with Incident-Based Automation project |  | 1d? | 2004-12-01 A | 2004-12-01 |  |  | 1d? | 392d | start no earlier than 2004-12-01 | Project Mgr | 8h |  |
| 418 | 8.1.1.2 | Establish interproject liaison and communication agreement and schedule with NWCG GIST position development and training effort |  | 26d | 2005-04-04 A | 2005-05-09 |  |  | 26d | 279d |  | Business Lead | 208h |  |
| 419 | 8.1.1.3 | Establish interproject liaison and communication agreement and schedule with NWCG DPRO training cirriculum revision effort |  | 26d | 2005-04-04 A | 2005-05-09 |  |  | 26d | 279d |  | Business Lead | 208h |  |
| 420 | 8.1.1.4 | Establish interproject liaison and communication agreement and schedule with SIT Unit Leader SME group |  | 26d | 2005-04-04 A | 2005-05-09 |  |  | 26d | 279d |  | Business Lead | 208h |  |
| 421 | 8.1.1.5 | Establish interproject liaison and communication agreement and schedule with NWCG Training WT |  | 26d | 2005-04-04 A | 2005-05-09 |  |  | 26d | 279d |  |  |  |  |
| 422 | 8.1.1.6 | Establish liaison relationships with Other All-Risk organizations involved with GIS SOP development [NIIMS Group,Department of Homeland Security (DHS),FEMA] |  | 60d? | 2005-02-15 A | 2005-05-09 |  |  | 60d? | 279d | finish no earlier than 2005-05-09 | NIIMS Group; Department of Homeland Security (DHS); FEMA | 1440h |  |
| 423 | 8.1.1.7 | Establish liaison relationships with Regional GIS coordinators |  | 26d? | 2005-04-04 | 2005-05-09 |  |  |  | 279d | finish no earlier than 2005-05-09 | Business Lead | 208h |  |
| 424 | 8.1.2 | Establish project status reporting processes |  | 1d? | 2004-12-06 A | 2004-12-06 |  |  | 1d? | 389d |  | Project Mgr | 8h |  |
| 425 | 8.1.3 | **Establish GSTOP Project communications methods** |  | 168d? | 2004-10-20 A | 2005-06-10 |  |  | 168d? | 255d |  |  | 168h |  |
| 426 | 8.1.3.1 | Establish team workspace on disaster help | milestone | 0d? | 2005-01-05 A | 2005-01-05 A |  | 100% |  |  |  |  |  |  |
| 427 | 8.1.3.2 | Find a storage location for GSTOP group review (NIFC site?) | milestone | 0d? | 2005-01-25 A | 2005-01-25 A |  | 100% |  |  |  |  |  |  |
| 428 | 8.1.3.3 | **Establish GSTOP project webpages linked to GTG website** |  | 8d? | 2005-06-01 | 2005-06-10 |  |  |  | 255d |  | Project Mgr | 128h |  |
| 429 | 8.1.3.3.1 | Identify Website Content |  | 8d? | 2005-06-01 | 2005-06-10 |  |  |  | 255d | start no earlier than 2005-06-01 | Project Mgr | 64h |  |
| 430 | 8.1.3.4 | **Establish process for information dissemination to Wildland Fire Agency Management** |  | 1d? | 2004-10-20 | 2004-10-20 |  |  |  | 422d |  | Business Lead | 16h |  |
| 431 | 8.1.3.4.1 | Confirm which segment of "management" we need to communicate with when about what. |  | 0.33d? | 2004-10-20 | 2004-10-20 |  |  |  | 422.67d |  | Business Lead; Project Mgr; Susan Goodman | 8h |  |
| 432 | 8.1.3.4.2 | Design communciations and schedule for dissemination to Fire GIS qulaified folks |  | 1d? | 2004-10-20 | 2004-10-20 |  |  |  | 422d |  |  |  |  |
| 433 | 8.1.3.4.3 | Complete distribution list of all regional ckey contacts for Fire GIS qualified staff |  | 1d? | 2004-10-20 | 2004-10-20 |  |  |  | 422d |  |  |  |  |
| 434 | 8.1.3.4.4 | Advise regional Fire GIS contacts re: GSTOP communciation plan and schedule |  | 1d? | 2004-10-20 | 2004-10-20 |  |  |  | 422d |  |  |  |  |
| 435 | 8.1.3.4.5 | Adjust GSTOP Communciation plan for feedback |  | 1d? | 2004-10-20 | 2004-10-20 |  |  |  | 422d |  |  |  |  |

Notes:
- 410: ESRI; they already have created their software / may happen multiple times
- 413: Text1: GSTOP Final Report
- 415: comm plan section 3: communications responsibilities/project manager
- 416: comm plan section 4.1.3 Inter-project communications
- 417: Text1: GSTOP-IBA cooperative agreement
- 418: Text1: GSTOP-GIST position dvlpmtt/trng effort cooperative agreement
- 419: Text1: GSTOP-DPRO Training cirriculum revision effort cooperative agreement
- 420: Text1: GSTOP-SIT Unit Leader SME group cooperative agreement
- 421: Text1: GSTOP-NWCG Training WT cooperative agreement
- 424: Text1: Standard form for project progress reporting
- 427: Text1: Location posted
- 433: Text1: List of all Fire GIS regional contacts
- 434: Text1: feedback

| ID | WBS | Task | Duration | Start | Finish | Predecessors | Complete | Remaining | Total slack | Free slack | Constraint | Resources | Work | Actual work | Text1 |
| --- | --- | --- | --- | --- | --- | --- | --- | --- | --- | --- | --- | --- | --- | --- | --- |
| 436 | 8.1.3.5 | **Establish process for information dissemination to Incident Management Teams via GACCs** | 1d? | 2004-10-20 | 2004-10-20 |  |  |  | 422d |  |  | Business Lead | 16h |  |  |
| 437 | 8.1.3.5.1 | Design communication and schedule (what messages, for whom when). | 0.33d? | 2004-10-20 | 2004-10-20 |  |  |  | 422.67d |  |  | Business Lead; Project Mgr; Susan Goodman | 8h |  |  |
| 438 | 8.1.3.5.2 | Advise NICC Coordinator re: planned communciations for GSTOP field test and rollout | 1d? | 2004-10-20 | 2004-10-20 |  |  |  | 422d |  |  |  |  |  | feedback |
| 439 | 8.1.3.6 | Establish process for reviewing and posting general project documents for view by project stakeholders | 1d? | 2004-10-20 | 2004-10-20 |  |  |  | 422d |  |  | Business Lead | 8h |  | GSTOP posting process (for project documents) |
| 440 | 8.1.3.7 | Establish process for developing and maintaining FAQs for GSTOP users | 1d? | 2004-10-20 | 2004-10-20 |  |  |  | 422d |  |  |  |  |  | GSTOP FAQ process (for project sponsors) |
| 441 | 8.1.3.8 | Establish process for developing and maintaining FAQ for business managers | 1d? | 2004-10-20 | 2004-10-20 |  |  |  | 422d |  |  |  |  |  | GSTOP FAQ process (for SOP users) |
| 442 | 8.1.4 | Develop a process for obtaining quantifiable feedback to evaluate the effectiveness of GSTOP communications efforts | 1d? | 2004-10-20 | 2004-10-20 |  |  |  | 422d |  |  |  |  |  |  |
| 443 | 8.2 | **Setup Project Briefings** | 2d? | 2005-01-25 A | 2005-01-26 |  |  | 2d? | 352d |  |  |  | 8h |  |  |
| 444 | 8.2.1 | Determine the set of meetings at which updates for the GSTOP project will be presented | 1d? | 2005-01-25 A | 2005-01-25 |  |  | 1d? | 352d | 0d |  | Business Lead | 8h |  | calendar of GSTOP project presentations |
| 445 | 8.2.2 | Schedule the presentations and all required logistics | 1d? | 2005-01-26 | 2005-01-26 | 444 |  |  | 352d |  |  |  |  |  |  |
| 446 | 8.3 | **Prepare Stakeholder Communications** | 1d? | 2004-10-20 | 2004-10-20 |  |  |  | 422d |  |  |  |  |  |  |
| 447 | 8.3.1 | Post general project documents for stakeholder view | 1d? | 2004-10-20 | 2004-10-20 |  |  |  | 422d |  |  |  |  |  | Project Charter, Project Plan, Staffing Plan |
| 448 | 8.3.2 | Develop GSTOP FAQs for users | 1d? | 2004-10-20 | 2004-10-20 |  |  |  | 422d |  |  |  |  |  | GSTOP FAQs for users |
| 449 | 8.3.3 | Develop GSTOP FAQs for business managers | 1d? | 2004-10-20 | 2004-10-20 |  |  |  | 422d |  |  |  |  |  | GSTOP FAQs for business managers |
| 450 | 8.3.4 | Develop GSTOP briefing(s) for GSTOP Sponsors | 1d? | 2004-10-20 | 2004-10-20 |  |  |  | 422d |  |  |  |  |  | GSTOP Sponsor Project Briefing(s) |
| 451 | 8.3.5 | Develop GSTOP briefing(s) for GSTOP Users | 1d? | 2004-10-20 | 2004-10-20 |  |  |  | 422d |  |  |  |  |  | GSTOP User Project Briefing(s) |
| 452 | 8.3.6 | Develop issue/white papers for Wildland Fire Agency Management | 1d? | 2004-10-20 | 2004-10-20 |  |  |  | 422d |  |  |  |  |  | GSTOP Issue/White Paper(s) |
| 453 | 8.3.7 | Develop GSTOP briefing(s) for Agency Technical community | 1d? | 2004-10-20 | 2004-10-20 |  |  |  | 422d |  |  |  |  |  | GSTOP Technical Briefing(s) |
| 454 | 8.3.8 | Develop standard form informational letters for general use throughout the project | 1d? | 2004-10-20 | 2004-10-20 |  |  |  | 422d |  |  |  |  |  |  |
| 455 | 8.3.9 | Develop GSTOP overview letter | 1d? | 2004-10-20 | 2004-10-20 |  |  |  | 422d |  |  |  |  |  |  |
| 456 | 8.3.10 | Develop GSTOP introduction letter soliciting input from other all-risk oganizations involved with GIS SOP development (include weblink to GSTOP project pages) | 1d? | 2004-10-20 | 2004-10-20 |  |  |  | 422d |  |  |  |  |  |  |
| 457 | 8.4 | **Conduct project briefings to stakeholders** | 356d? | 2004-10-20 A | 2006-03-01 |  | 11% | 318.53d? | 67d |  |  |  | 4144h | 685.33h |  |
| 458 | 8.4.1 | **Conduct briefings for project sponsors (when and where?)** | 251d? | 2005-03-16 A | 2006-03-01 |  | 17% | 209.17d? | 67d |  |  | IRMWT; NWCG Member Agencies | 4112h | 685.33h | Sponsor feedback |
| 459 | 8.4.1.1 | **Report to Executive Committee** | 251d? | 2005-03-16 A | 2006-03-01 |  | 17% | 209.17d? | 67d |  |  |  | 96h | 16h |  |
| 460 | 8.4.1.1.1 | 2005 Q1 Executive Briefing | 1d | 2005-03-16 A | 2005-03-16 A |  | 100% |  |  |  |  | Project Mgr; GTG Exec Comm | 16h | 16h | Executive Report |
| 461 | 8.4.1.1.2 | 2005 Q2 Executive Briefing | 1d | 2005-06-01 | 2005-06-01 |  |  |  | 262d |  | start no earlier than 2005-06-01 | Project Mgr; GTG Exec Comm | 16h |  | Executive Report |
| 462 | 8.4.1.1.3 | 2005 Q3 Executive Briefing | 1d? | 2005-09-01 | 2005-09-01 |  |  |  | 196d |  | start no earlier than 2005-09-01 | Project Mgr; GTG Exec Comm | 16h |  | Executive Report |
| 463 | 8.4.1.1.4 | 2005 Q4 Executive Briefing | 1d? | 2005-12-01 | 2005-12-01 |  |  |  | 131d |  | start no earlier than 2005-12-01 | Project Mgr; GTG Exec Comm | 16h |  | Executive Report |
| 464 | 8.4.1.1.5 | 2006 Q1 Executive Briefing | 1d? | 2006-03-01 | 2006-03-01 |  |  |  | 67d |  | start no earlier than 2006-03-01 | Project Mgr; GTG Exec Comm | 16h |  | Executive Report |
| 465 | 8.4.1.1.6 | 2006 Q2 Executive Briefing | 1d | 2005-06-01 | 2005-06-01 |  |  |  | 262d |  | start no earlier than 2005-06-01 | Project Mgr; GTG Exec Comm | 16h |  | Executive Report |

Notes:
- 442: comm plan 4.1.4 encouraging stakeholder feedback

| ID | WBS | Task | Duration | Start | Finish | Total slack | Constraint | Resources | Work | Text1 |
| --- | --- | --- | --- | --- | --- | --- | --- | --- | --- | --- |
| 466 | 8.4.2 | **Conduct project briefings at GSTOP SOP User community meetings (when and where?)** | 1d? | 2005-11-01 | 2005-11-01 | 153d |  | IMT Planning Section; Technical Specialists | 24h | GSTOP SOP User feedback |
| 467 | 8.4.2.1 | SIT Unit Leader SME meeting (where) | 1d? | 2005-11-01 | 2005-11-01 | 153d | start no earlier than 2005-11-01 | Business Lead | 8h | SIT Unit Leader SME group feedback |
| 468 | 8.4.3 | Conduct project briefings at Wildland Fire Agency Management business community meetings and conferences and agency meetings (when and where?) | 0.5d? | 2004-10-20 | 2004-10-20 | 422.5d |  | IMT Planning Section; Technical Specialists | 8h | Wildland Fire Agency Management feedback |
| 469 | 8.4.4 | **Conduct project briefings for Agency Technocal community (when and where?)** | 1d? | 2006-01-02 | 2006-01-02 | 109d |  |  |  | Agency Technical community feedback |
| 470 | 8.4.4.1 | Agency IRM meeting (where?) | 1d? | 2006-01-02 | 2006-01-02 | 109d | start no earlier than 2006-01-02 |  |  | Agency IRM feedback |
| 471 | 8.4.5 | Attend Fire Incident Mapping Tool beta test courses | 1d? | 2004-10-20 | 2004-10-20 | 422d |  |  |  | Feedback from Fire Incident Mapping Tool training |
